# MES_Contractor_Module (ex. MES_NTT_PMO)

Schedule from MS Project, 2021-01-04 to 2028-03-31, status date 2020-09-11.
MES_Vendor_Module (ex. MES_NTT_PMO)

## Calendars

- Alabama-20210111: Mon-Fri 08:00-12:00, 13:00-17:00; Sat-Sun off. Exceptions (off unless hours are given): 2021-01-18 (MLK Day), 2021-02-15 (President's Day), 2021-04-26 (Conf Mem), 2021-05-31 (Memorial Day 2021), 2021-06-07 (Jeferson Davis Bbday), 2021-07-05 (Independence Day 2021), 2021-09-06 (Labor Day 2021), 2021-10-11 (Columbus Day), 2021-11-11 (Veterans Day), 2021-11-25 (Thanksgiving Break 2021), 2021-11-26 (Thanksgiving (Friday)), 2021-12-24 (Christmas Day 2021), 2021-12-31 (New Year's Day 2022), 2022-01-03 (new years), 2022-01-17 (MLK Day), 2022-02-21 (President's Day), 2022-04-25 (Conf Mem), 2022-05-30 (Memorial Day 2022), 2022-06-06 (jeff davis bday), 2022-07-04 (Independence Day 2022), 2022-09-05 (Labor Day 2022), 2022-10-10 (Coumbus Day), 2022-11-11 (Veterans Day), 2022-11-24 (Thanksgiving Break 2022), 2022-11-25 (Thanksgiving (Friday)), 2022-12-26 (Christmas Day 2022), 2023-01-02 (New Year's Day 2023), 2023-01-16 (MLK Day), 2023-02-20 (President's Day), 2023-04-24 (Conf Mem), 2023-05-29 (Memorial Day 2023), 2023-06-05 (jeff davis bday), 2023-07-03 to 2023-07-04 (Fourth of July, recurring), 2023-07-04 (Independence Day 2023), 2023-09-04 to 2028-09-04 (Labor Day 2023, recurring), 2023-10-09 (Columbus Day), 2023-10-10 to 2029-10-08 (Columbus, recurring), 2023-11-13 (vets day), 2023-11-23 to 2028-11-23 (Thanksgiving Break 2023, recurring), 2023-11-24 (Thanksgiving (Friday)), 2023-12-25 (Christmas Day), 2024-01-01 (new years), 2024-01-15 (mlk day), 2024-02-19 to 2028-02-21 (President's Day, recurring), 2024-04-22 (Conf Mem), 2024-05-27 (mem day), 2024-06-03 (jeff davis bday), 2024-07-04 (4th), 2024-10-14 (Columbus Day), 2024-11-11 (Veterans Day, recurring), 2024-11-29 (Thanksgiving (Friday)), 2024-12-24 (Christmas Eve), 2024-12-25 (Christmas), 2025-01-01 (new years), 2025-01-20 (mlk day), 2025-04-28 (Conf Mem), 2025-05-26 (mem day), 2025-06-02 (jeff davis bday), 2025-07-04 (4th), 2025-11-10 (vets), 2025-11-28 (Thanksgiving (Friday)), 2025-12-24 (Christmas Eve), 2025-12-25 (christmas), 2026-01-01 (new years), 2026-01-19 (MLK & RELee), 2026-04-27 (Conf Mem), 2026-05-25 (mem day), 2026-06-01 (jeff davis bday), 2026-07-03 (4th), 2026-11-11 (vets), 2026-11-27 (Thanksgiving (Friday)), 2026-12-24 (Christmas Eve), 2026-12-25 (Christmas), 2027-01-01 (new years), 2027-01-18 (mlk day), 2027-04-26 (conf mem day), 2027-05-31 (mem day), 2027-06-07 (jeff davis bday), 2027-07-05 (4th), 2027-11-11 (vets), 2027-11-26 (Thanksgiving (Friday)), 2027-12-24 (christmas), 2028-01-03 (new years), 2028-01-17 (mlk).

## Schedule

| ID | WBS | Task | Type | Duration | Start | Finish | Predecessors | Total slack | Free slack | Constraint | _Current Target | _Baseline Target | _Progress % | _Projected Status | _Baseline % Status | _Days Since Update | Contract Area | _Current % Status | Text1 | _Finish Mitigation | Text19 | _Task Owner |
| --- | --- | --- | --- | --- | --- | --- | --- | --- | --- | --- | --- | --- | --- | --- | --- | --- | --- | --- | --- | --- | --- | --- |
| 1 | 1 | **External Dependencies (All XIs/XOs need to be verified by MES PMO)** |  | 180d | 2021-04-01 | 2021-12-22 |  | 0d |  |  | 0.0% | 0.0% | 0.0% | Projected Slip | Off Target | -11 | OCM | Off Target |  |  |  |  |
| 2 | 1.1 | **Incoming** |  | 0d | 2021-04-01 | 2021-04-01 |  | 0d |  |  | 0.0% | 0.0% | 0.0% | Projected Slip | On Target | -11 | OCM | Off Target |  |  |  |  |
| 3 | 1.1.1 | XI_### Task Name | milestone | 0d | 2021-04-01 | 2021-04-01 |  | 0d |  | finish no earlier than 2021-04-01 | 0.0% | 0.0% | 0.0% | No BL | No BL | -1014 | OCM | On Target |  |  |  |  |
| 4 | 1.2 | **Outgoing** |  | 0d | 2021-12-22 | 2021-12-22 |  | 1551d |  |  | 0.0% | 0.0% | 0.0% | No BL | No BL | -3 | OCM | Off Target |  |  |  |  |
| 5 | 1.2.1 | XO_### Design, Configure, and Build (DCB) - Complete | milestone | 0d | 2021-12-22 | 2021-12-22 | 752 | 1551d |  |  | 0.0% | 0.0% | 0.0% | No BL | No BL | -1014 |  | On Target |  |  |  |  |
| 6 | 2 | **Hard Dates** |  | 0d | 2021-04-01 | 2021-04-01 |  | 1290d |  |  | 0.0% | 0.0% | 0.0% | No BL | No BL | -13 | OCM | Off Target |  |  |  |  |
| 7 | 2.1 | HD: Module Contractor Project Start | milestone | 0d | 2021-04-01 | 2021-04-01 |  | 1290d | 0d | finish no earlier than 2021-04-01 | 0.0% | 0.0% | 0.0% | No BL | No BL | -1014 | OCM | On Target | -365 |  |  |  |
| 8 | 3 | **Key Milestones (List of KM will be reviewed with PMO)** |  | 290d | 2021-05-14 | 2022-07-19 |  | 1411d |  |  | 0.0% | 0.0% | 0.0% | No BL | No BL | -5 | OCM | Off Target |  |  |  |  |
| 9 | 3.1 | KM: DDI - Phase 1 - Project Approach and Scheduling Phase - Complete | milestone | 0d | 2021-05-14 | 2021-05-14 | 733 | 1701d |  |  | 0.0% | 0.0% | 0.0% | No BL | No BL | -1014 | OCM | On Target |  |  |  |  |
| 10 | 3.2 | KM: DDI - Phase 2 - Design Phase - Complete | milestone | 0d | 2021-07-14 | 2021-07-14 | 736 | 1661d |  |  | 0.0% | 0.0% | 0.0% | No BL | No BL | -1014 | OCM | On Target |  |  |  |  |
| 11 | 3.3 | KM: DDI - Phase 3 - Development Phase - Complete | milestone | 0d | 2021-10-07 | 2021-10-07 | 739 | 1601d |  |  | 0.0% | 0.0% | 0.0% | No BL | No BL | -1014 | OCM | On Target |  |  |  |  |
| 12 | 3.4 | KM: DDI - Phase 4 - Conversion Phase - Complete | milestone | 0d | 2021-10-07 | 2021-10-07 | 742 | 1601d |  |  | 0.0% | 0.0% | 0.0% | No BL | No BL | -1014 | OCM | On Target |  |  |  |  |
| 13 | 3.5 | KM: DDI - Phase 5 - Testing Phase - Complete | milestone | 0d | 2021-11-05 | 2021-11-05 | 745 | 1581d |  |  | 0.0% | 0.0% | 0.0% | No BL | No BL | -1014 | OCM | On Target |  |  |  |  |
| 14 | 3.6 | KM: DDI - Phase 6 - Implementation Phase - Complete | milestone | 0d | 2021-12-22 | 2021-12-22 | 747, 750 | 1551d |  |  | 0.0% | 0.0% | 0.0% | No BL | No BL | -1014 | OCM | On Target |  |  |  |  |
| 15 | 3.7 | KM: CMS Certification - Operations Readiness Review (Finish prior to go-Live) | milestone | 0d | 2021-12-08 | 2021-12-08 | 766, 765 | 1561d |  |  | 0.0% | 0.0% | 0.0% | No BL | No BL | -1014 |  | On Target |  |  |  |  |
| 16 | 3.8 | KM: Module Go-Live - Complete | milestone | 0d | 2021-12-22 | 2021-12-22 | 752 | 1551d |  |  | 0.0% | 0.0% | 0.0% | No BL | No BL | -1014 |  | On Target |  |  |  |  |
| 17 | 3.9 | KM: CMS Certification - Certification Review - (6 months after Go-Live) | milestone | 0d | 2022-07-19 | 2022-07-19 | 767 | 1411d |  |  | 0.0% | 0.0% | 0.0% | No BL | No BL | -1014 |  | On Target |  |  |  |  |
| 18 | 3.10 | KM: Module transition to Base MMIS Operations - Complete | milestone | 0d | 2022-07-19 | 2022-07-19 | 772, 771 | 1411d |  |  | 0.0% | 0.0% | 0.0% | No BL | No BL | -1014 |  | On Target |  |  |  |  |
| 19 | 4 | **Deliverables** |  | 297d | 2021-04-09 | 2022-06-22 |  | 1428d |  |  | 0.0% | 0.0% | 0.0% | No BL | No BL |  | PMO | Off Target |  |  |  |  |
| 20 | 4.1 | **Initial** |  | 35d | 2021-04-09 | 2021-05-28 |  | 1428d |  |  | 0.0% | 0.0% | 0.0% | No BL | No BL | -3 | PMO | Off Target |  |  |  |  |
| 21 | 4.1.1 | **Deliverable: Deliverable Name Del_ID** |  | 35d | 2021-04-09 | 2021-05-28 |  | 1428d |  |  | 0.0% | 0.0% |  |  |  |  | COM |  |  |  |  |  |
| 22 | 4.1.1.1 | Develop deliverable Del_ID |  | 12d | 2021-04-09 | 2021-04-27 |  | 1428d | 0d | start no earlier than 2021-04-09 | 0.0% | 0.0% | 0.0% | No BL | No BL | -1014 | COM | On Target | 1127 | 13 | Develop | PMO |
| 23 | 4.1.1.2 | Peer Review & QA Del_ID |  | 3d | 2021-04-28 | 2021-04-30 | 22 | 1691d | 0d |  | 0.0% | 0.0% | 0.0% | No BL | No BL | -1014 | COM | On Target | 1122 |  | Peer Review | PMO |
| 24 | 4.1.1.3 | D: Submit deliverable Del_ID | milestone | 0d | 2021-04-30 | 2021-04-30 | 23 | 1691d | 0d |  | 0.0% | 0.0% | 0.0% | No BL | No BL | -1014 | COM | On Target | 1124 |  | Submit | PMO |
| 25 | 4.1.1.4 | C: MES review of deliverable Del_ID |  | 10d | 2021-05-03 | 2021-05-14 | 24 | 1691d | 0d |  | 0.0% | 0.0% | 0.0% | No BL | No BL | -1014 | COM | On Target | 1122 | 14 | Agency Review | MES |
| 26 | 4.1.1.5 | C: Group Review of deliverable Del_ID |  | 1d | 2021-05-10 | 2021-05-10 | 24FS+5d | 1695d | 4d |  | 0.0% | 0.0% | 0.0% | No BL | No BL | -1014 | COM | On Target | 1122 |  |  | MES |
| 27 | 4.1.1.6 | D: NTT Data update based on MES feedback - deliverable Del_ID |  | 5d | 2021-05-17 | 2021-05-21 | 25, 26 | 1691d | 0d |  | 0.0% | 0.0% | 0.0% | No BL | No BL | -1014 | COM | On Target | 1122 |  | Update | PMO |
| 28 | 4.1.1.7 | D: Resubmit deliverable Del_ID | milestone | 0d | 2021-05-21 | 2021-05-21 | 27 | 1691d | 0d |  | 0.0% | 0.0% | 0.0% | No BL | No BL | -1014 | COM | On Target | 1124 |  | Resubmit | PMO |
| 29 | 4.1.1.8 | C: MES review and approval of deliverable Del_ID |  | 5d | 2021-05-24 | 2021-05-28 | 28 | 1691d | 0d |  | 0.0% | 0.0% | 0.0% | No BL | No BL | -1014 | COM | On Target | 1122 |  | Review/Approval | MES |
| 30 | 4.1.1.9 | M: MES approval of deliverable Del_ID | milestone | 0d | 2021-05-28 | 2021-05-28 | 29 | 1691d | 0d |  | 0.0% | 0.0% | 0.0% | No BL | No BL | -1014 | COM | On Target | 1124 |  |  | MES |

Notes:
- 1: To ensure integration between schedules, as well as the Integrated Master Schedule, each schedule contains Incoming and Outgoing Dependencies (0d duration tasks). These dependencies are milestones in a schedule that have an impact on another schedule. The naming convention for each type of dependency is as follow: / ·Outgoing - XO_###_Dependency Task Name / ·Incoming - XI_Module Acronym_###_Dependency Task Name
- 3: External Incoming Dependency from Schedule (Successors within this schedule)
- 4: Ranges: EVV-500, SI-600, EDW-700, Core-800
- 6: Rarely used, but available (Project Start is a valid example)
- 8: Though there are many milestones, Key Milestones mark an important/significant event in a project. They provide clear visibility into significant events, in which the MES PMO monitors closely. Key Milestones are identified in collaboration with the MES PMO.
- 9: Example
- 10: Example
- 11: Example
- 12: Example
- 13: Example
- 14: Example
- 15: Example
- 16: Example
- 17: Example
- 18: Example
- 19: Deliverables are maintained under the Level 1 task, Deliverables. Each Modules schedule will use the custom Text19 (Deliverable Activity) field to identify specific deliverable activity. The benefit of this configuration is to easily determine when deliverables are submitted, reviewed, approved, etc.. This setup has already been established in the within the Integrated Master Schedule template.
- 21: 6 months

| ID | WBS | Task | Type | Duration | Start | Finish | Predecessors | Total slack | Free slack | Constraint | _Current Target | _Baseline Target | Contract Area | Text1 | _Progress % | _Projected Status | _Baseline % Status | _Days Since Update | _Current % Status | _Finish Mitigation | Text19 | _Task Owner |
| --- | --- | --- | --- | --- | --- | --- | --- | --- | --- | --- | --- | --- | --- | --- | --- | --- | --- | --- | --- | --- | --- | --- |
| 31 | 4.1.2 | **Deliverable: Deliverable Name Del_ID2** |  | 35d | 2021-04-09 | 2021-05-28 |  | 1691d |  |  | 0.0% | 0.0% | COM |  |  |  |  |  |  |  |  |  |
| 32 | 4.1.2.1 | Develop deliverable Del_ID2 |  | 12d | 2021-04-09 | 2021-04-27 |  | 1691d | 0d | start no earlier than 2021-04-09 | 0.0% | 0.0% | COM | 1127 | 0.0% | No BL | No BL | -1014 | On Target | 13 | Develop | PMO |
| 33 | 4.1.2.2 | Peer Review & QA Del_ID2 |  | 3d | 2021-04-28 | 2021-04-30 | 32 | 1691d | 0d |  | 0.0% | 0.0% | COM | 1122 | 0.0% | No BL | No BL | -1014 | On Target |  | Peer Review | PMO |
| 34 | 4.1.2.3 | D: Submit deliverable Del_ID2 | milestone | 0d | 2021-04-30 | 2021-04-30 | 33 | 1691d | 0d |  | 0.0% | 0.0% | COM | 1124 | 0.0% | No BL | No BL | -1014 | On Target |  | Submit | PMO |
| 35 | 4.1.2.4 | C: MES review of deliverable Del_ID2 |  | 10d | 2021-05-03 | 2021-05-14 | 34 | 1691d | 0d |  | 0.0% | 0.0% | COM | 1122 | 0.0% | No BL | No BL | -1014 | On Target | 14 | Agency Review | MES |
| 36 | 4.1.2.5 | C: Group Review of deliverable Del_ID2 |  | 1d | 2021-05-10 | 2021-05-10 | 34FS+5d | 1695d | 4d |  | 0.0% | 0.0% | COM | 1122 | 0.0% | No BL | No BL | -1014 | On Target |  |  | MES |
| 37 | 4.1.2.6 | D: NTT Data update based on MES feedback - deliverable Del_ID2 |  | 5d | 2021-05-17 | 2021-05-21 | 35, 36 | 1691d | 0d |  | 0.0% | 0.0% | COM | 1122 | 0.0% | No BL | No BL | -1014 | On Target |  | Update | PMO |
| 38 | 4.1.2.7 | D: Resubmit deliverable Del_ID2 | milestone | 0d | 2021-05-21 | 2021-05-21 | 37 | 1691d | 0d |  | 0.0% | 0.0% | COM | 1124 | 0.0% | No BL | No BL | -1014 | On Target |  | Resubmit | PMO |
| 39 | 4.1.2.8 | C: MES review and approval of deliverable Del_ID2 |  | 5d | 2021-05-24 | 2021-05-28 | 38 | 1691d | 0d |  | 0.0% | 0.0% | COM | 1122 | 0.0% | No BL | No BL | -1014 | On Target |  | Review/Approval | MES |
| 40 | 4.1.2.9 | M: MES approval of deliverable Del_ID2 | milestone | 0d | 2021-05-28 | 2021-05-28 | 39 | 1691d | 0d |  | 0.0% | 0.0% | COM | 1124 | 0.0% | No BL | No BL | -1014 | On Target |  |  | MES |
| 41 | 4.1.3 | M: Initial - Completed | milestone | 0d | 2021-05-28 | 2021-05-28 | 30, 40, 77 | 1691d | 262d |  | 0.0% | 0.0% | COM | -422 | 0.0% | No BL | No BL | -1014 | On Target |  |  | PgMgr |
| 42 | 4.2 | **Every # months (Should be replicated based on Frequency expectation from RFB/RFP 1, 3, 6 months, etc…)** |  | 162d | 2021-10-25 | 2022-06-22 |  | 1428d |  |  | 0.0% | 0.0% |  |  | 0.0% | No BL | No BL | -74 | Off Target |  |  |  |
| 43 | 4.2.1 | **Deliverable Name Del_ID** |  | 162d | 2021-10-25 | 2022-06-22 |  | 1428d |  |  | 0.0% | 0.0% |  |  | 0.0% | No BL | No BL | -74 | Off Target |  |  |  |
| 44 | 4.2.1.1 | **Deliverable: Deliverable Name Del_ID** |  | 33d | 2021-10-25 | 2021-12-13 |  | 1428d |  |  | 0.0% | 0.0% | COM |  |  |  |  |  |  |  |  |  |
| 45 | 4.2.1.1.1 | Develop deliverable Del_ID |  | 10d | 2021-10-25 | 2021-11-05 | 22FS+6emo | 1428d | 0d | start no earlier than 2021-04-09 | 0.0% | 0.0% | COM | 928 | 0.0% | No BL | No BL | -1014 | On Target | 13 | Develop | PMO |
| 46 | 4.2.1.1.2 | Peer Review & QA Del_ID |  | 3d | 2021-11-08 | 2021-11-10 | 45 | 1558d | 0d |  | 0.0% | 0.0% | COM | 928 | 0.0% | No BL | No BL | -1014 | On Target |  | Peer Review | PMO |
| 47 | 4.2.1.1.3 | D: Submit deliverable Del_ID | milestone | 0d | 2021-11-10 | 2021-11-10 | 46 | 1558d | 0d |  | 0.0% | 0.0% | COM | 930 | 0.0% | No BL | No BL | -1014 | On Target |  | Submit | PMO |
| 48 | 4.2.1.1.4 | C: MES review of deliverable Del_ID |  | 10d | 2021-11-12 | 2021-11-29 | 47 | 1558d | 0d |  | 0.0% | 0.0% | COM | 929 | 0.0% | No BL | No BL | -1014 | On Target | 14 | Agency Review | MES |
| 49 | 4.2.1.1.5 | C: Group Review of deliverable Del_ID |  | 1d | 2021-11-19 | 2021-11-19 | 47FS+5d | 1562d | 4d |  | 0.0% | 0.0% | COM | 929 | 0.0% | No BL | No BL | -1014 | On Target |  |  | MES |
| 50 | 4.2.1.1.6 | D: NTT Data update based on MES feedback - deliverable Del_ID |  | 5d | 2021-11-30 | 2021-12-06 | 48, 49 | 1558d | 0d |  | 0.0% | 0.0% | COM | 925 | 0.0% | No BL | No BL | -1014 | On Target |  | Update | PMO |
| 51 | 4.2.1.1.7 | D: Resubmit deliverable Del_ID | milestone | 0d | 2021-12-06 | 2021-12-06 | 50 | 1558d | 0d |  | 0.0% | 0.0% | COM | 925 | 0.0% | No BL | No BL | -1014 | On Target |  | Resubmit | PMO |
| 52 | 4.2.1.1.8 | C: MES review and approval of deliverable Del_ID |  | 5d | 2021-12-07 | 2021-12-13 | 51 | 1558d | 0d |  | 0.0% | 0.0% | COM | 925 | 0.0% | No BL | No BL | -1014 | On Target |  | Review/Approval | MES |
| 53 | 4.2.1.1.9 | M: MES approval of deliverable Del_ID | milestone | 0d | 2021-12-13 | 2021-12-13 | 52 | 1558d | 129d |  | 0.0% | 0.0% | COM | 925 | 0.0% | No BL | No BL | -1014 | On Target |  |  | MES |
| 54 | 4.2.1.2 | **Deliverable: Deliverable Name Del_ID** |  | 33d | 2022-05-05 | 2022-06-22 |  | 1429d |  |  | 0.0% | 0.0% | COM |  |  |  |  |  |  |  |  |  |
| 55 | 4.2.1.2.1 | Develop deliverable Del_ID |  | 10d | 2022-05-05 | 2022-05-18 | 45FS+6emo | 1429d | 0d | start no earlier than 2021-04-09 | 0.0% | 0.0% | COM | 736 | 0.0% | No BL | No BL | -1014 | On Target | 13 | Develop | PMO |
| 56 | 4.2.1.2.2 | Peer Review & QA Del_ID |  | 3d | 2022-05-19 | 2022-05-23 | 55 | 1429d | 0d |  | 0.0% | 0.0% | COM | 736 | 0.0% | No BL | No BL | -1014 | On Target |  | Peer Review | PMO |
| 57 | 4.2.1.2.3 | D: Submit deliverable Del_ID | milestone | 0d | 2022-05-23 | 2022-05-23 | 56 | 1429d | 0d |  | 0.0% | 0.0% | COM | 736 | 0.0% | No BL | No BL | -1014 | On Target |  | Submit | PMO |
| 58 | 4.2.1.2.4 | C: MES review of deliverable Del_ID |  | 10d | 2022-05-24 | 2022-06-08 | 57 | 1429d | 0d |  | 0.0% | 0.0% | COM | 736 | 0.0% | No BL | No BL | -1014 | On Target | 14 | Agency Review | MES |
| 59 | 4.2.1.2.5 | C: Group Review of deliverable Del_ID |  | 1d | 2022-06-01 | 2022-06-01 | 57FS+5d | 1433d | 4d |  | 0.0% | 0.0% | COM | 735 | 0.0% | No BL | No BL | -1014 | On Target |  |  | MES |
| 60 | 4.2.1.2.6 | D: NTT Data update based on MES feedback - deliverable Del_ID |  | 5d | 2022-06-09 | 2022-06-15 | 58, 59 | 1429d | 0d |  | 0.0% | 0.0% | COM | 734 | 0.0% | No BL | No BL | -1014 | On Target |  | Update | PMO |
| 61 | 4.2.1.2.7 | D: Resubmit deliverable Del_ID | milestone | 0d | 2022-06-15 | 2022-06-15 | 60 | 1429d | 0d |  | 0.0% | 0.0% | COM | 734 | 0.0% | No BL | No BL | -1014 | On Target |  | Resubmit | PMO |
| 62 | 4.2.1.2.8 | C: MES review and approval of deliverable Del_ID |  | 5d | 2022-06-16 | 2022-06-22 | 61 | 1429d | 0d |  | 0.0% | 0.0% | COM | 734 | 0.0% | No BL | No BL | -1014 | On Target |  | Review/Approval | MES |
| 63 | 4.2.1.2.9 | M: MES approval of deliverable Del_ID | milestone | 0d | 2022-06-22 | 2022-06-22 | 62 | 1429d | 0d |  | 0.0% | 0.0% | COM | 734 | 0.0% | No BL | No BL | -1014 | On Target |  |  | MES |
| 64 | 4.2.2 | M: Every 6 months - Complete | milestone | 0d | 2022-06-22 | 2022-06-22 | 41, 53, 63 | 1429d |  |  | 0.0% | 0.0% |  | -572 | 0.0% | No BL | No BL | -1014 | On Target |  |  | PgMgr |

Notes:
- 31: 6 months
- 44: 6 months
- 54: 6 months

| ID | WBS | Task | Type | Duration | Start | Finish | Predecessors | Total slack | Free slack | _Current Target | _Baseline Target | _Progress % | _Projected Status | _Baseline % Status | _Days Since Update | Contract Area | _Current % Status | _Finish Mitigation | _Task Owner | Text1 | Text19 |
| --- | --- | --- | --- | --- | --- | --- | --- | --- | --- | --- | --- | --- | --- | --- | --- | --- | --- | --- | --- | --- | --- |
| 65 | 5 | **Project Management** |  | 799d | 2021-01-04 | 2024-03-25 |  | 994d |  | 0.0% | 0.0% | 0.0% | No BL | No BL | -8 | PMO | Off Target |  |  |  |  |
| 66 | 5.1 | **Vendor/Contractor Startup (PMO-2-o)** |  | 97d | 2021-01-06 | 2021-05-25 |  | 1694d |  | 0.0% | 0.0% | 0.0% | No BL | No BL | -81 |  | Off Target |  |  |  |  |
| 67 | 5.1.1 | **Contract Monitoring** |  | 48d | 2021-01-06 | 2021-03-16 |  | 1743d |  | 0.0% | 0.0% | 0.0% | Tracking to BL | Off Target |  | PMO | Off Target | 42 | Module Vendor |  |  |
| 68 | 5.1.1.1 | Review Contract Monitor Plan |  | 5d | 2021-01-06 | 2021-01-12 | 7FS-60d | 1743d | 0d | 0.0% | 0.0% | 0.0% | No BL | No BL | -1014 |  | On Target |  | Jane Doe |  |  |
| 69 | 5.1.1.2 | Develop Contract Matrix |  | 20d | 2021-01-13 | 2021-02-10 | 68 | 1743d | 0d | 0.0% | 0.0% | 0.0% | No BL | No BL | -1014 | COM | On Target | 13 | Jane Doe | 1213 | Develop |
| 70 | 5.1.1.3 | Peer Review & QA Contract Matrix |  | 3d | 2021-02-11 | 2021-02-16 | 69 | 1743d | 0d | 0.0% | 0.0% | 0.0% | No BL | No BL | -1014 | COM | On Target |  | Jane Doe | 1198 | Peer Review |
| 71 | 5.1.1.4 | D: Submit deliverable Contract Matrix | milestone | 0d | 2021-02-16 | 2021-02-16 | 70 | 1743d | 0d | 0.0% | 0.0% | 0.0% | No BL | No BL | -1014 | COM | On Target |  | Jane Doe | 1197 | Submit |
| 72 | 5.1.1.5 | C: MES review of deliverable Contract Matrix |  | 10d | 2021-02-17 | 2021-03-02 | 71 | 1743d | 0d | 0.0% | 0.0% | 0.0% | No BL | No BL | -1014 | COM | On Target | 14 | MES PMO | 1197 | Agency Review |
| 73 | 5.1.1.6 | C: Group Review of deliverable Contract Matrix |  | 1d | 2021-02-24 | 2021-02-24 | 71FS+5d | 1747d | 4d | 0.0% | 0.0% | 0.0% | No BL | No BL | -1014 | COM | On Target |  | MES | 1197 |  |
| 74 | 5.1.1.7 | D: NTT Data update based on MES feedback - deliverable Contract Matrix |  | 5d | 2021-03-03 | 2021-03-09 | 72, 73 | 1743d | 0d | 0.0% | 0.0% | 0.0% | No BL | No BL | -1014 | COM | On Target |  | PMO | 1197 | Update |
| 75 | 5.1.1.8 | D: Resubmit deliverable Contract Matrix | milestone | 0d | 2021-03-09 | 2021-03-09 | 74 | 1743d | 0d | 0.0% | 0.0% | 0.0% | No BL | No BL | -1014 | COM | On Target |  | PMO | 1197 | Resubmit |
| 76 | 5.1.1.9 | C: MES review and approval of deliverable Contract Matrix |  | 5d | 2021-03-10 | 2021-03-16 | 75 | 1743d | 0d | 0.0% | 0.0% | 0.0% | No BL | No BL | -1014 | COM | On Target |  | MES | 1197 | Review/Approval |
| 77 | 5.1.1.10 | M: MES approval of deliverable Contract Matrix | milestone | 0d | 2021-03-16 | 2021-03-16 | 76 | 1743d | 0d | 0.0% | 0.0% | 0.0% | No BL | No BL | -1014 | COM | On Target |  | MES | 1197 |  |
| 78 | 5.1.1.11 | M: Contract Monitoring | milestone | 0d | 2021-03-16 | 2021-03-16 | 77 | 1743d |  | 0.0% | 0.0% | 0.0% | No BL | No BL | -1014 | PMO | On Target |  | PgMgr | -307 |  |
| 79 | 5.1.2 | **Contractor Start-up (See PMO-2-o-02 Contractor Start_Up_Checklist, for details)** |  | 97d | 2021-01-06 | 2021-05-25 |  | 1694d |  | 0.0% | 0.0% | 0.0% | No BL | No BL | -81 |  | Off Target |  |  |  |  |
| 80 | 5.1.2.1 | Knowledge Transfer of Contractor Startup (PMO to PM/Program Manager) |  | 5d | 2021-01-06 | 2021-01-12 | 7FS-3mo | 1785d | 0d | 0.0% | 0.0% | 0.0% | No BL | No BL | -1014 |  | On Target |  |  |  |  |
| 81 | 5.1.2.2 | Begin Status Reporting of Contract Startup Activities (Monthly Status Report) |  | 1d | 2021-01-13 | 2021-01-13 | 80 | 1785d |  | 0.0% | 0.0% | 0.0% | No BL | No BL | -1014 |  | On Target |  |  |  |  |
| 82 | 5.1.2.3 | **Checklist Items - Key Items** |  | 77d | 2021-02-04 | 2021-05-25 |  | 1694d |  | 0.0% | 0.0% | 0.0% | No BL | No BL | -497 |  | On Target |  |  |  |  |
| 83 | 5.1.2.3.1 | Load/Review Requirements |  | 1d | 2021-02-04 | 2021-02-04 | 7FS-2mo | 1770d |  | 0.0% | 0.0% | 0.0% | No BL | No BL | -1014 |  | On Target |  |  |  |  |
| 84 | 5.1.2.3.2 | Internal Review of RFB/RFP |  | 1d | 2021-02-04 | 2021-02-04 | 7FS-2mo | 1770d |  | 0.0% | 0.0% | 0.0% | No BL | No BL | -1014 |  | On Target |  |  |  |  |
| 85 | 5.1.2.3.3 | Coordinate Demo |  | 1d | 2021-03-19 | 2021-03-19 | 7FS-2w | 1740d |  | 0.0% | 0.0% | 0.0% | No BL | No BL | -1014 |  | On Target |  |  |  |  |
| 86 | 5.1.2.3.4 | Contractor Kick-off |  | 1d | 2021-04-16 | 2021-04-16 | 7FS+2w | 1694d | 0d | 0.0% | 0.0% | 0.0% | No BL | No BL | -1014 |  | On Target |  |  |  |  |
| 87 | 5.1.2.3.5 | Contractor Demo |  | 1d | 2021-04-16 | 2021-04-16 | 7FS+2w | 1720d |  | 0.0% | 0.0% | 0.0% | No BL | No BL | -1014 |  | On Target |  |  |  |  |
| 88 | 5.1.2.3.6 | OCM Kick-off |  | 1d | 2021-05-03 | 2021-05-03 | 7FS+4w | 1710d |  | 0.0% | 0.0% | 0.0% | No BL | No BL | -1014 |  | On Target |  |  |  |  |
| 89 | 5.1.2.3.7 | Contract Discovery Sessions - RFB/RFP Review |  | 3w | 2021-05-04 | 2021-05-24 | 7FS+2w, 86FS+2w | 1694d | 0d | 0.0% | 0.0% | 0.0% | No BL | No BL | -1014 |  | On Target |  |  |  |  |
| 90 | 5.1.2.3.8 | Requirement Sessions |  | 1d | 2021-05-25 | 2021-05-25 | 7FS+6w, 89 | 1694d |  | 0.0% | 0.0% | 0.0% | No BL | No BL | -1014 |  | On Target |  |  |  |  |

| ID | WBS | Task | Duration | Start | Finish | Predecessors | Total slack | _Current Target | _Baseline Target | _Progress % | _Projected Status | _Baseline % Status | _Days Since Update | _Current % Status |
| --- | --- | --- | --- | --- | --- | --- | --- | --- | --- | --- | --- | --- | --- | --- |
| 91 | 5.1.2.4 | **Checklist Items** | 81d | 2021-01-06 | 2021-05-03 |  | 1710d | 0.0% | 0.0% | 0.0% | No BL | No BL | -497 | On Target |
| 92 | 5.1.2.4.1 | **Tools Checklist** | 66d | 2021-01-06 | 2021-04-09 |  | 1725d | 0.0% | 0.0% | 0.0% | No BL | No BL | -497 | On Target |
| 93 | 5.1.2.4.1.1 | SharePoint Implementation | 1d | 2021-01-06 | 2021-01-06 | 7FS-3mo | 1790d | 0.0% | 0.0% | 0.0% | No BL | No BL | -1014 | On Target |
| 94 | 5.1.2.4.1.2 | SharePoint Review | 1d | 2021-04-09 | 2021-04-09 | 7FS+1w | 1725d | 0.0% | 0.0% | 0.0% | No BL | No BL | -1014 | On Target |
| 95 | 5.1.2.4.1.3 | Executive Dashboard | 1d | 2021-01-06 | 2021-01-06 | 7FS-3mo | 1790d | 0.0% | 0.0% | 0.0% | No BL | No BL | -1014 | On Target |
| 96 | 5.1.2.4.1.4 | Report Card | 1d | 2021-01-06 | 2021-01-06 | 7FS-3mo | 1790d | 0.0% | 0.0% | 0.0% | No BL | No BL | -1014 | On Target |
| 97 | 5.1.2.4.1.5 | Access Information | 1d | 2021-03-12 | 2021-03-12 | 7FS-3w | 1745d | 0.0% | 0.0% | 0.0% | No BL | No BL | -1014 | On Target |
| 98 | 5.1.2.4.2 | **Site Checklist** | 1d | 2021-03-12 | 2021-03-12 |  | 1745d | 0.0% | 0.0% | 0.0% | No BL | No BL | -497 | On Target |
| 99 | 5.1.2.4.2.1 | Request office space information | 1d | 2021-03-12 | 2021-03-12 | 7FS-3w | 1745d | 0.0% | 0.0% | 0.0% | No BL | No BL | -1014 | On Target |
| 100 | 5.1.2.4.2.2 | Parking Responsibility | 1d | 2021-03-12 | 2021-03-12 | 7FS-3w | 1745d | 0.0% | 0.0% | 0.0% | No BL | No BL | -1014 | On Target |
| 101 | 5.1.2.4.2.3 | Request building access information | 1d | 2021-03-12 | 2021-03-12 | 7FS-3w | 1745d | 0.0% | 0.0% | 0.0% | No BL | No BL | -1014 | On Target |
| 102 | 5.1.2.4.3 | **PMO Checklist** | 31d | 2021-03-05 | 2021-04-16 |  | 1720d | 0.0% | 0.0% | 0.0% | No BL | No BL | -497 | On Target |
| 103 | 5.1.2.4.3.1 | Request staffing information | 1d | 2021-03-12 | 2021-03-12 | 7FS-3w | 1745d | 0.0% | 0.0% | 0.0% | No BL | No BL | -1014 | On Target |
| 104 | 5.1.2.4.3.2 | Review Templates | 1d | 2021-04-09 | 2021-04-09 | 7FS+1w | 1725d | 0.0% | 0.0% | 0.0% | No BL | No BL | -1014 | On Target |
| 105 | 5.1.2.4.3.3 | Send MES Newsletters | 1d | 2021-04-01 | 2021-04-01 | 7FS-1d | 1731d | 0.0% | 0.0% | 0.0% | No BL | No BL | -1014 | On Target |
| 106 | 5.1.2.4.3.4 | Send PMO-2-b Onboarding Plan and Checklist | 1d | 2021-04-01 | 2021-04-01 | 7FS-1d | 1731d | 0.0% | 0.0% | 0.0% | No BL | No BL | -1014 | On Target |
| 107 | 5.1.2.4.3.5 | Assign Specific Contractor Employees to Committees | 1d | 2021-04-09 | 2021-04-09 | 7FS+1w | 1725d | 0.0% | 0.0% | 0.0% | No BL | No BL | -1014 | On Target |
| 108 | 5.1.2.4.3.6 | Invoice Review | 1d | 2021-04-16 | 2021-04-16 | 7FS+2w | 1720d | 0.0% | 0.0% | 0.0% | No BL | No BL | -1014 | On Target |
| 109 | 5.1.2.4.3.7 | Start Reporting on Contractor Start-up | 1d | 2021-03-05 | 2021-03-05 | 7FS-1mo | 1750d | 0.0% | 0.0% | 0.0% | No BL | No BL | -1014 | On Target |
| 110 | 5.1.2.4.4 | **Meetings (Recurring)** | 36d | 2021-03-12 | 2021-05-03 |  | 1710d | 0.0% | 0.0% | 0.0% | No BL | No BL | -497 | On Target |
| 111 | 5.1.2.4.4.1 | Review Meeting Protocol | 1d | 2021-04-09 | 2021-04-09 | 7FS+1w | 1725d | 0.0% | 0.0% | 0.0% | No BL | No BL | -1014 | On Target |
| 112 | 5.1.2.4.4.2 | Meeting Attendees | 1d | 2021-03-12 | 2021-03-12 | 7FS-3w | 1745d | 0.0% | 0.0% | 0.0% | No BL | No BL | -1014 | On Target |
| 113 | 5.1.2.4.4.3 | Add Contractor employees to meetings | 1d | 2021-04-16 | 2021-04-16 | 7FS+2w | 1720d | 0.0% | 0.0% | 0.0% | No BL | No BL | -1014 | On Target |
| 114 | 5.1.2.4.4.4 | Program Status Report/Meeting | 1d | 2021-05-03 | 2021-05-03 | 7FS+4w | 1710d | 0.0% | 0.0% | 0.0% | No BL | No BL | -1014 | On Target |
| 115 | 5.1.2.4.4.5 | Contractor Status Meetings | 1d | 2021-05-03 | 2021-05-03 | 7FS+4w | 1710d | 0.0% | 0.0% | 0.0% | No BL | No BL | -1014 | On Target |
| 116 | 5.1.2.4.4.6 | Send Upcoming Event Calendar | 1d | 2021-03-26 | 2021-03-26 | 7FS-1w | 1735d | 0.0% | 0.0% | 0.0% | No BL | No BL | -1014 | On Target |

| ID | WBS | Task | Duration | Start | Finish | Total slack | Constraint | _Current Target | _Baseline Target | _Progress % | _Projected Status | _Baseline % Status | _Days Since Update | _Current % Status |
| --- | --- | --- | --- | --- | --- | --- | --- | --- | --- | --- | --- | --- | --- | --- |
| 117 | 5.2 | **Recurring Activities** | 798d | 2021-01-04 | 2024-03-22 | 995d |  | 0.0% | 0.0% | 0.0% | No BL | No BL | -97 | Off Target |
| 118 | 5.2.1 | **Contract Monitoring (Gather and Reporting)** | 480d | 2021-06-14 | 2023-05-19 | 1203d |  | 0.0% | 0.0% |  |  |  |  |  |
| 119 | 5.2.1.1 | Contract Monitoring (Gather and Reporting) 1 | 10d | 2021-06-14 | 2021-06-25 | 1673d | start no earlier than 2021-06-14 | 0.0% | 0.0% | 0.0% | No BL | No BL | -1014 | On Target |
| 120 | 5.2.1.2 | Contract Monitoring (Gather and Reporting) 2 | 10d | 2021-07-12 | 2021-07-23 | 1654d | start no earlier than 2021-07-12 | 0.0% | 0.0% | 0.0% | No BL | No BL | -1014 | On Target |
| 121 | 5.2.1.3 | Contract Monitoring (Gather and Reporting) 3 | 10d | 2021-08-09 | 2021-08-20 | 1634d | start no earlier than 2021-08-09 | 0.0% | 0.0% | 0.0% | No BL | No BL | -1014 | On Target |
| 122 | 5.2.1.4 | Contract Monitoring (Gather and Reporting) 4 | 10d | 2021-09-13 | 2021-09-24 | 1610d | start no earlier than 2021-09-13 | 0.0% | 0.0% | 0.0% | No BL | No BL | -1014 | On Target |
| 123 | 5.2.1.5 | Contract Monitoring (Gather and Reporting) 5 | 10d | 2021-10-12 | 2021-10-25 | 1590d | start no earlier than 2021-10-11 | 0.0% | 0.0% | 0.0% | No BL | No BL | -1014 | On Target |
| 124 | 5.2.1.6 | Contract Monitoring (Gather and Reporting) 6 | 10d | 2021-11-08 | 2021-11-22 | 1571d | start no earlier than 2021-11-08 | 0.0% | 0.0% | 0.0% | No BL | No BL | -1014 | On Target |
| 125 | 5.2.1.7 | Contract Monitoring (Gather and Reporting) 7 | 10d | 2021-12-13 | 2021-12-27 | 1549d | start no earlier than 2021-12-13 | 0.0% | 0.0% | 0.0% | No BL | No BL | -1014 | On Target |
| 126 | 5.2.1.8 | Contract Monitoring (Gather and Reporting) 8 | 10d | 2022-01-10 | 2022-01-24 | 1532d | start no earlier than 2022-01-10 | 0.0% | 0.0% | 0.0% | No BL | No BL | -1014 | On Target |
| 127 | 5.2.1.9 | Contract Monitoring (Gather and Reporting) 9 | 10d | 2022-02-14 | 2022-02-28 | 1508d | start no earlier than 2022-02-14 | 0.0% | 0.0% | 0.0% | No BL | No BL | -1014 | On Target |
| 128 | 5.2.1.10 | Contract Monitoring (Gather and Reporting) 10 | 10d | 2022-03-14 | 2022-03-25 | 1489d | start no earlier than 2022-03-14 | 0.0% | 0.0% | 0.0% | No BL | No BL | -1014 | On Target |
| 129 | 5.2.1.11 | Contract Monitoring (Gather and Reporting) 11 | 10d | 2022-04-11 | 2022-04-22 | 1469d | start no earlier than 2022-04-11 | 0.0% | 0.0% | 0.0% | No BL | No BL | -1014 | On Target |
| 130 | 5.2.1.12 | Contract Monitoring (Gather and Reporting) 12 | 10d | 2022-05-09 | 2022-05-20 | 1450d | start no earlier than 2022-05-09 | 0.0% | 0.0% | 0.0% | No BL | No BL | -1014 | On Target |
| 131 | 5.2.1.13 | Contract Monitoring (Gather and Reporting) 13 | 10d | 2022-06-13 | 2022-06-24 | 1427d | start no earlier than 2022-06-13 | 0.0% | 0.0% | 0.0% | No BL | No BL | -1014 | On Target |
| 132 | 5.2.1.14 | Contract Monitoring (Gather and Reporting) 14 | 10d | 2022-07-11 | 2022-07-22 | 1408d | start no earlier than 2022-07-11 | 0.0% | 0.0% | 0.0% | No BL | No BL | -1014 | On Target |
| 133 | 5.2.1.15 | Contract Monitoring (Gather and Reporting) 15 | 10d | 2022-08-08 | 2022-08-19 | 1388d | start no earlier than 2022-08-08 | 0.0% | 0.0% | 0.0% | No BL | No BL | -1014 | On Target |
| 134 | 5.2.1.16 | Contract Monitoring (Gather and Reporting) 16 | 10d | 2022-09-12 | 2022-09-23 | 1364d | start no earlier than 2022-09-12 | 0.0% | 0.0% | 0.0% | No BL | No BL | -1014 | On Target |
| 135 | 5.2.1.17 | Contract Monitoring (Gather and Reporting) 17 | 10d | 2022-10-11 | 2022-10-24 | 1344d | start no earlier than 2022-10-10 | 0.0% | 0.0% | 0.0% | No BL | No BL | -1014 | On Target |
| 136 | 5.2.1.18 | Contract Monitoring (Gather and Reporting) 18 | 10d | 2022-11-14 | 2022-11-29 | 1321d | start no earlier than 2022-11-14 | 0.0% | 0.0% | 0.0% | No BL | No BL | -1014 | On Target |
| 137 | 5.2.1.19 | Contract Monitoring (Gather and Reporting) 19 | 10d | 2022-12-12 | 2022-12-23 | 1303d | start no earlier than 2022-12-12 | 0.0% | 0.0% | 0.0% | No BL | No BL | -1014 | On Target |
| 138 | 5.2.1.20 | Contract Monitoring (Gather and Reporting) 20 | 10d | 2023-01-09 | 2023-01-23 | 1285d | start no earlier than 2023-01-09 | 0.0% | 0.0% | 0.0% | No BL | No BL | -1014 | On Target |
| 139 | 5.2.1.21 | Contract Monitoring (Gather and Reporting) 21 | 10d | 2023-02-13 | 2023-02-27 | 1261d | start no earlier than 2023-02-13 | 0.0% | 0.0% | 0.0% | No BL | No BL | -1014 | On Target |
| 140 | 5.2.1.22 | Contract Monitoring (Gather and Reporting) 22 | 10d | 2023-03-13 | 2023-03-24 | 1242d | start no earlier than 2023-03-13 | 0.0% | 0.0% | 0.0% | No BL | No BL | -1014 | On Target |
| 141 | 5.2.1.23 | Contract Monitoring (Gather and Reporting) 23 | 10d | 2023-04-10 | 2023-04-21 | 1222d | start no earlier than 2023-04-10 | 0.0% | 0.0% | 0.0% | No BL | No BL | -1014 | On Target |
| 142 | 5.2.1.24 | Contract Monitoring (Gather and Reporting) 24 | 10d | 2023-05-08 | 2023-05-19 | 1203d | start no earlier than 2023-05-08 | 0.0% | 0.0% | 0.0% | No BL | No BL | -1014 | On Target |

| ID | WBS | Task | Duration | Start | Finish | Total slack | Constraint | _Current Target | _Baseline Target | _Progress % | _Projected Status | _Baseline % Status | _Days Since Update | _Current % Status |
| --- | --- | --- | --- | --- | --- | --- | --- | --- | --- | --- | --- | --- | --- | --- |
| 143 | 5.2.2 | **Schedule Updates/Uploads** | 736d | 2021-04-02 | 2024-03-22 | 995d |  | 0.0% | 0.0% |  |  |  |  |  |
| 144 | 5.2.2.1 | Schedule Uploads 1 | 1d | 2021-04-02 | 2021-04-02 | 1730d | start no earlier than 2021-04-02 | 0.0% | 0.0% | 0.0% | No BL | No BL | -1014 | On Target |
| 145 | 5.2.2.2 | Schedule Uploads 2 | 1d | 2021-04-09 | 2021-04-09 | 1725d | start no earlier than 2021-04-09 | 0.0% | 0.0% | 0.0% | No BL | No BL | -1014 | On Target |
| 146 | 5.2.2.3 | Schedule Uploads 3 | 1d | 2021-04-16 | 2021-04-16 | 1720d | start no earlier than 2021-04-16 | 0.0% | 0.0% | 0.0% | No BL | No BL | -1014 | On Target |
| 147 | 5.2.2.4 | Schedule Uploads 4 | 1d | 2021-04-23 | 2021-04-23 | 1715d | start no earlier than 2021-04-23 | 0.0% | 0.0% | 0.0% | No BL | No BL | -1014 | On Target |
| 148 | 5.2.2.5 | Schedule Uploads 5 | 1d | 2021-04-30 | 2021-04-30 | 1711d | start no earlier than 2021-04-30 | 0.0% | 0.0% | 0.0% | No BL | No BL | -1014 | On Target |
| 149 | 5.2.2.6 | Schedule Uploads 6 | 1d | 2021-05-07 | 2021-05-07 | 1706d | start no earlier than 2021-05-07 | 0.0% | 0.0% | 0.0% | No BL | No BL | -1014 | On Target |
| 150 | 5.2.2.7 | Schedule Uploads 7 | 1d | 2021-05-14 | 2021-05-14 | 1701d | start no earlier than 2021-05-14 | 0.0% | 0.0% | 0.0% | No BL | No BL | -1014 | On Target |
| 151 | 5.2.2.8 | Schedule Uploads 8 | 1d | 2021-05-21 | 2021-05-21 | 1696d | start no earlier than 2021-05-21 | 0.0% | 0.0% | 0.0% | No BL | No BL | -1014 | On Target |
| 152 | 5.2.2.9 | Schedule Uploads 9 | 1d | 2021-05-28 | 2021-05-28 | 1691d | start no earlier than 2021-05-28 | 0.0% | 0.0% | 0.0% | No BL | No BL | -1014 | On Target |
| 153 | 5.2.2.10 | Schedule Uploads 10 | 1d | 2021-06-04 | 2021-06-04 | 1687d | start no earlier than 2021-06-04 | 0.0% | 0.0% | 0.0% | No BL | No BL | -1014 | On Target |
| 154 | 5.2.2.11 | Schedule Uploads 11 | 1d | 2021-06-11 | 2021-06-11 | 1683d | start no earlier than 2021-06-11 | 0.0% | 0.0% | 0.0% | No BL | No BL | -1014 | On Target |
| 155 | 5.2.2.12 | Schedule Uploads 12 | 1d | 2021-06-18 | 2021-06-18 | 1678d | start no earlier than 2021-06-18 | 0.0% | 0.0% | 0.0% | No BL | No BL | -1014 | On Target |
| 156 | 5.2.2.13 | Schedule Uploads 13 | 1d | 2021-06-25 | 2021-06-25 | 1673d | start no earlier than 2021-06-25 | 0.0% | 0.0% | 0.0% | No BL | No BL | -1014 | On Target |
| 157 | 5.2.2.14 | Schedule Uploads 14 | 1d | 2021-07-02 | 2021-07-02 | 1668d | start no earlier than 2021-07-02 | 0.0% | 0.0% | 0.0% | No BL | No BL | -1014 | On Target |
| 158 | 5.2.2.15 | Schedule Uploads 15 | 1d | 2021-07-09 | 2021-07-09 | 1664d | start no earlier than 2021-07-09 | 0.0% | 0.0% | 0.0% | No BL | No BL | -1014 | On Target |
| 159 | 5.2.2.16 | Schedule Uploads 16 | 1d | 2021-07-16 | 2021-07-16 | 1659d | start no earlier than 2021-07-16 | 0.0% | 0.0% | 0.0% | No BL | No BL | -1014 | On Target |
| 160 | 5.2.2.17 | Schedule Uploads 17 | 1d | 2021-07-23 | 2021-07-23 | 1654d | start no earlier than 2021-07-23 | 0.0% | 0.0% | 0.0% | No BL | No BL | -1014 | On Target |
| 161 | 5.2.2.18 | Schedule Uploads 18 | 1d | 2021-07-30 | 2021-07-30 | 1649d | start no earlier than 2021-07-30 | 0.0% | 0.0% | 0.0% | No BL | No BL | -1014 | On Target |
| 162 | 5.2.2.19 | Schedule Uploads 19 | 1d | 2021-08-06 | 2021-08-06 | 1644d | start no earlier than 2021-08-06 | 0.0% | 0.0% | 0.0% | No BL | No BL | -1014 | On Target |
| 163 | 5.2.2.20 | Schedule Uploads 20 | 1d | 2021-08-13 | 2021-08-13 | 1639d | start no earlier than 2021-08-13 | 0.0% | 0.0% | 0.0% | No BL | No BL | -1014 | On Target |
| 164 | 5.2.2.21 | Schedule Uploads 21 | 1d | 2021-08-20 | 2021-08-20 | 1634d | start no earlier than 2021-08-20 | 0.0% | 0.0% | 0.0% | No BL | No BL | -1014 | On Target |
| 165 | 5.2.2.22 | Schedule Uploads 22 | 1d | 2021-08-27 | 2021-08-27 | 1629d | start no earlier than 2021-08-27 | 0.0% | 0.0% | 0.0% | No BL | No BL | -1014 | On Target |
| 166 | 5.2.2.23 | Schedule Uploads 23 | 1d | 2021-09-03 | 2021-09-03 | 1624d | start no earlier than 2021-09-03 | 0.0% | 0.0% | 0.0% | No BL | No BL | -1014 | On Target |
| 167 | 5.2.2.24 | Schedule Uploads 24 | 1d | 2021-09-10 | 2021-09-10 | 1620d | start no earlier than 2021-09-10 | 0.0% | 0.0% | 0.0% | No BL | No BL | -1014 | On Target |
| 168 | 5.2.2.25 | Schedule Uploads 25 | 1d | 2021-09-17 | 2021-09-17 | 1615d | start no earlier than 2021-09-17 | 0.0% | 0.0% | 0.0% | No BL | No BL | -1014 | On Target |
| 169 | 5.2.2.26 | Schedule Uploads 26 | 1d | 2021-09-24 | 2021-09-24 | 1610d | start no earlier than 2021-09-24 | 0.0% | 0.0% | 0.0% | No BL | No BL | -1014 | On Target |
| 170 | 5.2.2.27 | Schedule Uploads 27 | 1d | 2021-10-01 | 2021-10-01 | 1605d | start no earlier than 2021-10-01 | 0.0% | 0.0% | 0.0% | No BL | No BL | -1014 | On Target |
| 171 | 5.2.2.28 | Schedule Uploads 28 | 1d | 2021-10-08 | 2021-10-08 | 1600d | start no earlier than 2021-10-08 | 0.0% | 0.0% | 0.0% | No BL | No BL | -1014 | On Target |
| 172 | 5.2.2.29 | Schedule Uploads 29 | 1d | 2021-10-15 | 2021-10-15 | 1596d | start no earlier than 2021-10-15 | 0.0% | 0.0% | 0.0% | No BL | No BL | -1014 | On Target |
| 173 | 5.2.2.30 | Schedule Uploads 30 | 1d | 2021-10-22 | 2021-10-22 | 1591d | start no earlier than 2021-10-22 | 0.0% | 0.0% | 0.0% | No BL | No BL | -1014 | On Target |
| 174 | 5.2.2.31 | Schedule Uploads 31 | 1d | 2021-10-29 | 2021-10-29 | 1586d | start no earlier than 2021-10-29 | 0.0% | 0.0% | 0.0% | No BL | No BL | -1014 | On Target |
| 175 | 5.2.2.32 | Schedule Uploads 32 | 1d | 2021-11-05 | 2021-11-05 | 1581d | start no earlier than 2021-11-05 | 0.0% | 0.0% | 0.0% | No BL | No BL | -1014 | On Target |
| 176 | 5.2.2.33 | Schedule Uploads 33 | 1d | 2021-11-12 | 2021-11-12 | 1577d | start no earlier than 2021-11-12 | 0.0% | 0.0% | 0.0% | No BL | No BL | -1014 | On Target |
| 177 | 5.2.2.34 | Schedule Uploads 34 | 1d | 2021-11-19 | 2021-11-19 | 1572d | start no earlier than 2021-11-19 | 0.0% | 0.0% | 0.0% | No BL | No BL | -1014 | On Target |
| 178 | 5.2.2.35 | Schedule Uploads 35 | 1d | 2021-11-29 | 2021-11-29 | 1568d | start no earlier than 2021-11-26 | 0.0% | 0.0% | 0.0% | No BL | No BL | -1014 | On Target |
| 179 | 5.2.2.36 | Schedule Uploads 36 | 1d | 2021-12-03 | 2021-12-03 | 1564d | start no earlier than 2021-12-03 | 0.0% | 0.0% | 0.0% | No BL | No BL | -1014 | On Target |
| 180 | 5.2.2.37 | Schedule Uploads 37 | 1d | 2021-12-10 | 2021-12-10 | 1559d | start no earlier than 2021-12-10 | 0.0% | 0.0% | 0.0% | No BL | No BL | -1014 | On Target |
| 181 | 5.2.2.38 | Schedule Uploads 38 | 1d | 2021-12-17 | 2021-12-17 | 1554d | start no earlier than 2021-12-17 | 0.0% | 0.0% | 0.0% | No BL | No BL | -1014 | On Target |
| 182 | 5.2.2.39 | Schedule Uploads 39 | 1d | 2021-12-27 | 2021-12-27 | 1549d | start no earlier than 2021-12-24 | 0.0% | 0.0% | 0.0% | No BL | No BL | -1014 | On Target |
| 183 | 5.2.2.40 | Schedule Uploads 40 | 1d | 2022-01-04 | 2022-01-04 | 1545d | start no earlier than 2021-12-31 | 0.0% | 0.0% | 0.0% | No BL | No BL | -1014 | On Target |
| 184 | 5.2.2.41 | Schedule Uploads 41 | 1d | 2022-01-07 | 2022-01-07 | 1542d | start no earlier than 2022-01-07 | 0.0% | 0.0% | 0.0% | No BL | No BL | -1014 | On Target |
| 185 | 5.2.2.42 | Schedule Uploads 42 | 1d | 2022-01-14 | 2022-01-14 | 1537d | start no earlier than 2022-01-14 | 0.0% | 0.0% | 0.0% | No BL | No BL | -1014 | On Target |
| 186 | 5.2.2.43 | Schedule Uploads 43 | 1d | 2022-01-21 | 2022-01-21 | 1533d | start no earlier than 2022-01-21 | 0.0% | 0.0% | 0.0% | No BL | No BL | -1014 | On Target |
| 187 | 5.2.2.44 | Schedule Uploads 44 | 1d | 2022-01-28 | 2022-01-28 | 1528d | start no earlier than 2022-01-28 | 0.0% | 0.0% | 0.0% | No BL | No BL | -1014 | On Target |
| 188 | 5.2.2.45 | Schedule Uploads 45 | 1d | 2022-02-04 | 2022-02-04 | 1523d | start no earlier than 2022-02-04 | 0.0% | 0.0% | 0.0% | No BL | No BL | -1014 | On Target |
| 189 | 5.2.2.46 | Schedule Uploads 46 | 1d | 2022-02-11 | 2022-02-11 | 1518d | start no earlier than 2022-02-11 | 0.0% | 0.0% | 0.0% | No BL | No BL | -1014 | On Target |
| 190 | 5.2.2.47 | Schedule Uploads 47 | 1d | 2022-02-18 | 2022-02-18 | 1513d | start no earlier than 2022-02-18 | 0.0% | 0.0% | 0.0% | No BL | No BL | -1014 | On Target |
| 191 | 5.2.2.48 | Schedule Uploads 48 | 1d | 2022-02-25 | 2022-02-25 | 1509d | start no earlier than 2022-02-25 | 0.0% | 0.0% | 0.0% | No BL | No BL | -1014 | On Target |
| 192 | 5.2.2.49 | Schedule Uploads 49 | 1d | 2022-03-04 | 2022-03-04 | 1504d | start no earlier than 2022-03-04 | 0.0% | 0.0% | 0.0% | No BL | No BL | -1014 | On Target |
| 193 | 5.2.2.50 | Schedule Uploads 50 | 1d | 2022-03-11 | 2022-03-11 | 1499d | start no earlier than 2022-03-11 | 0.0% | 0.0% | 0.0% | No BL | No BL | -1014 | On Target |
| 194 | 5.2.2.51 | Schedule Uploads 51 | 1d | 2022-03-18 | 2022-03-18 | 1494d | start no earlier than 2022-03-18 | 0.0% | 0.0% | 0.0% | No BL | No BL | -1014 | On Target |
| 195 | 5.2.2.52 | Schedule Uploads 52 | 1d | 2022-03-25 | 2022-03-25 | 1489d | start no earlier than 2022-03-25 | 0.0% | 0.0% | 0.0% | No BL | No BL | -1014 | On Target |
| 196 | 5.2.2.53 | Schedule Uploads 53 | 1d | 2022-04-01 | 2022-04-01 | 1484d | start no earlier than 2022-04-01 | 0.0% | 0.0% | 0.0% | No BL | No BL | -1014 | On Target |
| 197 | 5.2.2.54 | Schedule Uploads 54 | 1d | 2022-04-08 | 2022-04-08 | 1479d | start no earlier than 2022-04-08 | 0.0% | 0.0% | 0.0% | No BL | No BL | -1014 | On Target |
| 198 | 5.2.2.55 | Schedule Uploads 55 | 1d | 2022-04-15 | 2022-04-15 | 1474d | start no earlier than 2022-04-15 | 0.0% | 0.0% | 0.0% | No BL | No BL | -1014 | On Target |
| 199 | 5.2.2.56 | Schedule Uploads 56 | 1d | 2022-04-22 | 2022-04-22 | 1469d | start no earlier than 2022-04-22 | 0.0% | 0.0% | 0.0% | No BL | No BL | -1014 | On Target |
| 200 | 5.2.2.57 | Schedule Uploads 57 | 1d | 2022-04-29 | 2022-04-29 | 1465d | start no earlier than 2022-04-29 | 0.0% | 0.0% | 0.0% | No BL | No BL | -1014 | On Target |
| 201 | 5.2.2.58 | Schedule Uploads 58 | 1d | 2022-05-06 | 2022-05-06 | 1460d | start no earlier than 2022-05-06 | 0.0% | 0.0% | 0.0% | No BL | No BL | -1014 | On Target |
| 202 | 5.2.2.59 | Schedule Uploads 59 | 1d | 2022-05-13 | 2022-05-13 | 1455d | start no earlier than 2022-05-13 | 0.0% | 0.0% | 0.0% | No BL | No BL | -1014 | On Target |
| 203 | 5.2.2.60 | Schedule Uploads 60 | 1d | 2022-05-20 | 2022-05-20 | 1450d | start no earlier than 2022-05-20 | 0.0% | 0.0% | 0.0% | No BL | No BL | -1014 | On Target |
| 204 | 5.2.2.61 | Schedule Uploads 61 | 1d | 2022-05-27 | 2022-05-27 | 1445d | start no earlier than 2022-05-27 | 0.0% | 0.0% | 0.0% | No BL | No BL | -1014 | On Target |
| 205 | 5.2.2.62 | Schedule Uploads 62 | 1d | 2022-06-03 | 2022-06-03 | 1441d | start no earlier than 2022-06-03 | 0.0% | 0.0% | 0.0% | No BL | No BL | -1014 | On Target |
| 206 | 5.2.2.63 | Schedule Uploads 63 | 1d | 2022-06-10 | 2022-06-10 | 1437d | start no earlier than 2022-06-10 | 0.0% | 0.0% | 0.0% | No BL | No BL | -1014 | On Target |
| 207 | 5.2.2.64 | Schedule Uploads 64 | 1d | 2022-06-17 | 2022-06-17 | 1432d | start no earlier than 2022-06-17 | 0.0% | 0.0% | 0.0% | No BL | No BL | -1014 | On Target |
| 208 | 5.2.2.65 | Schedule Uploads 65 | 1d | 2022-06-24 | 2022-06-24 | 1427d | start no earlier than 2022-06-24 | 0.0% | 0.0% | 0.0% | No BL | No BL | -1014 | On Target |
| 209 | 5.2.2.66 | Schedule Uploads 66 | 1d | 2022-07-01 | 2022-07-01 | 1422d | start no earlier than 2022-07-01 | 0.0% | 0.0% | 0.0% | No BL | No BL | -1014 | On Target |
| 210 | 5.2.2.67 | Schedule Uploads 67 | 1d | 2022-07-08 | 2022-07-08 | 1418d | start no earlier than 2022-07-08 | 0.0% | 0.0% | 0.0% | No BL | No BL | -1014 | On Target |
| 211 | 5.2.2.68 | Schedule Uploads 68 | 1d | 2022-07-15 | 2022-07-15 | 1413d | start no earlier than 2022-07-15 | 0.0% | 0.0% | 0.0% | No BL | No BL | -1014 | On Target |
| 212 | 5.2.2.69 | Schedule Uploads 69 | 1d | 2022-07-22 | 2022-07-22 | 1408d | start no earlier than 2022-07-22 | 0.0% | 0.0% | 0.0% | No BL | No BL | -1014 | On Target |

| ID | WBS | Task | Duration | Start | Finish | Total slack | Constraint | _Current Target | _Baseline Target | _Progress % | _Projected Status | _Baseline % Status | _Days Since Update | _Current % Status |
| --- | --- | --- | --- | --- | --- | --- | --- | --- | --- | --- | --- | --- | --- | --- |
| 213 | 5.2.2.70 | Schedule Uploads 70 | 1d | 2022-07-29 | 2022-07-29 | 1403d | start no earlier than 2022-07-29 | 0.0% | 0.0% | 0.0% | No BL | No BL | -1014 | On Target |
| 214 | 5.2.2.71 | Schedule Uploads 71 | 1d | 2022-08-05 | 2022-08-05 | 1398d | start no earlier than 2022-08-05 | 0.0% | 0.0% | 0.0% | No BL | No BL | -1014 | On Target |
| 215 | 5.2.2.72 | Schedule Uploads 72 | 1d | 2022-08-12 | 2022-08-12 | 1393d | start no earlier than 2022-08-12 | 0.0% | 0.0% | 0.0% | No BL | No BL | -1014 | On Target |
| 216 | 5.2.2.73 | Schedule Uploads 73 | 1d | 2022-08-19 | 2022-08-19 | 1388d | start no earlier than 2022-08-19 | 0.0% | 0.0% | 0.0% | No BL | No BL | -1014 | On Target |
| 217 | 5.2.2.74 | Schedule Uploads 74 | 1d | 2022-08-26 | 2022-08-26 | 1383d | start no earlier than 2022-08-26 | 0.0% | 0.0% | 0.0% | No BL | No BL | -1014 | On Target |
| 218 | 5.2.2.75 | Schedule Uploads 75 | 1d | 2022-09-02 | 2022-09-02 | 1378d | start no earlier than 2022-09-02 | 0.0% | 0.0% | 0.0% | No BL | No BL | -1014 | On Target |
| 219 | 5.2.2.76 | Schedule Uploads 76 | 1d | 2022-09-09 | 2022-09-09 | 1374d | start no earlier than 2022-09-09 | 0.0% | 0.0% | 0.0% | No BL | No BL | -1014 | On Target |
| 220 | 5.2.2.77 | Schedule Uploads 77 | 1d | 2022-09-16 | 2022-09-16 | 1369d | start no earlier than 2022-09-16 | 0.0% | 0.0% | 0.0% | No BL | No BL | -1014 | On Target |
| 221 | 5.2.2.78 | Schedule Uploads 78 | 1d | 2022-09-23 | 2022-09-23 | 1364d | start no earlier than 2022-09-23 | 0.0% | 0.0% | 0.0% | No BL | No BL | -1014 | On Target |
| 222 | 5.2.2.79 | Schedule Uploads 79 | 1d | 2022-09-30 | 2022-09-30 | 1359d | start no earlier than 2022-09-30 | 0.0% | 0.0% | 0.0% | No BL | No BL | -1014 | On Target |
| 223 | 5.2.2.80 | Schedule Uploads 80 | 1d | 2022-10-07 | 2022-10-07 | 1354d | start no earlier than 2022-10-07 | 0.0% | 0.0% | 0.0% | No BL | No BL | -1014 | On Target |
| 224 | 5.2.2.81 | Schedule Uploads 81 | 1d | 2022-10-14 | 2022-10-14 | 1350d | start no earlier than 2022-10-14 | 0.0% | 0.0% | 0.0% | No BL | No BL | -1014 | On Target |
| 225 | 5.2.2.82 | Schedule Uploads 82 | 1d | 2022-10-21 | 2022-10-21 | 1345d | start no earlier than 2022-10-21 | 0.0% | 0.0% | 0.0% | No BL | No BL | -1014 | On Target |
| 226 | 5.2.2.83 | Schedule Uploads 83 | 1d | 2022-10-28 | 2022-10-28 | 1340d | start no earlier than 2022-10-28 | 0.0% | 0.0% | 0.0% | No BL | No BL | -1014 | On Target |
| 227 | 5.2.2.84 | Schedule Uploads 84 | 1d | 2022-11-04 | 2022-11-04 | 1335d | start no earlier than 2022-11-04 | 0.0% | 0.0% | 0.0% | No BL | No BL | -1014 | On Target |
| 228 | 5.2.2.85 | Schedule Uploads 85 | 1d | 2022-11-14 | 2022-11-14 | 1330d | start no earlier than 2022-11-11 | 0.0% | 0.0% | 0.0% | No BL | No BL | -1014 | On Target |
| 229 | 5.2.2.86 | Schedule Uploads 86 | 1d | 2022-11-18 | 2022-11-18 | 1326d | start no earlier than 2022-11-18 | 0.0% | 0.0% | 0.0% | No BL | No BL | -1014 | On Target |
| 230 | 5.2.2.87 | Schedule Uploads 87 | 1d | 2022-11-28 | 2022-11-28 | 1322d | start no earlier than 2022-11-25 | 0.0% | 0.0% | 0.0% | No BL | No BL | -1014 | On Target |
| 231 | 5.2.2.88 | Schedule Uploads 88 | 1d | 2022-12-02 | 2022-12-02 | 1318d | start no earlier than 2022-12-02 | 0.0% | 0.0% | 0.0% | No BL | No BL | -1014 | On Target |
| 232 | 5.2.2.89 | Schedule Uploads 89 | 1d | 2022-12-09 | 2022-12-09 | 1313d | start no earlier than 2022-12-09 | 0.0% | 0.0% | 0.0% | No BL | No BL | -1014 | On Target |
| 233 | 5.2.2.90 | Schedule Uploads 90 | 1d | 2022-12-16 | 2022-12-16 | 1308d | start no earlier than 2022-12-16 | 0.0% | 0.0% | 0.0% | No BL | No BL | -1014 | On Target |
| 234 | 5.2.2.91 | Schedule Uploads 91 | 1d | 2022-12-23 | 2022-12-23 | 1303d | start no earlier than 2022-12-23 | 0.0% | 0.0% | 0.0% | No BL | No BL | -1014 | On Target |
| 235 | 5.2.2.92 | Schedule Uploads 92 | 1d | 2022-12-30 | 2022-12-30 | 1299d | start no earlier than 2022-12-30 | 0.0% | 0.0% | 0.0% | No BL | No BL | -1014 | On Target |
| 236 | 5.2.2.93 | Schedule Uploads 93 | 1d | 2023-01-06 | 2023-01-06 | 1295d | start no earlier than 2023-01-06 | 0.0% | 0.0% | 0.0% | No BL | No BL | -1014 | On Target |
| 237 | 5.2.2.94 | Schedule Uploads 94 | 1d | 2023-01-13 | 2023-01-13 | 1290d | start no earlier than 2023-01-13 | 0.0% | 0.0% | 0.0% | No BL | No BL | -1014 | On Target |
| 238 | 5.2.2.95 | Schedule Uploads 95 | 1d | 2023-01-20 | 2023-01-20 | 1286d | start no earlier than 2023-01-20 | 0.0% | 0.0% | 0.0% | No BL | No BL | -1014 | On Target |
| 239 | 5.2.2.96 | Schedule Uploads 96 | 1d | 2023-01-27 | 2023-01-27 | 1281d | start no earlier than 2023-01-27 | 0.0% | 0.0% | 0.0% | No BL | No BL | -1014 | On Target |
| 240 | 5.2.2.97 | Schedule Uploads 97 | 1d | 2023-02-03 | 2023-02-03 | 1276d | start no earlier than 2023-02-03 | 0.0% | 0.0% | 0.0% | No BL | No BL | -1014 | On Target |
| 241 | 5.2.2.98 | Schedule Uploads 98 | 1d | 2023-02-10 | 2023-02-10 | 1271d | start no earlier than 2023-02-10 | 0.0% | 0.0% | 0.0% | No BL | No BL | -1014 | On Target |
| 242 | 5.2.2.99 | Schedule Uploads 99 | 1d | 2023-02-17 | 2023-02-17 | 1266d | start no earlier than 2023-02-17 | 0.0% | 0.0% | 0.0% | No BL | No BL | -1014 | On Target |
| 243 | 5.2.2.100 | Schedule Uploads 100 | 1d | 2023-02-24 | 2023-02-24 | 1262d | start no earlier than 2023-02-24 | 0.0% | 0.0% | 0.0% | No BL | No BL | -1014 | On Target |
| 244 | 5.2.2.101 | Schedule Uploads 101 | 1d | 2023-03-03 | 2023-03-03 | 1257d | start no earlier than 2023-03-03 | 0.0% | 0.0% | 0.0% | No BL | No BL | -1014 | On Target |
| 245 | 5.2.2.102 | Schedule Uploads 102 | 1d | 2023-03-10 | 2023-03-10 | 1252d | start no earlier than 2023-03-10 | 0.0% | 0.0% | 0.0% | No BL | No BL | -1014 | On Target |
| 246 | 5.2.2.103 | Schedule Uploads 103 | 1d | 2023-03-17 | 2023-03-17 | 1247d | start no earlier than 2023-03-17 | 0.0% | 0.0% | 0.0% | No BL | No BL | -1014 | On Target |
| 247 | 5.2.2.104 | Schedule Uploads 104 | 1d | 2023-03-24 | 2023-03-24 | 1242d | start no earlier than 2023-03-24 | 0.0% | 0.0% | 0.0% | No BL | No BL | -1014 | On Target |
| 248 | 5.2.2.105 | Schedule Uploads 105 | 1d | 2023-03-31 | 2023-03-31 | 1237d | start no earlier than 2023-03-31 | 0.0% | 0.0% | 0.0% | No BL | No BL | -1014 | On Target |
| 249 | 5.2.2.106 | Schedule Uploads 106 | 1d | 2023-04-07 | 2023-04-07 | 1232d | start no earlier than 2023-04-07 | 0.0% | 0.0% | 0.0% | No BL | No BL | -1014 | On Target |
| 250 | 5.2.2.107 | Schedule Uploads 107 | 1d | 2023-04-14 | 2023-04-14 | 1227d | start no earlier than 2023-04-14 | 0.0% | 0.0% | 0.0% | No BL | No BL | -1014 | On Target |
| 251 | 5.2.2.108 | Schedule Uploads 108 | 1d | 2023-04-21 | 2023-04-21 | 1222d | start no earlier than 2023-04-21 | 0.0% | 0.0% | 0.0% | No BL | No BL | -1014 | On Target |
| 252 | 5.2.2.109 | Schedule Uploads 109 | 1d | 2023-04-28 | 2023-04-28 | 1218d | start no earlier than 2023-04-28 | 0.0% | 0.0% | 0.0% | No BL | No BL | -1014 | On Target |
| 253 | 5.2.2.110 | Schedule Uploads 110 | 1d | 2023-05-05 | 2023-05-05 | 1213d | start no earlier than 2023-05-05 | 0.0% | 0.0% | 0.0% | No BL | No BL | -1014 | On Target |
| 254 | 5.2.2.111 | Schedule Uploads 111 | 1d | 2023-05-12 | 2023-05-12 | 1208d | start no earlier than 2023-05-12 | 0.0% | 0.0% | 0.0% | No BL | No BL | -1014 | On Target |
| 255 | 5.2.2.112 | Schedule Uploads 112 | 1d | 2023-05-19 | 2023-05-19 | 1203d | start no earlier than 2023-05-19 | 0.0% | 0.0% | 0.0% | No BL | No BL | -1014 | On Target |
| 256 | 5.2.2.113 | Schedule Uploads 113 | 1d | 2023-05-26 | 2023-05-26 | 1198d | start no earlier than 2023-05-26 | 0.0% | 0.0% | 0.0% | No BL | No BL | -1014 | On Target |
| 257 | 5.2.2.114 | Schedule Uploads 114 | 1d | 2023-06-02 | 2023-06-02 | 1194d | start no earlier than 2023-06-02 | 0.0% | 0.0% | 0.0% | No BL | No BL | -1014 | On Target |
| 258 | 5.2.2.115 | Schedule Uploads 115 | 1d | 2023-06-09 | 2023-06-09 | 1190d | start no earlier than 2023-06-09 | 0.0% | 0.0% | 0.0% | No BL | No BL | -1014 | On Target |
| 259 | 5.2.2.116 | Schedule Uploads 116 | 1d | 2023-06-16 | 2023-06-16 | 1185d | start no earlier than 2023-06-16 | 0.0% | 0.0% | 0.0% | No BL | No BL | -1014 | On Target |
| 260 | 5.2.2.117 | Schedule Uploads 117 | 1d | 2023-06-23 | 2023-06-23 | 1180d | start no earlier than 2023-06-23 | 0.0% | 0.0% | 0.0% | No BL | No BL | -1014 | On Target |
| 261 | 5.2.2.118 | Schedule Uploads 118 | 1d | 2023-06-30 | 2023-06-30 | 1175d | start no earlier than 2023-06-30 | 0.0% | 0.0% | 0.0% | No BL | No BL | -1014 | On Target |
| 262 | 5.2.2.119 | Schedule Uploads 119 | 1d | 2023-07-07 | 2023-07-07 | 1171d | start no earlier than 2023-07-07 | 0.0% | 0.0% | 0.0% | No BL | No BL | -1014 | On Target |
| 263 | 5.2.2.120 | Schedule Uploads 120 | 1d | 2023-07-14 | 2023-07-14 | 1166d | start no earlier than 2023-07-14 | 0.0% | 0.0% | 0.0% | No BL | No BL | -1014 | On Target |
| 264 | 5.2.2.121 | Schedule Uploads 121 | 1d | 2023-07-21 | 2023-07-21 | 1161d | start no earlier than 2023-07-21 | 0.0% | 0.0% | 0.0% | No BL | No BL | -1014 | On Target |
| 265 | 5.2.2.122 | Schedule Uploads 122 | 1d | 2023-07-28 | 2023-07-28 | 1156d | start no earlier than 2023-07-28 | 0.0% | 0.0% | 0.0% | No BL | No BL | -1014 | On Target |
| 266 | 5.2.2.123 | Schedule Uploads 123 | 1d | 2023-08-04 | 2023-08-04 | 1151d | start no earlier than 2023-08-04 | 0.0% | 0.0% | 0.0% | No BL | No BL | -1014 | On Target |
| 267 | 5.2.2.124 | Schedule Uploads 124 | 1d | 2023-08-11 | 2023-08-11 | 1146d | start no earlier than 2023-08-11 | 0.0% | 0.0% | 0.0% | No BL | No BL | -1014 | On Target |
| 268 | 5.2.2.125 | Schedule Uploads 125 | 1d | 2023-08-18 | 2023-08-18 | 1141d | start no earlier than 2023-08-18 | 0.0% | 0.0% | 0.0% | No BL | No BL | -1014 | On Target |
| 269 | 5.2.2.126 | Schedule Uploads 126 | 1d | 2023-08-25 | 2023-08-25 | 1136d | start no earlier than 2023-08-25 | 0.0% | 0.0% | 0.0% | No BL | No BL | -1014 | On Target |
| 270 | 5.2.2.127 | Schedule Uploads 127 | 1d | 2023-09-01 | 2023-09-01 | 1131d | start no earlier than 2023-09-01 | 0.0% | 0.0% | 0.0% | No BL | No BL | -1014 | On Target |
| 271 | 5.2.2.128 | Schedule Uploads 128 | 1d | 2023-09-08 | 2023-09-08 | 1127d | start no earlier than 2023-09-08 | 0.0% | 0.0% | 0.0% | No BL | No BL | -1014 | On Target |
| 272 | 5.2.2.129 | Schedule Uploads 129 | 1d | 2023-09-15 | 2023-09-15 | 1122d | start no earlier than 2023-09-15 | 0.0% | 0.0% | 0.0% | No BL | No BL | -1014 | On Target |
| 273 | 5.2.2.130 | Schedule Uploads 130 | 1d | 2023-09-22 | 2023-09-22 | 1117d | start no earlier than 2023-09-22 | 0.0% | 0.0% | 0.0% | No BL | No BL | -1014 | On Target |
| 274 | 5.2.2.131 | Schedule Uploads 131 | 1d | 2023-09-29 | 2023-09-29 | 1112d | start no earlier than 2023-09-29 | 0.0% | 0.0% | 0.0% | No BL | No BL | -1014 | On Target |
| 275 | 5.2.2.132 | Schedule Uploads 132 | 1d | 2023-10-06 | 2023-10-06 | 1107d | start no earlier than 2023-10-06 | 0.0% | 0.0% | 0.0% | No BL | No BL | -1014 | On Target |
| 276 | 5.2.2.133 | Schedule Uploads 133 | 1d | 2023-10-13 | 2023-10-13 | 1103d | start no earlier than 2023-10-13 | 0.0% | 0.0% | 0.0% | No BL | No BL | -1014 | On Target |
| 277 | 5.2.2.134 | Schedule Uploads 134 | 1d | 2023-10-20 | 2023-10-20 | 1098d | start no earlier than 2023-10-20 | 0.0% | 0.0% | 0.0% | No BL | No BL | -1014 | On Target |
| 278 | 5.2.2.135 | Schedule Uploads 135 | 1d | 2023-10-27 | 2023-10-27 | 1093d | start no earlier than 2023-10-27 | 0.0% | 0.0% | 0.0% | No BL | No BL | -1014 | On Target |
| 279 | 5.2.2.136 | Schedule Uploads 136 | 1d | 2023-11-03 | 2023-11-03 | 1088d | start no earlier than 2023-11-03 | 0.0% | 0.0% | 0.0% | No BL | No BL | -1014 | On Target |
| 280 | 5.2.2.137 | Schedule Uploads 137 | 1d | 2023-11-10 | 2023-11-10 | 1083d | start no earlier than 2023-11-10 | 0.0% | 0.0% | 0.0% | No BL | No BL | -1014 | On Target |
| 281 | 5.2.2.138 | Schedule Uploads 138 | 1d | 2023-11-17 | 2023-11-17 | 1079d | start no earlier than 2023-11-17 | 0.0% | 0.0% | 0.0% | No BL | No BL | -1014 | On Target |
| 282 | 5.2.2.139 | Schedule Uploads 139 | 1d | 2023-11-27 | 2023-11-27 | 1075d | start no earlier than 2023-11-24 | 0.0% | 0.0% | 0.0% | No BL | No BL | -1014 | On Target |

| ID | WBS | Task | Duration | Start | Finish | Total slack | Constraint | _Current Target | _Baseline Target | _Progress % | _Projected Status | _Baseline % Status | _Days Since Update | _Current % Status |
| --- | --- | --- | --- | --- | --- | --- | --- | --- | --- | --- | --- | --- | --- | --- |
| 283 | 5.2.2.140 | Schedule Uploads 140 | 1d | 2023-12-01 | 2023-12-01 | 1071d | start no earlier than 2023-12-01 | 0.0% | 0.0% | 0.0% | No BL | No BL | -1014 | On Target |
| 284 | 5.2.2.141 | Schedule Uploads 141 | 1d | 2023-12-08 | 2023-12-08 | 1066d | start no earlier than 2023-12-08 | 0.0% | 0.0% | 0.0% | No BL | No BL | -1014 | On Target |
| 285 | 5.2.2.142 | Schedule Uploads 142 | 1d | 2023-12-15 | 2023-12-15 | 1061d | start no earlier than 2023-12-15 | 0.0% | 0.0% | 0.0% | No BL | No BL | -1014 | On Target |
| 286 | 5.2.2.143 | Schedule Uploads 143 | 1d | 2023-12-22 | 2023-12-22 | 1056d | start no earlier than 2023-12-22 | 0.0% | 0.0% | 0.0% | No BL | No BL | -1014 | On Target |
| 287 | 5.2.2.144 | Schedule Uploads 144 | 1d | 2023-12-29 | 2023-12-29 | 1052d | start no earlier than 2023-12-29 | 0.0% | 0.0% | 0.0% | No BL | No BL | -1014 | On Target |
| 288 | 5.2.2.145 | Schedule Uploads 145 | 1d | 2024-01-05 | 2024-01-05 | 1048d | start no earlier than 2024-01-05 | 0.0% | 0.0% | 0.0% | No BL | No BL | -1014 | On Target |
| 289 | 5.2.2.146 | Schedule Uploads 146 | 1d | 2024-01-12 | 2024-01-12 | 1043d | start no earlier than 2024-01-12 | 0.0% | 0.0% | 0.0% | No BL | No BL | -1014 | On Target |
| 290 | 5.2.2.147 | Schedule Uploads 147 | 1d | 2024-01-19 | 2024-01-19 | 1039d | start no earlier than 2024-01-19 | 0.0% | 0.0% | 0.0% | No BL | No BL | -1014 | On Target |
| 291 | 5.2.2.148 | Schedule Uploads 148 | 1d | 2024-01-26 | 2024-01-26 | 1034d | start no earlier than 2024-01-26 | 0.0% | 0.0% | 0.0% | No BL | No BL | -1014 | On Target |
| 292 | 5.2.2.149 | Schedule Uploads 149 | 1d | 2024-02-02 | 2024-02-02 | 1029d | start no earlier than 2024-02-02 | 0.0% | 0.0% | 0.0% | No BL | No BL | -1014 | On Target |
| 293 | 5.2.2.150 | Schedule Uploads 150 | 1d | 2024-02-09 | 2024-02-09 | 1024d | start no earlier than 2024-02-09 | 0.0% | 0.0% | 0.0% | No BL | No BL | -1014 | On Target |
| 294 | 5.2.2.151 | Schedule Uploads 151 | 1d | 2024-02-16 | 2024-02-16 | 1019d | start no earlier than 2024-02-16 | 0.0% | 0.0% | 0.0% | No BL | No BL | -1014 | On Target |
| 295 | 5.2.2.152 | Schedule Uploads 152 | 1d | 2024-02-23 | 2024-02-23 | 1015d | start no earlier than 2024-02-23 | 0.0% | 0.0% | 0.0% | No BL | No BL | -1014 | On Target |
| 296 | 5.2.2.153 | Schedule Uploads 153 | 1d | 2024-03-01 | 2024-03-01 | 1010d | start no earlier than 2024-03-01 | 0.0% | 0.0% | 0.0% | No BL | No BL | -1014 | On Target |
| 297 | 5.2.2.154 | Schedule Uploads 154 | 1d | 2024-03-08 | 2024-03-08 | 1005d | start no earlier than 2024-03-08 | 0.0% | 0.0% | 0.0% | No BL | No BL | -1014 | On Target |
| 298 | 5.2.2.155 | Schedule Uploads 155 | 1d | 2024-03-15 | 2024-03-15 | 1000d | start no earlier than 2024-03-15 | 0.0% | 0.0% | 0.0% | No BL | No BL | -1014 | On Target |
| 299 | 5.2.2.156 | Schedule Uploads 156 | 1d | 2024-03-22 | 2024-03-22 | 995d | start no earlier than 2024-03-22 | 0.0% | 0.0% | 0.0% | No BL | No BL | -1014 | On Target |
| 300 | 5.2.3 | **Executive Dashboard Updates** | 731d | 2021-04-02 | 2024-03-15 | 1000d |  | 0.0% | 0.0% |  |  |  |  |  |
| 301 | 5.2.3.1 | Executive Dashboard Updates 1 | 1d | 2021-04-02 | 2021-04-02 | 1730d | start no earlier than 2021-04-02 | 0.0% | 0.0% | 0.0% | No BL | No BL | -1014 | On Target |
| 302 | 5.2.3.2 | Executive Dashboard Updates 2 | 1d | 2021-04-16 | 2021-04-16 | 1720d | start no earlier than 2021-04-16 | 0.0% | 0.0% | 0.0% | No BL | No BL | -1014 | On Target |
| 303 | 5.2.3.3 | Executive Dashboard Updates 3 | 1d | 2021-04-30 | 2021-04-30 | 1711d | start no earlier than 2021-04-30 | 0.0% | 0.0% | 0.0% | No BL | No BL | -1014 | On Target |
| 304 | 5.2.3.4 | Executive Dashboard Updates 4 | 1d | 2021-05-14 | 2021-05-14 | 1701d | start no earlier than 2021-05-14 | 0.0% | 0.0% | 0.0% | No BL | No BL | -1014 | On Target |
| 305 | 5.2.3.5 | Executive Dashboard Updates 5 | 1d | 2021-05-28 | 2021-05-28 | 1691d | start no earlier than 2021-05-28 | 0.0% | 0.0% | 0.0% | No BL | No BL | -1014 | On Target |
| 306 | 5.2.3.6 | Executive Dashboard Updates 6 | 1d | 2021-06-11 | 2021-06-11 | 1683d | start no earlier than 2021-06-11 | 0.0% | 0.0% | 0.0% | No BL | No BL | -1014 | On Target |
| 307 | 5.2.3.7 | Executive Dashboard Updates 7 | 1d | 2021-06-25 | 2021-06-25 | 1673d | start no earlier than 2021-06-25 | 0.0% | 0.0% | 0.0% | No BL | No BL | -1014 | On Target |
| 308 | 5.2.3.8 | Executive Dashboard Updates 8 | 1d | 2021-07-09 | 2021-07-09 | 1664d | start no earlier than 2021-07-09 | 0.0% | 0.0% | 0.0% | No BL | No BL | -1014 | On Target |
| 309 | 5.2.3.9 | Executive Dashboard Updates 9 | 1d | 2021-07-23 | 2021-07-23 | 1654d | start no earlier than 2021-07-23 | 0.0% | 0.0% | 0.0% | No BL | No BL | -1014 | On Target |
| 310 | 5.2.3.10 | Executive Dashboard Updates 10 | 1d | 2021-08-06 | 2021-08-06 | 1644d | start no earlier than 2021-08-06 | 0.0% | 0.0% | 0.0% | No BL | No BL | -1014 | On Target |
| 311 | 5.2.3.11 | Executive Dashboard Updates 11 | 1d | 2021-08-20 | 2021-08-20 | 1634d | start no earlier than 2021-08-20 | 0.0% | 0.0% | 0.0% | No BL | No BL | -1014 | On Target |
| 312 | 5.2.3.12 | Executive Dashboard Updates 12 | 1d | 2021-09-03 | 2021-09-03 | 1624d | start no earlier than 2021-09-03 | 0.0% | 0.0% | 0.0% | No BL | No BL | -1014 | On Target |
| 313 | 5.2.3.13 | Executive Dashboard Updates 13 | 1d | 2021-09-17 | 2021-09-17 | 1615d | start no earlier than 2021-09-17 | 0.0% | 0.0% | 0.0% | No BL | No BL | -1014 | On Target |
| 314 | 5.2.3.14 | Executive Dashboard Updates 14 | 1d | 2021-10-01 | 2021-10-01 | 1605d | start no earlier than 2021-10-01 | 0.0% | 0.0% | 0.0% | No BL | No BL | -1014 | On Target |
| 315 | 5.2.3.15 | Executive Dashboard Updates 15 | 1d | 2021-10-15 | 2021-10-15 | 1596d | start no earlier than 2021-10-15 | 0.0% | 0.0% | 0.0% | No BL | No BL | -1014 | On Target |
| 316 | 5.2.3.16 | Executive Dashboard Updates 16 | 1d | 2021-10-29 | 2021-10-29 | 1586d | start no earlier than 2021-10-29 | 0.0% | 0.0% | 0.0% | No BL | No BL | -1014 | On Target |
| 317 | 5.2.3.17 | Executive Dashboard Updates 17 | 1d | 2021-11-12 | 2021-11-12 | 1577d | start no earlier than 2021-11-12 | 0.0% | 0.0% | 0.0% | No BL | No BL | -1014 | On Target |
| 318 | 5.2.3.18 | Executive Dashboard Updates 18 | 1d | 2021-11-29 | 2021-11-29 | 1568d | start no earlier than 2021-11-26 | 0.0% | 0.0% | 0.0% | No BL | No BL | -1014 | On Target |
| 319 | 5.2.3.19 | Executive Dashboard Updates 19 | 1d | 2021-12-10 | 2021-12-10 | 1559d | start no earlier than 2021-12-10 | 0.0% | 0.0% | 0.0% | No BL | No BL | -1014 | On Target |
| 320 | 5.2.3.20 | Executive Dashboard Updates 20 | 1d | 2021-12-27 | 2021-12-27 | 1549d | start no earlier than 2021-12-24 | 0.0% | 0.0% | 0.0% | No BL | No BL | -1014 | On Target |
| 321 | 5.2.3.21 | Executive Dashboard Updates 21 | 1d | 2022-01-07 | 2022-01-07 | 1542d | start no earlier than 2022-01-07 | 0.0% | 0.0% | 0.0% | No BL | No BL | -1014 | On Target |
| 322 | 5.2.3.22 | Executive Dashboard Updates 22 | 1d | 2022-01-21 | 2022-01-21 | 1533d | start no earlier than 2022-01-21 | 0.0% | 0.0% | 0.0% | No BL | No BL | -1014 | On Target |
| 323 | 5.2.3.23 | Executive Dashboard Updates 23 | 1d | 2022-02-04 | 2022-02-04 | 1523d | start no earlier than 2022-02-04 | 0.0% | 0.0% | 0.0% | No BL | No BL | -1014 | On Target |
| 324 | 5.2.3.24 | Executive Dashboard Updates 24 | 1d | 2022-02-18 | 2022-02-18 | 1513d | start no earlier than 2022-02-18 | 0.0% | 0.0% | 0.0% | No BL | No BL | -1014 | On Target |
| 325 | 5.2.3.25 | Executive Dashboard Updates 25 | 1d | 2022-03-04 | 2022-03-04 | 1504d | start no earlier than 2022-03-04 | 0.0% | 0.0% | 0.0% | No BL | No BL | -1014 | On Target |
| 326 | 5.2.3.26 | Executive Dashboard Updates 26 | 1d | 2022-03-18 | 2022-03-18 | 1494d | start no earlier than 2022-03-18 | 0.0% | 0.0% | 0.0% | No BL | No BL | -1014 | On Target |
| 327 | 5.2.3.27 | Executive Dashboard Updates 27 | 1d | 2022-04-01 | 2022-04-01 | 1484d | start no earlier than 2022-04-01 | 0.0% | 0.0% | 0.0% | No BL | No BL | -1014 | On Target |
| 328 | 5.2.3.28 | Executive Dashboard Updates 28 | 1d | 2022-04-15 | 2022-04-15 | 1474d | start no earlier than 2022-04-15 | 0.0% | 0.0% | 0.0% | No BL | No BL | -1014 | On Target |
| 329 | 5.2.3.29 | Executive Dashboard Updates 29 | 1d | 2022-04-29 | 2022-04-29 | 1465d | start no earlier than 2022-04-29 | 0.0% | 0.0% | 0.0% | No BL | No BL | -1014 | On Target |
| 330 | 5.2.3.30 | Executive Dashboard Updates 30 | 1d | 2022-05-13 | 2022-05-13 | 1455d | start no earlier than 2022-05-13 | 0.0% | 0.0% | 0.0% | No BL | No BL | -1014 | On Target |
| 331 | 5.2.3.31 | Executive Dashboard Updates 31 | 1d | 2022-05-27 | 2022-05-27 | 1445d | start no earlier than 2022-05-27 | 0.0% | 0.0% | 0.0% | No BL | No BL | -1014 | On Target |
| 332 | 5.2.3.32 | Executive Dashboard Updates 32 | 1d | 2022-06-10 | 2022-06-10 | 1437d | start no earlier than 2022-06-10 | 0.0% | 0.0% | 0.0% | No BL | No BL | -1014 | On Target |
| 333 | 5.2.3.33 | Executive Dashboard Updates 33 | 1d | 2022-06-24 | 2022-06-24 | 1427d | start no earlier than 2022-06-24 | 0.0% | 0.0% | 0.0% | No BL | No BL | -1014 | On Target |
| 334 | 5.2.3.34 | Executive Dashboard Updates 34 | 1d | 2022-07-08 | 2022-07-08 | 1418d | start no earlier than 2022-07-08 | 0.0% | 0.0% | 0.0% | No BL | No BL | -1014 | On Target |
| 335 | 5.2.3.35 | Executive Dashboard Updates 35 | 1d | 2022-07-22 | 2022-07-22 | 1408d | start no earlier than 2022-07-22 | 0.0% | 0.0% | 0.0% | No BL | No BL | -1014 | On Target |
| 336 | 5.2.3.36 | Executive Dashboard Updates 36 | 1d | 2022-08-05 | 2022-08-05 | 1398d | start no earlier than 2022-08-05 | 0.0% | 0.0% | 0.0% | No BL | No BL | -1014 | On Target |
| 337 | 5.2.3.37 | Executive Dashboard Updates 37 | 1d | 2022-08-19 | 2022-08-19 | 1388d | start no earlier than 2022-08-19 | 0.0% | 0.0% | 0.0% | No BL | No BL | -1014 | On Target |
| 338 | 5.2.3.38 | Executive Dashboard Updates 38 | 1d | 2022-09-02 | 2022-09-02 | 1378d | start no earlier than 2022-09-02 | 0.0% | 0.0% | 0.0% | No BL | No BL | -1014 | On Target |
| 339 | 5.2.3.39 | Executive Dashboard Updates 39 | 1d | 2022-09-16 | 2022-09-16 | 1369d | start no earlier than 2022-09-16 | 0.0% | 0.0% | 0.0% | No BL | No BL | -1014 | On Target |
| 340 | 5.2.3.40 | Executive Dashboard Updates 40 | 1d | 2022-09-30 | 2022-09-30 | 1359d | start no earlier than 2022-09-30 | 0.0% | 0.0% | 0.0% | No BL | No BL | -1014 | On Target |
| 341 | 5.2.3.41 | Executive Dashboard Updates 41 | 1d | 2022-10-14 | 2022-10-14 | 1350d | start no earlier than 2022-10-14 | 0.0% | 0.0% | 0.0% | No BL | No BL | -1014 | On Target |
| 342 | 5.2.3.42 | Executive Dashboard Updates 42 | 1d | 2022-10-28 | 2022-10-28 | 1340d | start no earlier than 2022-10-28 | 0.0% | 0.0% | 0.0% | No BL | No BL | -1014 | On Target |
| 343 | 5.2.3.43 | Executive Dashboard Updates 43 | 1d | 2022-11-14 | 2022-11-14 | 1330d | start no earlier than 2022-11-11 | 0.0% | 0.0% | 0.0% | No BL | No BL | -1014 | On Target |
| 344 | 5.2.3.44 | Executive Dashboard Updates 44 | 1d | 2022-11-28 | 2022-11-28 | 1322d | start no earlier than 2022-11-25 | 0.0% | 0.0% | 0.0% | No BL | No BL | -1014 | On Target |
| 345 | 5.2.3.45 | Executive Dashboard Updates 45 | 1d | 2022-12-09 | 2022-12-09 | 1313d | start no earlier than 2022-12-09 | 0.0% | 0.0% | 0.0% | No BL | No BL | -1014 | On Target |
| 346 | 5.2.3.46 | Executive Dashboard Updates 46 | 1d | 2022-12-23 | 2022-12-23 | 1303d | start no earlier than 2022-12-23 | 0.0% | 0.0% | 0.0% | No BL | No BL | -1014 | On Target |
| 347 | 5.2.3.47 | Executive Dashboard Updates 47 | 1d | 2023-01-06 | 2023-01-06 | 1295d | start no earlier than 2023-01-06 | 0.0% | 0.0% | 0.0% | No BL | No BL | -1014 | On Target |
| 348 | 5.2.3.48 | Executive Dashboard Updates 48 | 1d | 2023-01-20 | 2023-01-20 | 1286d | start no earlier than 2023-01-20 | 0.0% | 0.0% | 0.0% | No BL | No BL | -1014 | On Target |
| 349 | 5.2.3.49 | Executive Dashboard Updates 49 | 1d | 2023-02-03 | 2023-02-03 | 1276d | start no earlier than 2023-02-03 | 0.0% | 0.0% | 0.0% | No BL | No BL | -1014 | On Target |
| 350 | 5.2.3.50 | Executive Dashboard Updates 50 | 1d | 2023-02-17 | 2023-02-17 | 1266d | start no earlier than 2023-02-17 | 0.0% | 0.0% | 0.0% | No BL | No BL | -1014 | On Target |
| 351 | 5.2.3.51 | Executive Dashboard Updates 51 | 1d | 2023-03-03 | 2023-03-03 | 1257d | start no earlier than 2023-03-03 | 0.0% | 0.0% | 0.0% | No BL | No BL | -1014 | On Target |
| 352 | 5.2.3.52 | Executive Dashboard Updates 52 | 1d | 2023-03-17 | 2023-03-17 | 1247d | start no earlier than 2023-03-17 | 0.0% | 0.0% | 0.0% | No BL | No BL | -1014 | On Target |

| ID | WBS | Task | Duration | Start | Finish | Total slack | Constraint | _Current Target | _Baseline Target | _Progress % | _Projected Status | _Baseline % Status | _Days Since Update | _Current % Status |
| --- | --- | --- | --- | --- | --- | --- | --- | --- | --- | --- | --- | --- | --- | --- |
| 353 | 5.2.3.53 | Executive Dashboard Updates 53 | 1d | 2023-03-31 | 2023-03-31 | 1237d | start no earlier than 2023-03-31 | 0.0% | 0.0% | 0.0% | No BL | No BL | -1014 | On Target |
| 354 | 5.2.3.54 | Executive Dashboard Updates 54 | 1d | 2023-04-14 | 2023-04-14 | 1227d | start no earlier than 2023-04-14 | 0.0% | 0.0% | 0.0% | No BL | No BL | -1014 | On Target |
| 355 | 5.2.3.55 | Executive Dashboard Updates 55 | 1d | 2023-04-28 | 2023-04-28 | 1218d | start no earlier than 2023-04-28 | 0.0% | 0.0% | 0.0% | No BL | No BL | -1014 | On Target |
| 356 | 5.2.3.56 | Executive Dashboard Updates 56 | 1d | 2023-05-12 | 2023-05-12 | 1208d | start no earlier than 2023-05-12 | 0.0% | 0.0% | 0.0% | No BL | No BL | -1014 | On Target |
| 357 | 5.2.3.57 | Executive Dashboard Updates 57 | 1d | 2023-05-26 | 2023-05-26 | 1198d | start no earlier than 2023-05-26 | 0.0% | 0.0% | 0.0% | No BL | No BL | -1014 | On Target |
| 358 | 5.2.3.58 | Executive Dashboard Updates 58 | 1d | 2023-06-09 | 2023-06-09 | 1190d | start no earlier than 2023-06-09 | 0.0% | 0.0% | 0.0% | No BL | No BL | -1014 | On Target |
| 359 | 5.2.3.59 | Executive Dashboard Updates 59 | 1d | 2023-06-23 | 2023-06-23 | 1180d | start no earlier than 2023-06-23 | 0.0% | 0.0% | 0.0% | No BL | No BL | -1014 | On Target |
| 360 | 5.2.3.60 | Executive Dashboard Updates 60 | 1d | 2023-07-07 | 2023-07-07 | 1171d | start no earlier than 2023-07-07 | 0.0% | 0.0% | 0.0% | No BL | No BL | -1014 | On Target |
| 361 | 5.2.3.61 | Executive Dashboard Updates 61 | 1d | 2023-07-21 | 2023-07-21 | 1161d | start no earlier than 2023-07-21 | 0.0% | 0.0% | 0.0% | No BL | No BL | -1014 | On Target |
| 362 | 5.2.3.62 | Executive Dashboard Updates 62 | 1d | 2023-08-04 | 2023-08-04 | 1151d | start no earlier than 2023-08-04 | 0.0% | 0.0% | 0.0% | No BL | No BL | -1014 | On Target |
| 363 | 5.2.3.63 | Executive Dashboard Updates 63 | 1d | 2023-08-18 | 2023-08-18 | 1141d | start no earlier than 2023-08-18 | 0.0% | 0.0% | 0.0% | No BL | No BL | -1014 | On Target |
| 364 | 5.2.3.64 | Executive Dashboard Updates 64 | 1d | 2023-09-01 | 2023-09-01 | 1131d | start no earlier than 2023-09-01 | 0.0% | 0.0% | 0.0% | No BL | No BL | -1014 | On Target |
| 365 | 5.2.3.65 | Executive Dashboard Updates 65 | 1d | 2023-09-15 | 2023-09-15 | 1122d | start no earlier than 2023-09-15 | 0.0% | 0.0% | 0.0% | No BL | No BL | -1014 | On Target |
| 366 | 5.2.3.66 | Executive Dashboard Updates 66 | 1d | 2023-09-29 | 2023-09-29 | 1112d | start no earlier than 2023-09-29 | 0.0% | 0.0% | 0.0% | No BL | No BL | -1014 | On Target |
| 367 | 5.2.3.67 | Executive Dashboard Updates 67 | 1d | 2023-10-13 | 2023-10-13 | 1103d | start no earlier than 2023-10-13 | 0.0% | 0.0% | 0.0% | No BL | No BL | -1014 | On Target |
| 368 | 5.2.3.68 | Executive Dashboard Updates 68 | 1d | 2023-10-27 | 2023-10-27 | 1093d | start no earlier than 2023-10-27 | 0.0% | 0.0% | 0.0% | No BL | No BL | -1014 | On Target |
| 369 | 5.2.3.69 | Executive Dashboard Updates 69 | 1d | 2023-11-10 | 2023-11-10 | 1083d | start no earlier than 2023-11-10 | 0.0% | 0.0% | 0.0% | No BL | No BL | -1014 | On Target |
| 370 | 5.2.3.70 | Executive Dashboard Updates 70 | 1d | 2023-11-27 | 2023-11-27 | 1075d | start no earlier than 2023-11-24 | 0.0% | 0.0% | 0.0% | No BL | No BL | -1014 | On Target |
| 371 | 5.2.3.71 | Executive Dashboard Updates 71 | 1d | 2023-12-08 | 2023-12-08 | 1066d | start no earlier than 2023-12-08 | 0.0% | 0.0% | 0.0% | No BL | No BL | -1014 | On Target |
| 372 | 5.2.3.72 | Executive Dashboard Updates 72 | 1d | 2023-12-22 | 2023-12-22 | 1056d | start no earlier than 2023-12-22 | 0.0% | 0.0% | 0.0% | No BL | No BL | -1014 | On Target |
| 373 | 5.2.3.73 | Executive Dashboard Updates 73 | 1d | 2024-01-05 | 2024-01-05 | 1048d | start no earlier than 2024-01-05 | 0.0% | 0.0% | 0.0% | No BL | No BL | -1014 | On Target |
| 374 | 5.2.3.74 | Executive Dashboard Updates 74 | 1d | 2024-01-19 | 2024-01-19 | 1039d | start no earlier than 2024-01-19 | 0.0% | 0.0% | 0.0% | No BL | No BL | -1014 | On Target |
| 375 | 5.2.3.75 | Executive Dashboard Updates 75 | 1d | 2024-02-02 | 2024-02-02 | 1029d | start no earlier than 2024-02-02 | 0.0% | 0.0% | 0.0% | No BL | No BL | -1014 | On Target |
| 376 | 5.2.3.76 | Executive Dashboard Updates 76 | 1d | 2024-02-16 | 2024-02-16 | 1019d | start no earlier than 2024-02-16 | 0.0% | 0.0% | 0.0% | No BL | No BL | -1014 | On Target |
| 377 | 5.2.3.77 | Executive Dashboard Updates 77 | 1d | 2024-03-01 | 2024-03-01 | 1010d | start no earlier than 2024-03-01 | 0.0% | 0.0% | 0.0% | No BL | No BL | -1014 | On Target |
| 378 | 5.2.3.78 | Executive Dashboard Updates 78 | 1d | 2024-03-15 | 2024-03-15 | 1000d | start no earlier than 2024-03-15 | 0.0% | 0.0% | 0.0% | No BL | No BL | -1014 | On Target |

| ID | WBS | Task | Duration | Start | Finish | Predecessors | Total slack | Free slack | Constraint | _Current Target | _Baseline Target | _Progress % | _Projected Status | _Baseline % Status | _Days Since Update | _Current % Status |
| --- | --- | --- | --- | --- | --- | --- | --- | --- | --- | --- | --- | --- | --- | --- | --- | --- |
| 379 | 5.2.4 | **Kick-Off Meetings (See PMO-2-c Kick-Off Meetings Protocol Guide)** | 131d | 2021-04-01 | 2021-10-07 |  | 1601d |  |  | 0.0% | 0.0% |  |  |  |  |  |
| 380 | 5.2.4.1 | **Phase NNN - Kick-Off Meeting (Will be replicated for each Phase. Procurement, Contract, Requirements, Design/Dev, Testing, OCM, Implementation, CMS Certification, Lesson Learned)** | 131d | 2021-04-01 | 2021-10-07 |  | 1601d |  |  | 0.0% | 0.0% | 0.0% | No BL | No BL | -424 | On Target |
| 381 | 5.2.4.1.1 | Kick-off Assessment | 1d | 2021-04-01 | 2021-04-01 |  | 1731d |  | start no earlier than 2021-04-01 | 0.0% | 0.0% | 0.0% | No BL | No BL | -1014 | On Target |
| 382 | 5.2.4.1.2 | Kick-off Expectations Sessions | 1d | 2021-05-03 | 2021-05-03 |  | 1710d |  | start no earlier than 2021-05-01 | 0.0% | 0.0% | 0.0% | No BL | No BL | -1014 | On Target |
| 383 | 5.2.4.1.3 | Develop Agenda and Supporting Material | 5d | 2021-06-01 | 2021-06-08 |  | 1686d |  | start no earlier than 2021-06-01 | 0.0% | 0.0% | 0.0% | No BL | No BL | -1014 | On Target |
| 384 | 5.2.4.1.4 | Obtain Approval of Agenda and Supporting Material | 3d | 2021-07-01 | 2021-07-06 |  | 1667d |  | start no earlier than 2021-07-01 | 0.0% | 0.0% | 0.0% | No BL | No BL | -1014 | On Target |
| 385 | 5.2.4.1.5 | Kick-Off Dry Run | 1d | 2021-08-02 | 2021-08-02 |  | 1648d |  | start no earlier than 2021-08-01 | 0.0% | 0.0% | 0.0% | No BL | No BL | -1014 | On Target |
| 386 | 5.2.4.1.6 | Kick-Off Meeting | 1d | 2021-09-01 | 2021-09-01 |  | 1626d |  | start no earlier than 2021-09-01 | 0.0% | 0.0% | 0.0% | No BL | No BL | -1014 | On Target |
| 387 | 5.2.4.1.7 | Closedown | 5d | 2021-10-01 | 2021-10-07 |  | 1601d |  | start no earlier than 2021-10-01 | 0.0% | 0.0% | 0.0% | No BL | No BL | -1014 | On Target |
| 388 | 5.2.5 | **Lessons Learned (See PMO-2-n-05 Lesson Learned Protocol Reference Guide)** | 23d | 2021-01-04 | 2021-02-04 |  | 1770d |  |  | 0.0% | 0.0% |  |  |  |  |  |
| 389 | 5.2.5.1 | **Iteration - Phase/# (Will be replicated for each Phase. Specific iteration will be determined during Project schedule development)** | 23d | 2021-01-04 | 2021-02-04 |  | 1770d |  |  | 0.0% | 0.0% | 0.0% | No BL | No BL | -285 | On Target |
| 390 | 5.2.5.1.1 | Review AMMP Lessons Learned | 2d | 2021-01-04 | 2021-01-05 |  | 1770d | 0d |  | 0.0% | 0.0% | 0.0% | No BL | No BL | -1014 | On Target |
| 391 | 5.2.5.1.2 | Uncover Lessons Learned | 3d | 2021-01-06 | 2021-01-08 | 390 | 1770d | 0d |  | 0.0% | 0.0% | 0.0% | No BL | No BL | -1014 | On Target |
| 392 | 5.2.5.1.3 | Document Lessons Learned | 5d | 2021-01-11 | 2021-01-15 | 391 | 1770d | 0d |  | 0.0% | 0.0% | 0.0% | No BL | No BL | -1014 | On Target |
| 393 | 5.2.5.1.4 | Analyze Lessons Learned | 2d | 2021-01-19 | 2021-01-20 | 392 | 1770d | 0d |  | 0.0% | 0.0% | 0.0% | No BL | No BL | -1014 | On Target |
| 394 | 5.2.5.1.5 | Formulate Action Plan | 3d | 2021-01-21 | 2021-01-25 | 393 | 1770d | 0d |  | 0.0% | 0.0% | 0.0% | No BL | No BL | -1014 | On Target |
| 395 | 5.2.5.1.6 | Disseminate Lessons Learned | 1d | 2021-01-26 | 2021-01-26 | 394 | 1770d | 0d |  | 0.0% | 0.0% | 0.0% | No BL | No BL | -1014 | On Target |
| 396 | 5.2.5.1.7 | AMMP PMO Review of Lessons Learned | 5d | 2021-01-27 | 2021-02-02 | 395 | 1770d | 0d |  | 0.0% | 0.0% | 0.0% | No BL | No BL | -1014 | On Target |
| 397 | 5.2.5.1.8 | Archive Lessons Learned | 2d | 2021-02-03 | 2021-02-04 | 396 | 1770d |  |  | 0.0% | 0.0% | 0.0% | No BL | No BL | -1014 | On Target |
| 398 | 5.2.6 | **OCM Effectiveness Evaluations (See PMO-2-y OCM Effectiveness Evaluation Plan)** | 25d | 2021-01-04 | 2021-02-08 |  | 1768d |  |  | 0.0% | 0.0% |  |  |  |  |  |
| 399 | 5.2.6.1 | **Iteration - Phase/# (Will be replicated multiple times. Specific iteration will be determined during Project schedule development)** | 25d | 2021-01-04 | 2021-02-08 |  | 1768d |  |  | 0.0% | 0.0% | 0.0% | No BL | No BL | -285 | On Target |
| 400 | 5.2.6.1.1 | Send assessment survey link to Stakeholder Users | 1d | 2021-01-04 | 2021-01-04 |  | 1768d | 0d |  | 0.0% | 0.0% | 0.0% | No BL | No BL | -1014 | On Target |
| 401 | 5.2.6.1.2 | Send assessment survey link to FPO Managers | 1d | 2021-01-04 | 2021-01-04 |  | 1768d | 0d |  | 0.0% | 0.0% | 0.0% | No BL | No BL | -1014 | On Target |
| 402 | 5.2.6.1.3 | Track participation of Stakeholder User responses collected in survey tool – send reminders | 1d | 2021-01-12 | 2021-01-12 | 400FS+5d | 1768d | 0d |  | 0.0% | 0.0% | 0.0% | No BL | No BL | -1014 | On Target |
| 403 | 5.2.6.1.4 | Track participation of FPO Manager responses in survey tool – send reminders | 1d | 2021-01-12 | 2021-01-12 | 401FS+5d | 1768d | 0d |  | 0.0% | 0.0% | 0.0% | No BL | No BL | -1014 | On Target |
| 404 | 5.2.6.1.5 | Schedule PCT Assessment with MES team | 1d | 2021-01-13 | 2021-01-13 | 402, 403 | 1773d | 5d |  | 0.0% | 0.0% | 0.0% | No BL | No BL | -1014 | On Target |
| 405 | 5.2.6.1.6 | Export results of Stakeholder User Assessments | 1d | 2021-01-13 | 2021-01-13 | 402 | 1768d | 0d |  | 0.0% | 0.0% | 0.0% | No BL | No BL | -1014 | On Target |
| 406 | 5.2.6.1.7 | Export results of FPO Manager Assessments | 1d | 2021-01-13 | 2021-01-13 | 403 | 1768d | 0d |  | 0.0% | 0.0% | 0.0% | No BL | No BL | -1014 | On Target |
| 407 | 5.2.6.1.8 | Begin OCM Effectiveness Evaluation report | 5d | 2021-01-14 | 2021-01-21 | 405, 406 | 1768d | 0d |  | 0.0% | 0.0% | 0.0% | No BL | No BL | -1014 | On Target |
| 408 | 5.2.6.1.9 | Participate in PCT Assessment | 1d | 2021-01-22 | 2021-01-22 | 404, 407 | 1768d | 0d |  | 0.0% | 0.0% | 0.0% | No BL | No BL | -1014 | On Target |
| 409 | 5.2.6.1.10 | Document PCT progress | 5d | 2021-01-25 | 2021-01-29 | 408 | 1768d | 0d |  | 0.0% | 0.0% | 0.0% | No BL | No BL | -1014 | On Target |
| 410 | 5.2.6.1.11 | Identify Action Steps for improvement | 3d | 2021-02-01 | 2021-02-03 | 409 | 1768d | 0d |  | 0.0% | 0.0% | 0.0% | No BL | No BL | -1014 | On Target |
| 411 | 5.2.6.1.12 | Deliver OCM Effectiveness Evaluation Report | 1d | 2021-02-04 | 2021-02-04 | 410 | 1768d | 0d |  | 0.0% | 0.0% | 0.0% | No BL | No BL | -1014 | On Target |
| 412 | 5.2.6.1.13 | Report on Action Steps and/or Risks Logged | 2d | 2021-02-05 | 2021-02-08 | 411 | 1768d |  |  | 0.0% | 0.0% | 0.0% | No BL | No BL | -1014 | On Target |

| ID | WBS | Task | Type | Duration | Start | Finish | Predecessors | Total slack | Free slack | Constraint | _Current Target | _Baseline Target | _Progress % | _Projected Status | _Baseline % Status | _Days Since Update | _Current % Status |
| --- | --- | --- | --- | --- | --- | --- | --- | --- | --- | --- | --- | --- | --- | --- | --- | --- | --- |
| 413 | 5.1 | **Contract/Budget Review - Annually** |  | 261d | 2021-12-23 | 2023-01-13 |  | 1290d |  |  | 0.0% | 0.0% | 0.0% | No BL | No BL | -18 | Off Target |
| 414 | 5.1.1 | **CY N->N+1 - Contract/Budget Review - Annually** |  | 20d | 2021-12-23 | 2022-01-25 |  | 1290d |  |  | 0.0% | 0.0% | 0.0% | No BL | No BL | -18 | Off Target |
| 415 | 5.1.1.1 | Review Contract, Budget, Invoice Tracker |  | 3d | 2021-12-23 | 2021-12-28 | 7FS+9mo | 1290d | 0d |  | 0.0% | 0.0% | 0.0% | No BL | No BL | -1014 | On Target |
| 416 | 5.1.1.2 | Identify updates needed for Schedule, Invoice, Deliverables |  | 5d | 2021-12-29 | 2022-01-06 | 415 | 1531d | 0d |  | 0.0% | 0.0% | 0.0% | No BL | No BL | -1014 | On Target |
| 417 | 5.1.1.3 | Implement updates needed for Schedule, Invoice, Deliverables |  | 7d | 2022-01-07 | 2022-01-18 | 416 | 1531d | 0d |  | 0.0% | 0.0% | 0.0% | No BL | No BL | -1014 | On Target |
| 418 | 5.1.1.4 | Verify updates needed for Schedule, Invoice, Deliverables |  | 5d | 2022-01-19 | 2022-01-25 | 417 | 1531d | 0d |  | 0.0% | 0.0% | 0.0% | No BL | No BL | -1014 | On Target |
| 419 | 5.1.1.5 | CY N - Contract Review Artifact updates - Complete | milestone | 0d | 2022-01-25 | 2022-01-25 | 418 | 1531d |  |  | 0.0% | 0.0% | 0.0% | No BL | No BL | -1014 | On Target |
| 420 | 5.1.2 | **CY N+1->N+2 - Contract/Budget Review - Annually** |  | 18d | 2022-12-19 | 2023-01-13 |  | 1290d |  |  | 0.0% | 0.0% | 0.0% | No BL | No BL | -18 | Off Target |
| 421 | 5.1.2.1 | Review Contract, Budget, Invoice Tracker |  | 3d | 2022-12-19 | 2022-12-21 | 415FS+12mo | 1290d | 0d |  | 0.0% | 0.0% | 0.0% | No BL | No BL | -1014 | On Target |
| 422 | 5.1.2.2 | Identify updates needed for Schedule, Invoice, Deliverables |  | 5d | 2022-12-22 | 2022-12-29 | 421 | 1290d | 0d |  | 0.0% | 0.0% | 0.0% | No BL | No BL | -1014 | On Target |
| 423 | 5.1.2.3 | Implement updates needed for Schedule, Invoice, Deliverables |  | 5d | 2022-12-30 | 2023-01-06 | 422 | 1290d | 0d |  | 0.0% | 0.0% | 0.0% | No BL | No BL | -1014 | On Target |
| 424 | 5.1.2.4 | Verify updates needed for Schedule, Invoice, Deliverables |  | 5d | 2023-01-09 | 2023-01-13 | 423 | 1290d | 0d |  | 0.0% | 0.0% | 0.0% | No BL | No BL | -1014 | On Target |
| 425 | 5.1.2.5 | CY N+1 - Contract Review Artifact updates - Complete | milestone | 0d | 2023-01-13 | 2023-01-13 | 424 | 1290d |  |  | 0.0% | 0.0% | 0.0% | No BL | No BL | -1014 | On Target |
| 426 | 5.3 | **Meetings** |  | 738d | 2021-04-01 | 2024-03-25 |  | 994d |  |  | 0.0% | 0.0% | 0.0% | No BL | No BL | -97 | Off Target |
| 427 | 5.3.1 | **Module Status Meeting** |  | 721d | 2021-04-07 | 2024-03-06 |  | 1007d |  |  | 0.0% | 0.0% |  |  |  |  |  |
| 428 | 5.3.1.1 | Module Status Meeting 1 |  | 1d | 2021-04-07 | 2021-04-07 |  | 1727d |  | start no earlier than 2021-04-07 | 0.0% | 0.0% | 0.0% | No BL | No BL | -1014 | On Target |
| 429 | 5.3.1.2 | Module Status Meeting 2 |  | 1d | 2021-05-05 | 2021-05-05 |  | 1708d |  | start no earlier than 2021-05-05 | 0.0% | 0.0% | 0.0% | No BL | No BL | -1014 | On Target |
| 430 | 5.3.1.3 | Module Status Meeting 3 |  | 1d | 2021-06-02 | 2021-06-02 |  | 1689d |  | start no earlier than 2021-06-02 | 0.0% | 0.0% | 0.0% | No BL | No BL | -1014 | On Target |
| 431 | 5.3.1.4 | Module Status Meeting 4 |  | 1d | 2021-07-07 | 2021-07-07 |  | 1666d |  | start no earlier than 2021-07-07 | 0.0% | 0.0% | 0.0% | No BL | No BL | -1014 | On Target |
| 432 | 5.3.1.5 | Module Status Meeting 5 |  | 1d | 2021-08-04 | 2021-08-04 |  | 1646d |  | start no earlier than 2021-08-04 | 0.0% | 0.0% | 0.0% | No BL | No BL | -1014 | On Target |
| 433 | 5.3.1.6 | Module Status Meeting 6 |  | 1d | 2021-09-01 | 2021-09-01 |  | 1626d |  | start no earlier than 2021-09-01 | 0.0% | 0.0% | 0.0% | No BL | No BL | -1014 | On Target |
| 434 | 5.3.1.7 | Module Status Meeting 7 |  | 1d | 2021-10-06 | 2021-10-06 |  | 1602d |  | start no earlier than 2021-10-06 | 0.0% | 0.0% | 0.0% | No BL | No BL | -1014 | On Target |
| 435 | 5.3.1.8 | Module Status Meeting 8 |  | 1d | 2021-11-03 | 2021-11-03 |  | 1583d |  | start no earlier than 2021-11-03 | 0.0% | 0.0% | 0.0% | No BL | No BL | -1014 | On Target |
| 436 | 5.3.1.9 | Module Status Meeting 9 |  | 1d | 2021-12-01 | 2021-12-01 |  | 1566d |  | start no earlier than 2021-12-01 | 0.0% | 0.0% | 0.0% | No BL | No BL | -1014 | On Target |
| 437 | 5.3.1.10 | Module Status Meeting 10 |  | 1d | 2022-01-05 | 2022-01-05 |  | 1544d |  | start no earlier than 2022-01-05 | 0.0% | 0.0% | 0.0% | No BL | No BL | -1014 | On Target |
| 438 | 5.3.1.11 | Module Status Meeting 11 |  | 1d | 2022-02-02 | 2022-02-02 |  | 1525d |  | start no earlier than 2022-02-02 | 0.0% | 0.0% | 0.0% | No BL | No BL | -1014 | On Target |
| 439 | 5.3.1.12 | Module Status Meeting 12 |  | 1d | 2022-03-02 | 2022-03-02 |  | 1506d |  | start no earlier than 2022-03-02 | 0.0% | 0.0% | 0.0% | No BL | No BL | -1014 | On Target |
| 440 | 5.3.1.13 | Module Status Meeting 13 |  | 1d | 2022-04-06 | 2022-04-06 |  | 1481d |  | start no earlier than 2022-04-06 | 0.0% | 0.0% | 0.0% | No BL | No BL | -1014 | On Target |
| 441 | 5.3.1.14 | Module Status Meeting 14 |  | 1d | 2022-05-04 | 2022-05-04 |  | 1462d |  | start no earlier than 2022-05-04 | 0.0% | 0.0% | 0.0% | No BL | No BL | -1014 | On Target |
| 442 | 5.3.1.15 | Module Status Meeting 15 |  | 1d | 2022-06-01 | 2022-06-01 |  | 1443d |  | start no earlier than 2022-06-01 | 0.0% | 0.0% | 0.0% | No BL | No BL | -1014 | On Target |
| 443 | 5.3.1.16 | Module Status Meeting 16 |  | 1d | 2022-07-06 | 2022-07-06 |  | 1420d |  | start no earlier than 2022-07-06 | 0.0% | 0.0% | 0.0% | No BL | No BL | -1014 | On Target |
| 444 | 5.3.1.17 | Module Status Meeting 17 |  | 1d | 2022-08-03 | 2022-08-03 |  | 1400d |  | start no earlier than 2022-08-03 | 0.0% | 0.0% | 0.0% | No BL | No BL | -1014 | On Target |
| 445 | 5.3.1.18 | Module Status Meeting 18 |  | 1d | 2022-09-07 | 2022-09-07 |  | 1376d |  | start no earlier than 2022-09-07 | 0.0% | 0.0% | 0.0% | No BL | No BL | -1014 | On Target |
| 446 | 5.3.1.19 | Module Status Meeting 19 |  | 1d | 2022-10-05 | 2022-10-05 |  | 1356d |  | start no earlier than 2022-10-05 | 0.0% | 0.0% | 0.0% | No BL | No BL | -1014 | On Target |
| 447 | 5.3.1.20 | Module Status Meeting 20 |  | 1d | 2022-11-02 | 2022-11-02 |  | 1337d |  | start no earlier than 2022-11-02 | 0.0% | 0.0% | 0.0% | No BL | No BL | -1014 | On Target |
| 448 | 5.3.1.21 | Module Status Meeting 21 |  | 1d | 2022-12-07 | 2022-12-07 |  | 1315d |  | start no earlier than 2022-12-07 | 0.0% | 0.0% | 0.0% | No BL | No BL | -1014 | On Target |
| 449 | 5.3.1.22 | Module Status Meeting 22 |  | 1d | 2023-01-04 | 2023-01-04 |  | 1297d |  | start no earlier than 2023-01-04 | 0.0% | 0.0% | 0.0% | No BL | No BL | -1014 | On Target |
| 450 | 5.3.1.23 | Module Status Meeting 23 |  | 1d | 2023-02-01 | 2023-02-01 |  | 1278d |  | start no earlier than 2023-02-01 | 0.0% | 0.0% | 0.0% | No BL | No BL | -1014 | On Target |
| 451 | 5.3.1.24 | Module Status Meeting 24 |  | 1d | 2023-03-01 | 2023-03-01 |  | 1259d |  | start no earlier than 2023-03-01 | 0.0% | 0.0% | 0.0% | No BL | No BL | -1014 | On Target |
| 452 | 5.3.1.25 | Module Status Meeting 25 |  | 1d | 2023-04-05 | 2023-04-05 |  | 1234d |  | start no earlier than 2023-04-05 | 0.0% | 0.0% | 0.0% | No BL | No BL | -1014 | On Target |
| 453 | 5.3.1.26 | Module Status Meeting 26 |  | 1d | 2023-05-03 | 2023-05-03 |  | 1215d |  | start no earlier than 2023-05-03 | 0.0% | 0.0% | 0.0% | No BL | No BL | -1014 | On Target |
| 454 | 5.3.1.27 | Module Status Meeting 27 |  | 1d | 2023-06-07 | 2023-06-07 |  | 1192d |  | start no earlier than 2023-06-07 | 0.0% | 0.0% | 0.0% | No BL | No BL | -1014 | On Target |
| 455 | 5.3.1.28 | Module Status Meeting 28 |  | 1d | 2023-07-05 | 2023-07-05 |  | 1173d |  | start no earlier than 2023-07-05 | 0.0% | 0.0% | 0.0% | No BL | No BL | -1014 | On Target |
| 456 | 5.3.1.29 | Module Status Meeting 29 |  | 1d | 2023-08-02 | 2023-08-02 |  | 1153d |  | start no earlier than 2023-08-02 | 0.0% | 0.0% | 0.0% | No BL | No BL | -1014 | On Target |
| 457 | 5.3.1.30 | Module Status Meeting 30 |  | 1d | 2023-09-06 | 2023-09-06 |  | 1129d |  | start no earlier than 2023-09-06 | 0.0% | 0.0% | 0.0% | No BL | No BL | -1014 | On Target |
| 458 | 5.3.1.31 | Module Status Meeting 31 |  | 1d | 2023-10-04 | 2023-10-04 |  | 1109d |  | start no earlier than 2023-10-04 | 0.0% | 0.0% | 0.0% | No BL | No BL | -1014 | On Target |
| 459 | 5.3.1.32 | Module Status Meeting 32 |  | 1d | 2023-11-01 | 2023-11-01 |  | 1090d |  | start no earlier than 2023-11-01 | 0.0% | 0.0% | 0.0% | No BL | No BL | -1014 | On Target |
| 460 | 5.3.1.33 | Module Status Meeting 33 |  | 1d | 2023-12-06 | 2023-12-06 |  | 1068d |  | start no earlier than 2023-12-06 | 0.0% | 0.0% | 0.0% | No BL | No BL | -1014 | On Target |
| 461 | 5.3.1.34 | Module Status Meeting 34 |  | 1d | 2024-01-03 | 2024-01-03 |  | 1050d |  | start no earlier than 2024-01-03 | 0.0% | 0.0% | 0.0% | No BL | No BL | -1014 | On Target |
| 462 | 5.3.1.35 | Module Status Meeting 35 |  | 1d | 2024-02-07 | 2024-02-07 |  | 1026d |  | start no earlier than 2024-02-07 | 0.0% | 0.0% | 0.0% | No BL | No BL | -1014 | On Target |
| 463 | 5.3.1.36 | Module Status Meeting 36 |  | 1d | 2024-03-06 | 2024-03-06 |  | 1007d |  | start no earlier than 2024-03-06 | 0.0% | 0.0% | 0.0% | No BL | No BL | -1014 | On Target |

| ID | WBS | Task | Duration | Start | Finish | Total slack | Constraint | _Current Target | _Baseline Target | _Progress % | _Projected Status | _Baseline % Status | _Days Since Update | _Current % Status |
| --- | --- | --- | --- | --- | --- | --- | --- | --- | --- | --- | --- | --- | --- | --- |
| 464 | 5.3.2 | **Weekly Standup (What Occurred, Whats Coming, Blokcers)** | 736d | 2021-04-05 | 2024-03-25 | 994d |  | 0.0% | 0.0% |  |  |  |  |  |
| 465 | 5.3.2.1 | Weekly Standup (What Occurred, Whats Coming, Blokcers) 1 | 1d | 2021-04-05 | 2021-04-05 | 1729d | start no earlier than 2021-04-05 | 0.0% | 0.0% | 0.0% | No BL | No BL | -1014 | On Target |
| 466 | 5.3.2.2 | Weekly Standup (What Occurred, Whats Coming, Blokcers) 2 | 1d | 2021-04-12 | 2021-04-12 | 1724d | start no earlier than 2021-04-12 | 0.0% | 0.0% | 0.0% | No BL | No BL | -1014 | On Target |
| 467 | 5.3.2.3 | Weekly Standup (What Occurred, Whats Coming, Blokcers) 3 | 1d | 2021-04-19 | 2021-04-19 | 1719d | start no earlier than 2021-04-19 | 0.0% | 0.0% | 0.0% | No BL | No BL | -1014 | On Target |
| 468 | 5.3.2.4 | Weekly Standup (What Occurred, Whats Coming, Blokcers) 4 | 1d | 2021-04-27 | 2021-04-27 | 1714d | start no earlier than 2021-04-26 | 0.0% | 0.0% | 0.0% | No BL | No BL | -1014 | On Target |
| 469 | 5.3.2.5 | Weekly Standup (What Occurred, Whats Coming, Blokcers) 5 | 1d | 2021-05-03 | 2021-05-03 | 1710d | start no earlier than 2021-05-03 | 0.0% | 0.0% | 0.0% | No BL | No BL | -1014 | On Target |
| 470 | 5.3.2.6 | Weekly Standup (What Occurred, Whats Coming, Blokcers) 6 | 1d | 2021-05-10 | 2021-05-10 | 1705d | start no earlier than 2021-05-10 | 0.0% | 0.0% | 0.0% | No BL | No BL | -1014 | On Target |
| 471 | 5.3.2.7 | Weekly Standup (What Occurred, Whats Coming, Blokcers) 7 | 1d | 2021-05-17 | 2021-05-17 | 1700d | start no earlier than 2021-05-17 | 0.0% | 0.0% | 0.0% | No BL | No BL | -1014 | On Target |
| 472 | 5.3.2.8 | Weekly Standup (What Occurred, Whats Coming, Blokcers) 8 | 1d | 2021-05-24 | 2021-05-24 | 1695d | start no earlier than 2021-05-24 | 0.0% | 0.0% | 0.0% | No BL | No BL | -1014 | On Target |
| 473 | 5.3.2.9 | Weekly Standup (What Occurred, Whats Coming, Blokcers) 9 | 1d | 2021-06-01 | 2021-06-01 | 1690d | start no earlier than 2021-05-31 | 0.0% | 0.0% | 0.0% | No BL | No BL | -1014 | On Target |
| 474 | 5.3.2.10 | Weekly Standup (What Occurred, Whats Coming, Blokcers) 10 | 1d | 2021-06-08 | 2021-06-08 | 1686d | start no earlier than 2021-06-07 | 0.0% | 0.0% | 0.0% | No BL | No BL | -1014 | On Target |
| 475 | 5.3.2.11 | Weekly Standup (What Occurred, Whats Coming, Blokcers) 11 | 1d | 2021-06-14 | 2021-06-14 | 1682d | start no earlier than 2021-06-14 | 0.0% | 0.0% | 0.0% | No BL | No BL | -1014 | On Target |
| 476 | 5.3.2.12 | Weekly Standup (What Occurred, Whats Coming, Blokcers) 12 | 1d | 2021-06-21 | 2021-06-21 | 1677d | start no earlier than 2021-06-21 | 0.0% | 0.0% | 0.0% | No BL | No BL | -1014 | On Target |
| 477 | 5.3.2.13 | Weekly Standup (What Occurred, Whats Coming, Blokcers) 13 | 1d | 2021-06-28 | 2021-06-28 | 1672d | start no earlier than 2021-06-28 | 0.0% | 0.0% | 0.0% | No BL | No BL | -1014 | On Target |
| 478 | 5.3.2.14 | Weekly Standup (What Occurred, Whats Coming, Blokcers) 14 | 1d | 2021-07-06 | 2021-07-06 | 1667d | start no earlier than 2021-07-05 | 0.0% | 0.0% | 0.0% | No BL | No BL | -1014 | On Target |
| 479 | 5.3.2.15 | Weekly Standup (What Occurred, Whats Coming, Blokcers) 15 | 1d | 2021-07-12 | 2021-07-12 | 1663d | start no earlier than 2021-07-12 | 0.0% | 0.0% | 0.0% | No BL | No BL | -1014 | On Target |
| 480 | 5.3.2.16 | Weekly Standup (What Occurred, Whats Coming, Blokcers) 16 | 1d | 2021-07-19 | 2021-07-19 | 1658d | start no earlier than 2021-07-19 | 0.0% | 0.0% | 0.0% | No BL | No BL | -1014 | On Target |
| 481 | 5.3.2.17 | Weekly Standup (What Occurred, Whats Coming, Blokcers) 17 | 1d | 2021-07-26 | 2021-07-26 | 1653d | start no earlier than 2021-07-26 | 0.0% | 0.0% | 0.0% | No BL | No BL | -1014 | On Target |
| 482 | 5.3.2.18 | Weekly Standup (What Occurred, Whats Coming, Blokcers) 18 | 1d | 2021-08-02 | 2021-08-02 | 1648d | start no earlier than 2021-08-02 | 0.0% | 0.0% | 0.0% | No BL | No BL | -1014 | On Target |
| 483 | 5.3.2.19 | Weekly Standup (What Occurred, Whats Coming, Blokcers) 19 | 1d | 2021-08-09 | 2021-08-09 | 1643d | start no earlier than 2021-08-09 | 0.0% | 0.0% | 0.0% | No BL | No BL | -1014 | On Target |
| 484 | 5.3.2.20 | Weekly Standup (What Occurred, Whats Coming, Blokcers) 20 | 1d | 2021-08-16 | 2021-08-16 | 1638d | start no earlier than 2021-08-16 | 0.0% | 0.0% | 0.0% | No BL | No BL | -1014 | On Target |
| 485 | 5.3.2.21 | Weekly Standup (What Occurred, Whats Coming, Blokcers) 21 | 1d | 2021-08-23 | 2021-08-23 | 1633d | start no earlier than 2021-08-23 | 0.0% | 0.0% | 0.0% | No BL | No BL | -1014 | On Target |
| 486 | 5.3.2.22 | Weekly Standup (What Occurred, Whats Coming, Blokcers) 22 | 1d | 2021-08-30 | 2021-08-30 | 1628d | start no earlier than 2021-08-30 | 0.0% | 0.0% | 0.0% | No BL | No BL | -1014 | On Target |
| 487 | 5.3.2.23 | Weekly Standup (What Occurred, Whats Coming, Blokcers) 23 | 1d | 2021-09-07 | 2021-09-07 | 1623d | start no earlier than 2021-09-06 | 0.0% | 0.0% | 0.0% | No BL | No BL | -1014 | On Target |
| 488 | 5.3.2.24 | Weekly Standup (What Occurred, Whats Coming, Blokcers) 24 | 1d | 2021-09-13 | 2021-09-13 | 1619d | start no earlier than 2021-09-13 | 0.0% | 0.0% | 0.0% | No BL | No BL | -1014 | On Target |
| 489 | 5.3.2.25 | Weekly Standup (What Occurred, Whats Coming, Blokcers) 25 | 1d | 2021-09-20 | 2021-09-20 | 1614d | start no earlier than 2021-09-20 | 0.0% | 0.0% | 0.0% | No BL | No BL | -1014 | On Target |
| 490 | 5.3.2.26 | Weekly Standup (What Occurred, Whats Coming, Blokcers) 26 | 1d | 2021-09-27 | 2021-09-27 | 1609d | start no earlier than 2021-09-27 | 0.0% | 0.0% | 0.0% | No BL | No BL | -1014 | On Target |
| 491 | 5.3.2.27 | Weekly Standup (What Occurred, Whats Coming, Blokcers) 27 | 1d | 2021-10-04 | 2021-10-04 | 1604d | start no earlier than 2021-10-04 | 0.0% | 0.0% | 0.0% | No BL | No BL | -1014 | On Target |
| 492 | 5.3.2.28 | Weekly Standup (What Occurred, Whats Coming, Blokcers) 28 | 1d | 2021-10-12 | 2021-10-12 | 1599d | start no earlier than 2021-10-11 | 0.0% | 0.0% | 0.0% | No BL | No BL | -1014 | On Target |
| 493 | 5.3.2.29 | Weekly Standup (What Occurred, Whats Coming, Blokcers) 29 | 1d | 2021-10-18 | 2021-10-18 | 1595d | start no earlier than 2021-10-18 | 0.0% | 0.0% | 0.0% | No BL | No BL | -1014 | On Target |
| 494 | 5.3.2.30 | Weekly Standup (What Occurred, Whats Coming, Blokcers) 30 | 1d | 2021-10-25 | 2021-10-25 | 1590d | start no earlier than 2021-10-25 | 0.0% | 0.0% | 0.0% | No BL | No BL | -1014 | On Target |
| 495 | 5.3.2.31 | Weekly Standup (What Occurred, Whats Coming, Blokcers) 31 | 1d | 2021-11-01 | 2021-11-01 | 1585d | start no earlier than 2021-11-01 | 0.0% | 0.0% | 0.0% | No BL | No BL | -1014 | On Target |
| 496 | 5.3.2.32 | Weekly Standup (What Occurred, Whats Coming, Blokcers) 32 | 1d | 2021-11-08 | 2021-11-08 | 1580d | start no earlier than 2021-11-08 | 0.0% | 0.0% | 0.0% | No BL | No BL | -1014 | On Target |
| 497 | 5.3.2.33 | Weekly Standup (What Occurred, Whats Coming, Blokcers) 33 | 1d | 2021-11-15 | 2021-11-15 | 1576d | start no earlier than 2021-11-15 | 0.0% | 0.0% | 0.0% | No BL | No BL | -1014 | On Target |
| 498 | 5.3.2.34 | Weekly Standup (What Occurred, Whats Coming, Blokcers) 34 | 1d | 2021-11-22 | 2021-11-22 | 1571d | start no earlier than 2021-11-22 | 0.0% | 0.0% | 0.0% | No BL | No BL | -1014 | On Target |
| 499 | 5.3.2.35 | Weekly Standup (What Occurred, Whats Coming, Blokcers) 35 | 1d | 2021-11-29 | 2021-11-29 | 1568d | start no earlier than 2021-11-29 | 0.0% | 0.0% | 0.0% | No BL | No BL | -1014 | On Target |
| 500 | 5.3.2.36 | Weekly Standup (What Occurred, Whats Coming, Blokcers) 36 | 1d | 2021-12-06 | 2021-12-06 | 1563d | start no earlier than 2021-12-06 | 0.0% | 0.0% | 0.0% | No BL | No BL | -1014 | On Target |
| 501 | 5.3.2.37 | Weekly Standup (What Occurred, Whats Coming, Blokcers) 37 | 1d | 2021-12-13 | 2021-12-13 | 1558d | start no earlier than 2021-12-13 | 0.0% | 0.0% | 0.0% | No BL | No BL | -1014 | On Target |
| 502 | 5.3.2.38 | Weekly Standup (What Occurred, Whats Coming, Blokcers) 38 | 1d | 2021-12-20 | 2021-12-20 | 1553d | start no earlier than 2021-12-20 | 0.0% | 0.0% | 0.0% | No BL | No BL | -1014 | On Target |
| 503 | 5.3.2.39 | Weekly Standup (What Occurred, Whats Coming, Blokcers) 39 | 1d | 2021-12-27 | 2021-12-27 | 1549d | start no earlier than 2021-12-27 | 0.0% | 0.0% | 0.0% | No BL | No BL | -1014 | On Target |
| 504 | 5.3.2.40 | Weekly Standup (What Occurred, Whats Coming, Blokcers) 40 | 1d | 2022-01-04 | 2022-01-04 | 1545d | start no earlier than 2022-01-03 | 0.0% | 0.0% | 0.0% | No BL | No BL | -1014 | On Target |
| 505 | 5.3.2.41 | Weekly Standup (What Occurred, Whats Coming, Blokcers) 41 | 1d | 2022-01-10 | 2022-01-10 | 1541d | start no earlier than 2022-01-10 | 0.0% | 0.0% | 0.0% | No BL | No BL | -1014 | On Target |
| 506 | 5.3.2.42 | Weekly Standup (What Occurred, Whats Coming, Blokcers) 42 | 1d | 2022-01-18 | 2022-01-18 | 1536d | start no earlier than 2022-01-17 | 0.0% | 0.0% | 0.0% | No BL | No BL | -1014 | On Target |
| 507 | 5.3.2.43 | Weekly Standup (What Occurred, Whats Coming, Blokcers) 43 | 1d | 2022-01-24 | 2022-01-24 | 1532d | start no earlier than 2022-01-24 | 0.0% | 0.0% | 0.0% | No BL | No BL | -1014 | On Target |
| 508 | 5.3.2.44 | Weekly Standup (What Occurred, Whats Coming, Blokcers) 44 | 1d | 2022-01-31 | 2022-01-31 | 1527d | start no earlier than 2022-01-31 | 0.0% | 0.0% | 0.0% | No BL | No BL | -1014 | On Target |
| 509 | 5.3.2.45 | Weekly Standup (What Occurred, Whats Coming, Blokcers) 45 | 1d | 2022-02-07 | 2022-02-07 | 1522d | start no earlier than 2022-02-07 | 0.0% | 0.0% | 0.0% | No BL | No BL | -1014 | On Target |
| 510 | 5.3.2.46 | Weekly Standup (What Occurred, Whats Coming, Blokcers) 46 | 1d | 2022-02-14 | 2022-02-14 | 1517d | start no earlier than 2022-02-14 | 0.0% | 0.0% | 0.0% | No BL | No BL | -1014 | On Target |
| 511 | 5.3.2.47 | Weekly Standup (What Occurred, Whats Coming, Blokcers) 47 | 1d | 2022-02-22 | 2022-02-22 | 1512d | start no earlier than 2022-02-21 | 0.0% | 0.0% | 0.0% | No BL | No BL | -1014 | On Target |
| 512 | 5.3.2.48 | Weekly Standup (What Occurred, Whats Coming, Blokcers) 48 | 1d | 2022-02-28 | 2022-02-28 | 1508d | start no earlier than 2022-02-28 | 0.0% | 0.0% | 0.0% | No BL | No BL | -1014 | On Target |
| 513 | 5.3.2.49 | Weekly Standup (What Occurred, Whats Coming, Blokcers) 49 | 1d | 2022-03-07 | 2022-03-07 | 1503d | start no earlier than 2022-03-07 | 0.0% | 0.0% | 0.0% | No BL | No BL | -1014 | On Target |
| 514 | 5.3.2.50 | Weekly Standup (What Occurred, Whats Coming, Blokcers) 50 | 1d | 2022-03-14 | 2022-03-14 | 1498d | start no earlier than 2022-03-14 | 0.0% | 0.0% | 0.0% | No BL | No BL | -1014 | On Target |
| 515 | 5.3.2.51 | Weekly Standup (What Occurred, Whats Coming, Blokcers) 51 | 1d | 2022-03-21 | 2022-03-21 | 1493d | start no earlier than 2022-03-21 | 0.0% | 0.0% | 0.0% | No BL | No BL | -1014 | On Target |
| 516 | 5.3.2.52 | Weekly Standup (What Occurred, Whats Coming, Blokcers) 52 | 1d | 2022-03-28 | 2022-03-28 | 1488d | start no earlier than 2022-03-28 | 0.0% | 0.0% | 0.0% | No BL | No BL | -1014 | On Target |
| 517 | 5.3.2.53 | Weekly Standup (What Occurred, Whats Coming, Blokcers) 53 | 1d | 2022-04-04 | 2022-04-04 | 1483d | start no earlier than 2022-04-04 | 0.0% | 0.0% | 0.0% | No BL | No BL | -1014 | On Target |
| 518 | 5.3.2.54 | Weekly Standup (What Occurred, Whats Coming, Blokcers) 54 | 1d | 2022-04-11 | 2022-04-11 | 1478d | start no earlier than 2022-04-11 | 0.0% | 0.0% | 0.0% | No BL | No BL | -1014 | On Target |
| 519 | 5.3.2.55 | Weekly Standup (What Occurred, Whats Coming, Blokcers) 55 | 1d | 2022-04-18 | 2022-04-18 | 1473d | start no earlier than 2022-04-18 | 0.0% | 0.0% | 0.0% | No BL | No BL | -1014 | On Target |
| 520 | 5.3.2.56 | Weekly Standup (What Occurred, Whats Coming, Blokcers) 56 | 1d | 2022-04-26 | 2022-04-26 | 1468d | start no earlier than 2022-04-25 | 0.0% | 0.0% | 0.0% | No BL | No BL | -1014 | On Target |
| 521 | 5.3.2.57 | Weekly Standup (What Occurred, Whats Coming, Blokcers) 57 | 1d | 2022-05-02 | 2022-05-02 | 1464d | start no earlier than 2022-05-02 | 0.0% | 0.0% | 0.0% | No BL | No BL | -1014 | On Target |
| 522 | 5.3.2.58 | Weekly Standup (What Occurred, Whats Coming, Blokcers) 58 | 1d | 2022-05-09 | 2022-05-09 | 1459d | start no earlier than 2022-05-09 | 0.0% | 0.0% | 0.0% | No BL | No BL | -1014 | On Target |
| 523 | 5.3.2.59 | Weekly Standup (What Occurred, Whats Coming, Blokcers) 59 | 1d | 2022-05-16 | 2022-05-16 | 1454d | start no earlier than 2022-05-16 | 0.0% | 0.0% | 0.0% | No BL | No BL | -1014 | On Target |
| 524 | 5.3.2.60 | Weekly Standup (What Occurred, Whats Coming, Blokcers) 60 | 1d | 2022-05-23 | 2022-05-23 | 1449d | start no earlier than 2022-05-23 | 0.0% | 0.0% | 0.0% | No BL | No BL | -1014 | On Target |
| 525 | 5.3.2.61 | Weekly Standup (What Occurred, Whats Coming, Blokcers) 61 | 1d | 2022-05-31 | 2022-05-31 | 1444d | start no earlier than 2022-05-30 | 0.0% | 0.0% | 0.0% | No BL | No BL | -1014 | On Target |
| 526 | 5.3.2.62 | Weekly Standup (What Occurred, Whats Coming, Blokcers) 62 | 1d | 2022-06-07 | 2022-06-07 | 1440d | start no earlier than 2022-06-06 | 0.0% | 0.0% | 0.0% | No BL | No BL | -1014 | On Target |
| 527 | 5.3.2.63 | Weekly Standup (What Occurred, Whats Coming, Blokcers) 63 | 1d | 2022-06-13 | 2022-06-13 | 1436d | start no earlier than 2022-06-13 | 0.0% | 0.0% | 0.0% | No BL | No BL | -1014 | On Target |
| 528 | 5.3.2.64 | Weekly Standup (What Occurred, Whats Coming, Blokcers) 64 | 1d | 2022-06-20 | 2022-06-20 | 1431d | start no earlier than 2022-06-20 | 0.0% | 0.0% | 0.0% | No BL | No BL | -1014 | On Target |
| 529 | 5.3.2.65 | Weekly Standup (What Occurred, Whats Coming, Blokcers) 65 | 1d | 2022-06-27 | 2022-06-27 | 1426d | start no earlier than 2022-06-27 | 0.0% | 0.0% | 0.0% | No BL | No BL | -1014 | On Target |
| 530 | 5.3.2.66 | Weekly Standup (What Occurred, Whats Coming, Blokcers) 66 | 1d | 2022-07-05 | 2022-07-05 | 1421d | start no earlier than 2022-07-04 | 0.0% | 0.0% | 0.0% | No BL | No BL | -1014 | On Target |
| 531 | 5.3.2.67 | Weekly Standup (What Occurred, Whats Coming, Blokcers) 67 | 1d | 2022-07-11 | 2022-07-11 | 1417d | start no earlier than 2022-07-11 | 0.0% | 0.0% | 0.0% | No BL | No BL | -1014 | On Target |
| 532 | 5.3.2.68 | Weekly Standup (What Occurred, Whats Coming, Blokcers) 68 | 1d | 2022-07-18 | 2022-07-18 | 1412d | start no earlier than 2022-07-18 | 0.0% | 0.0% | 0.0% | No BL | No BL | -1014 | On Target |
| 533 | 5.3.2.69 | Weekly Standup (What Occurred, Whats Coming, Blokcers) 69 | 1d | 2022-07-25 | 2022-07-25 | 1407d | start no earlier than 2022-07-25 | 0.0% | 0.0% | 0.0% | No BL | No BL | -1014 | On Target |

| ID | WBS | Task | Duration | Start | Finish | Total slack | Constraint | _Current Target | _Baseline Target | _Progress % | _Projected Status | _Baseline % Status | _Days Since Update | _Current % Status |
| --- | --- | --- | --- | --- | --- | --- | --- | --- | --- | --- | --- | --- | --- | --- |
| 534 | 5.3.2.70 | Weekly Standup (What Occurred, Whats Coming, Blokcers) 70 | 1d | 2022-08-01 | 2022-08-01 | 1402d | start no earlier than 2022-08-01 | 0.0% | 0.0% | 0.0% | No BL | No BL | -1014 | On Target |
| 535 | 5.3.2.71 | Weekly Standup (What Occurred, Whats Coming, Blokcers) 71 | 1d | 2022-08-08 | 2022-08-08 | 1397d | start no earlier than 2022-08-08 | 0.0% | 0.0% | 0.0% | No BL | No BL | -1014 | On Target |
| 536 | 5.3.2.72 | Weekly Standup (What Occurred, Whats Coming, Blokcers) 72 | 1d | 2022-08-15 | 2022-08-15 | 1392d | start no earlier than 2022-08-15 | 0.0% | 0.0% | 0.0% | No BL | No BL | -1014 | On Target |
| 537 | 5.3.2.73 | Weekly Standup (What Occurred, Whats Coming, Blokcers) 73 | 1d | 2022-08-22 | 2022-08-22 | 1387d | start no earlier than 2022-08-22 | 0.0% | 0.0% | 0.0% | No BL | No BL | -1014 | On Target |
| 538 | 5.3.2.74 | Weekly Standup (What Occurred, Whats Coming, Blokcers) 74 | 1d | 2022-08-29 | 2022-08-29 | 1382d | start no earlier than 2022-08-29 | 0.0% | 0.0% | 0.0% | No BL | No BL | -1014 | On Target |
| 539 | 5.3.2.75 | Weekly Standup (What Occurred, Whats Coming, Blokcers) 75 | 1d | 2022-09-06 | 2022-09-06 | 1377d | start no earlier than 2022-09-05 | 0.0% | 0.0% | 0.0% | No BL | No BL | -1014 | On Target |
| 540 | 5.3.2.76 | Weekly Standup (What Occurred, Whats Coming, Blokcers) 76 | 1d | 2022-09-12 | 2022-09-12 | 1373d | start no earlier than 2022-09-12 | 0.0% | 0.0% | 0.0% | No BL | No BL | -1014 | On Target |
| 541 | 5.3.2.77 | Weekly Standup (What Occurred, Whats Coming, Blokcers) 77 | 1d | 2022-09-19 | 2022-09-19 | 1368d | start no earlier than 2022-09-19 | 0.0% | 0.0% | 0.0% | No BL | No BL | -1014 | On Target |
| 542 | 5.3.2.78 | Weekly Standup (What Occurred, Whats Coming, Blokcers) 78 | 1d | 2022-09-26 | 2022-09-26 | 1363d | start no earlier than 2022-09-26 | 0.0% | 0.0% | 0.0% | No BL | No BL | -1014 | On Target |
| 543 | 5.3.2.79 | Weekly Standup (What Occurred, Whats Coming, Blokcers) 79 | 1d | 2022-10-03 | 2022-10-03 | 1358d | start no earlier than 2022-10-03 | 0.0% | 0.0% | 0.0% | No BL | No BL | -1014 | On Target |
| 544 | 5.3.2.80 | Weekly Standup (What Occurred, Whats Coming, Blokcers) 80 | 1d | 2022-10-11 | 2022-10-11 | 1353d | start no earlier than 2022-10-10 | 0.0% | 0.0% | 0.0% | No BL | No BL | -1014 | On Target |
| 545 | 5.3.2.81 | Weekly Standup (What Occurred, Whats Coming, Blokcers) 81 | 1d | 2022-10-17 | 2022-10-17 | 1349d | start no earlier than 2022-10-17 | 0.0% | 0.0% | 0.0% | No BL | No BL | -1014 | On Target |
| 546 | 5.3.2.82 | Weekly Standup (What Occurred, Whats Coming, Blokcers) 82 | 1d | 2022-10-24 | 2022-10-24 | 1344d | start no earlier than 2022-10-24 | 0.0% | 0.0% | 0.0% | No BL | No BL | -1014 | On Target |
| 547 | 5.3.2.83 | Weekly Standup (What Occurred, Whats Coming, Blokcers) 83 | 1d | 2022-10-31 | 2022-10-31 | 1339d | start no earlier than 2022-10-31 | 0.0% | 0.0% | 0.0% | No BL | No BL | -1014 | On Target |
| 548 | 5.3.2.84 | Weekly Standup (What Occurred, Whats Coming, Blokcers) 84 | 1d | 2022-11-07 | 2022-11-07 | 1334d | start no earlier than 2022-11-07 | 0.0% | 0.0% | 0.0% | No BL | No BL | -1014 | On Target |
| 549 | 5.3.2.85 | Weekly Standup (What Occurred, Whats Coming, Blokcers) 85 | 1d | 2022-11-14 | 2022-11-14 | 1330d | start no earlier than 2022-11-14 | 0.0% | 0.0% | 0.0% | No BL | No BL | -1014 | On Target |
| 550 | 5.3.2.86 | Weekly Standup (What Occurred, Whats Coming, Blokcers) 86 | 1d | 2022-11-21 | 2022-11-21 | 1325d | start no earlier than 2022-11-21 | 0.0% | 0.0% | 0.0% | No BL | No BL | -1014 | On Target |
| 551 | 5.3.2.87 | Weekly Standup (What Occurred, Whats Coming, Blokcers) 87 | 1d | 2022-11-28 | 2022-11-28 | 1322d | start no earlier than 2022-11-28 | 0.0% | 0.0% | 0.0% | No BL | No BL | -1014 | On Target |
| 552 | 5.3.2.88 | Weekly Standup (What Occurred, Whats Coming, Blokcers) 88 | 1d | 2022-12-05 | 2022-12-05 | 1317d | start no earlier than 2022-12-05 | 0.0% | 0.0% | 0.0% | No BL | No BL | -1014 | On Target |
| 553 | 5.3.2.89 | Weekly Standup (What Occurred, Whats Coming, Blokcers) 89 | 1d | 2022-12-12 | 2022-12-12 | 1312d | start no earlier than 2022-12-12 | 0.0% | 0.0% | 0.0% | No BL | No BL | -1014 | On Target |
| 554 | 5.3.2.90 | Weekly Standup (What Occurred, Whats Coming, Blokcers) 90 | 1d | 2022-12-19 | 2022-12-19 | 1307d | start no earlier than 2022-12-19 | 0.0% | 0.0% | 0.0% | No BL | No BL | -1014 | On Target |
| 555 | 5.3.2.91 | Weekly Standup (What Occurred, Whats Coming, Blokcers) 91 | 1d | 2022-12-27 | 2022-12-27 | 1302d | start no earlier than 2022-12-26 | 0.0% | 0.0% | 0.0% | No BL | No BL | -1014 | On Target |
| 556 | 5.3.2.92 | Weekly Standup (What Occurred, Whats Coming, Blokcers) 92 | 1d | 2023-01-03 | 2023-01-03 | 1298d | start no earlier than 2023-01-02 | 0.0% | 0.0% | 0.0% | No BL | No BL | -1014 | On Target |
| 557 | 5.3.2.93 | Weekly Standup (What Occurred, Whats Coming, Blokcers) 93 | 1d | 2023-01-09 | 2023-01-09 | 1294d | start no earlier than 2023-01-09 | 0.0% | 0.0% | 0.0% | No BL | No BL | -1014 | On Target |
| 558 | 5.3.2.94 | Weekly Standup (What Occurred, Whats Coming, Blokcers) 94 | 1d | 2023-01-17 | 2023-01-17 | 1289d | start no earlier than 2023-01-16 | 0.0% | 0.0% | 0.0% | No BL | No BL | -1014 | On Target |
| 559 | 5.3.2.95 | Weekly Standup (What Occurred, Whats Coming, Blokcers) 95 | 1d | 2023-01-23 | 2023-01-23 | 1285d | start no earlier than 2023-01-23 | 0.0% | 0.0% | 0.0% | No BL | No BL | -1014 | On Target |
| 560 | 5.3.2.96 | Weekly Standup (What Occurred, Whats Coming, Blokcers) 96 | 1d | 2023-01-30 | 2023-01-30 | 1280d | start no earlier than 2023-01-30 | 0.0% | 0.0% | 0.0% | No BL | No BL | -1014 | On Target |
| 561 | 5.3.2.97 | Weekly Standup (What Occurred, Whats Coming, Blokcers) 97 | 1d | 2023-02-06 | 2023-02-06 | 1275d | start no earlier than 2023-02-06 | 0.0% | 0.0% | 0.0% | No BL | No BL | -1014 | On Target |
| 562 | 5.3.2.98 | Weekly Standup (What Occurred, Whats Coming, Blokcers) 98 | 1d | 2023-02-13 | 2023-02-13 | 1270d | start no earlier than 2023-02-13 | 0.0% | 0.0% | 0.0% | No BL | No BL | -1014 | On Target |
| 563 | 5.3.2.99 | Weekly Standup (What Occurred, Whats Coming, Blokcers) 99 | 1d | 2023-02-21 | 2023-02-21 | 1265d | start no earlier than 2023-02-20 | 0.0% | 0.0% | 0.0% | No BL | No BL | -1014 | On Target |
| 564 | 5.3.2.100 | Weekly Standup (What Occurred, Whats Coming, Blokcers) 100 | 1d | 2023-02-27 | 2023-02-27 | 1261d | start no earlier than 2023-02-27 | 0.0% | 0.0% | 0.0% | No BL | No BL | -1014 | On Target |
| 565 | 5.3.2.101 | Weekly Standup (What Occurred, Whats Coming, Blokcers) 101 | 1d | 2023-03-06 | 2023-03-06 | 1256d | start no earlier than 2023-03-06 | 0.0% | 0.0% | 0.0% | No BL | No BL | -1014 | On Target |
| 566 | 5.3.2.102 | Weekly Standup (What Occurred, Whats Coming, Blokcers) 102 | 1d | 2023-03-13 | 2023-03-13 | 1251d | start no earlier than 2023-03-13 | 0.0% | 0.0% | 0.0% | No BL | No BL | -1014 | On Target |
| 567 | 5.3.2.103 | Weekly Standup (What Occurred, Whats Coming, Blokcers) 103 | 1d | 2023-03-20 | 2023-03-20 | 1246d | start no earlier than 2023-03-20 | 0.0% | 0.0% | 0.0% | No BL | No BL | -1014 | On Target |
| 568 | 5.3.2.104 | Weekly Standup (What Occurred, Whats Coming, Blokcers) 104 | 1d | 2023-03-27 | 2023-03-27 | 1241d | start no earlier than 2023-03-27 | 0.0% | 0.0% | 0.0% | No BL | No BL | -1014 | On Target |
| 569 | 5.3.2.105 | Weekly Standup (What Occurred, Whats Coming, Blokcers) 105 | 1d | 2023-04-03 | 2023-04-03 | 1236d | start no earlier than 2023-04-03 | 0.0% | 0.0% | 0.0% | No BL | No BL | -1014 | On Target |
| 570 | 5.3.2.106 | Weekly Standup (What Occurred, Whats Coming, Blokcers) 106 | 1d | 2023-04-10 | 2023-04-10 | 1231d | start no earlier than 2023-04-10 | 0.0% | 0.0% | 0.0% | No BL | No BL | -1014 | On Target |
| 571 | 5.3.2.107 | Weekly Standup (What Occurred, Whats Coming, Blokcers) 107 | 1d | 2023-04-17 | 2023-04-17 | 1226d | start no earlier than 2023-04-17 | 0.0% | 0.0% | 0.0% | No BL | No BL | -1014 | On Target |
| 572 | 5.3.2.108 | Weekly Standup (What Occurred, Whats Coming, Blokcers) 108 | 1d | 2023-04-25 | 2023-04-25 | 1221d | start no earlier than 2023-04-24 | 0.0% | 0.0% | 0.0% | No BL | No BL | -1014 | On Target |
| 573 | 5.3.2.109 | Weekly Standup (What Occurred, Whats Coming, Blokcers) 109 | 1d | 2023-05-01 | 2023-05-01 | 1217d | start no earlier than 2023-05-01 | 0.0% | 0.0% | 0.0% | No BL | No BL | -1014 | On Target |
| 574 | 5.3.2.110 | Weekly Standup (What Occurred, Whats Coming, Blokcers) 110 | 1d | 2023-05-08 | 2023-05-08 | 1212d | start no earlier than 2023-05-08 | 0.0% | 0.0% | 0.0% | No BL | No BL | -1014 | On Target |
| 575 | 5.3.2.111 | Weekly Standup (What Occurred, Whats Coming, Blokcers) 111 | 1d | 2023-05-15 | 2023-05-15 | 1207d | start no earlier than 2023-05-15 | 0.0% | 0.0% | 0.0% | No BL | No BL | -1014 | On Target |
| 576 | 5.3.2.112 | Weekly Standup (What Occurred, Whats Coming, Blokcers) 112 | 1d | 2023-05-22 | 2023-05-22 | 1202d | start no earlier than 2023-05-22 | 0.0% | 0.0% | 0.0% | No BL | No BL | -1014 | On Target |
| 577 | 5.3.2.113 | Weekly Standup (What Occurred, Whats Coming, Blokcers) 113 | 1d | 2023-05-30 | 2023-05-30 | 1197d | start no earlier than 2023-05-29 | 0.0% | 0.0% | 0.0% | No BL | No BL | -1014 | On Target |
| 578 | 5.3.2.114 | Weekly Standup (What Occurred, Whats Coming, Blokcers) 114 | 1d | 2023-06-06 | 2023-06-06 | 1193d | start no earlier than 2023-06-05 | 0.0% | 0.0% | 0.0% | No BL | No BL | -1014 | On Target |
| 579 | 5.3.2.115 | Weekly Standup (What Occurred, Whats Coming, Blokcers) 115 | 1d | 2023-06-12 | 2023-06-12 | 1189d | start no earlier than 2023-06-12 | 0.0% | 0.0% | 0.0% | No BL | No BL | -1014 | On Target |
| 580 | 5.3.2.116 | Weekly Standup (What Occurred, Whats Coming, Blokcers) 116 | 1d | 2023-06-19 | 2023-06-19 | 1184d | start no earlier than 2023-06-19 | 0.0% | 0.0% | 0.0% | No BL | No BL | -1014 | On Target |
| 581 | 5.3.2.117 | Weekly Standup (What Occurred, Whats Coming, Blokcers) 117 | 1d | 2023-06-26 | 2023-06-26 | 1179d | start no earlier than 2023-06-26 | 0.0% | 0.0% | 0.0% | No BL | No BL | -1014 | On Target |
| 582 | 5.3.2.118 | Weekly Standup (What Occurred, Whats Coming, Blokcers) 118 | 1d | 2023-07-03 | 2023-07-03 | 1174d | start no earlier than 2023-07-03 | 0.0% | 0.0% | 0.0% | No BL | No BL | -1014 | On Target |
| 583 | 5.3.2.119 | Weekly Standup (What Occurred, Whats Coming, Blokcers) 119 | 1d | 2023-07-10 | 2023-07-10 | 1170d | start no earlier than 2023-07-10 | 0.0% | 0.0% | 0.0% | No BL | No BL | -1014 | On Target |
| 584 | 5.3.2.120 | Weekly Standup (What Occurred, Whats Coming, Blokcers) 120 | 1d | 2023-07-17 | 2023-07-17 | 1165d | start no earlier than 2023-07-17 | 0.0% | 0.0% | 0.0% | No BL | No BL | -1014 | On Target |
| 585 | 5.3.2.121 | Weekly Standup (What Occurred, Whats Coming, Blokcers) 121 | 1d | 2023-07-24 | 2023-07-24 | 1160d | start no earlier than 2023-07-24 | 0.0% | 0.0% | 0.0% | No BL | No BL | -1014 | On Target |
| 586 | 5.3.2.122 | Weekly Standup (What Occurred, Whats Coming, Blokcers) 122 | 1d | 2023-07-31 | 2023-07-31 | 1155d | start no earlier than 2023-07-31 | 0.0% | 0.0% | 0.0% | No BL | No BL | -1014 | On Target |
| 587 | 5.3.2.123 | Weekly Standup (What Occurred, Whats Coming, Blokcers) 123 | 1d | 2023-08-07 | 2023-08-07 | 1150d | start no earlier than 2023-08-07 | 0.0% | 0.0% | 0.0% | No BL | No BL | -1014 | On Target |
| 588 | 5.3.2.124 | Weekly Standup (What Occurred, Whats Coming, Blokcers) 124 | 1d | 2023-08-14 | 2023-08-14 | 1145d | start no earlier than 2023-08-14 | 0.0% | 0.0% | 0.0% | No BL | No BL | -1014 | On Target |
| 589 | 5.3.2.125 | Weekly Standup (What Occurred, Whats Coming, Blokcers) 125 | 1d | 2023-08-21 | 2023-08-21 | 1140d | start no earlier than 2023-08-21 | 0.0% | 0.0% | 0.0% | No BL | No BL | -1014 | On Target |
| 590 | 5.3.2.126 | Weekly Standup (What Occurred, Whats Coming, Blokcers) 126 | 1d | 2023-08-28 | 2023-08-28 | 1135d | start no earlier than 2023-08-28 | 0.0% | 0.0% | 0.0% | No BL | No BL | -1014 | On Target |
| 591 | 5.3.2.127 | Weekly Standup (What Occurred, Whats Coming, Blokcers) 127 | 1d | 2023-09-05 | 2023-09-05 | 1130d | start no earlier than 2023-09-04 | 0.0% | 0.0% | 0.0% | No BL | No BL | -1014 | On Target |
| 592 | 5.3.2.128 | Weekly Standup (What Occurred, Whats Coming, Blokcers) 128 | 1d | 2023-09-11 | 2023-09-11 | 1126d | start no earlier than 2023-09-11 | 0.0% | 0.0% | 0.0% | No BL | No BL | -1014 | On Target |
| 593 | 5.3.2.129 | Weekly Standup (What Occurred, Whats Coming, Blokcers) 129 | 1d | 2023-09-18 | 2023-09-18 | 1121d | start no earlier than 2023-09-18 | 0.0% | 0.0% | 0.0% | No BL | No BL | -1014 | On Target |
| 594 | 5.3.2.130 | Weekly Standup (What Occurred, Whats Coming, Blokcers) 130 | 1d | 2023-09-25 | 2023-09-25 | 1116d | start no earlier than 2023-09-25 | 0.0% | 0.0% | 0.0% | No BL | No BL | -1014 | On Target |
| 595 | 5.3.2.131 | Weekly Standup (What Occurred, Whats Coming, Blokcers) 131 | 1d | 2023-10-02 | 2023-10-02 | 1111d | start no earlier than 2023-10-02 | 0.0% | 0.0% | 0.0% | No BL | No BL | -1014 | On Target |
| 596 | 5.3.2.132 | Weekly Standup (What Occurred, Whats Coming, Blokcers) 132 | 1d | 2023-10-10 | 2023-10-10 | 1106d | start no earlier than 2023-10-09 | 0.0% | 0.0% | 0.0% | No BL | No BL | -1014 | On Target |
| 597 | 5.3.2.133 | Weekly Standup (What Occurred, Whats Coming, Blokcers) 133 | 1d | 2023-10-16 | 2023-10-16 | 1102d | start no earlier than 2023-10-16 | 0.0% | 0.0% | 0.0% | No BL | No BL | -1014 | On Target |
| 598 | 5.3.2.134 | Weekly Standup (What Occurred, Whats Coming, Blokcers) 134 | 1d | 2023-10-23 | 2023-10-23 | 1097d | start no earlier than 2023-10-23 | 0.0% | 0.0% | 0.0% | No BL | No BL | -1014 | On Target |
| 599 | 5.3.2.135 | Weekly Standup (What Occurred, Whats Coming, Blokcers) 135 | 1d | 2023-10-30 | 2023-10-30 | 1092d | start no earlier than 2023-10-30 | 0.0% | 0.0% | 0.0% | No BL | No BL | -1014 | On Target |
| 600 | 5.3.2.136 | Weekly Standup (What Occurred, Whats Coming, Blokcers) 136 | 1d | 2023-11-06 | 2023-11-06 | 1087d | start no earlier than 2023-11-06 | 0.0% | 0.0% | 0.0% | No BL | No BL | -1014 | On Target |
| 601 | 5.3.2.137 | Weekly Standup (What Occurred, Whats Coming, Blokcers) 137 | 1d | 2023-11-14 | 2023-11-14 | 1082d | start no earlier than 2023-11-13 | 0.0% | 0.0% | 0.0% | No BL | No BL | -1014 | On Target |
| 602 | 5.3.2.138 | Weekly Standup (What Occurred, Whats Coming, Blokcers) 138 | 1d | 2023-11-20 | 2023-11-20 | 1078d | start no earlier than 2023-11-20 | 0.0% | 0.0% | 0.0% | No BL | No BL | -1014 | On Target |
| 603 | 5.3.2.139 | Weekly Standup (What Occurred, Whats Coming, Blokcers) 139 | 1d | 2023-11-27 | 2023-11-27 | 1075d | start no earlier than 2023-11-27 | 0.0% | 0.0% | 0.0% | No BL | No BL | -1014 | On Target |

| ID | WBS | Task | Duration | Start | Finish | Total slack | Constraint | _Current Target | _Baseline Target | _Progress % | _Projected Status | _Baseline % Status | _Days Since Update | _Current % Status |
| --- | --- | --- | --- | --- | --- | --- | --- | --- | --- | --- | --- | --- | --- | --- |
| 604 | 5.3.2.140 | Weekly Standup (What Occurred, Whats Coming, Blokcers) 140 | 1d | 2023-12-04 | 2023-12-04 | 1070d | start no earlier than 2023-12-04 | 0.0% | 0.0% | 0.0% | No BL | No BL | -1014 | On Target |
| 605 | 5.3.2.141 | Weekly Standup (What Occurred, Whats Coming, Blokcers) 141 | 1d | 2023-12-11 | 2023-12-11 | 1065d | start no earlier than 2023-12-11 | 0.0% | 0.0% | 0.0% | No BL | No BL | -1014 | On Target |
| 606 | 5.3.2.142 | Weekly Standup (What Occurred, Whats Coming, Blokcers) 142 | 1d | 2023-12-18 | 2023-12-18 | 1060d | start no earlier than 2023-12-18 | 0.0% | 0.0% | 0.0% | No BL | No BL | -1014 | On Target |
| 607 | 5.3.2.143 | Weekly Standup (What Occurred, Whats Coming, Blokcers) 143 | 1d | 2023-12-26 | 2023-12-26 | 1055d | start no earlier than 2023-12-25 | 0.0% | 0.0% | 0.0% | No BL | No BL | -1014 | On Target |
| 608 | 5.3.2.144 | Weekly Standup (What Occurred, Whats Coming, Blokcers) 144 | 1d | 2024-01-02 | 2024-01-02 | 1051d | start no earlier than 2024-01-01 | 0.0% | 0.0% | 0.0% | No BL | No BL | -1014 | On Target |
| 609 | 5.3.2.145 | Weekly Standup (What Occurred, Whats Coming, Blokcers) 145 | 1d | 2024-01-08 | 2024-01-08 | 1047d | start no earlier than 2024-01-08 | 0.0% | 0.0% | 0.0% | No BL | No BL | -1014 | On Target |
| 610 | 5.3.2.146 | Weekly Standup (What Occurred, Whats Coming, Blokcers) 146 | 1d | 2024-01-16 | 2024-01-16 | 1042d | start no earlier than 2024-01-15 | 0.0% | 0.0% | 0.0% | No BL | No BL | -1014 | On Target |
| 611 | 5.3.2.147 | Weekly Standup (What Occurred, Whats Coming, Blokcers) 147 | 1d | 2024-01-22 | 2024-01-22 | 1038d | start no earlier than 2024-01-22 | 0.0% | 0.0% | 0.0% | No BL | No BL | -1014 | On Target |
| 612 | 5.3.2.148 | Weekly Standup (What Occurred, Whats Coming, Blokcers) 148 | 1d | 2024-01-29 | 2024-01-29 | 1033d | start no earlier than 2024-01-29 | 0.0% | 0.0% | 0.0% | No BL | No BL | -1014 | On Target |
| 613 | 5.3.2.149 | Weekly Standup (What Occurred, Whats Coming, Blokcers) 149 | 1d | 2024-02-05 | 2024-02-05 | 1028d | start no earlier than 2024-02-05 | 0.0% | 0.0% | 0.0% | No BL | No BL | -1014 | On Target |
| 614 | 5.3.2.150 | Weekly Standup (What Occurred, Whats Coming, Blokcers) 150 | 1d | 2024-02-12 | 2024-02-12 | 1023d | start no earlier than 2024-02-12 | 0.0% | 0.0% | 0.0% | No BL | No BL | -1014 | On Target |
| 615 | 5.3.2.151 | Weekly Standup (What Occurred, Whats Coming, Blokcers) 151 | 1d | 2024-02-20 | 2024-02-20 | 1018d | start no earlier than 2024-02-19 | 0.0% | 0.0% | 0.0% | No BL | No BL | -1014 | On Target |
| 616 | 5.3.2.152 | Weekly Standup (What Occurred, Whats Coming, Blokcers) 152 | 1d | 2024-02-26 | 2024-02-26 | 1014d | start no earlier than 2024-02-26 | 0.0% | 0.0% | 0.0% | No BL | No BL | -1014 | On Target |
| 617 | 5.3.2.153 | Weekly Standup (What Occurred, Whats Coming, Blokcers) 153 | 1d | 2024-03-04 | 2024-03-04 | 1009d | start no earlier than 2024-03-04 | 0.0% | 0.0% | 0.0% | No BL | No BL | -1014 | On Target |
| 618 | 5.3.2.154 | Weekly Standup (What Occurred, Whats Coming, Blokcers) 154 | 1d | 2024-03-11 | 2024-03-11 | 1004d | start no earlier than 2024-03-11 | 0.0% | 0.0% | 0.0% | No BL | No BL | -1014 | On Target |
| 619 | 5.3.2.155 | Weekly Standup (What Occurred, Whats Coming, Blokcers) 155 | 1d | 2024-03-18 | 2024-03-18 | 999d | start no earlier than 2024-03-18 | 0.0% | 0.0% | 0.0% | No BL | No BL | -1014 | On Target |
| 620 | 5.3.2.156 | Weekly Standup (What Occurred, Whats Coming, Blokcers) 156 | 1d | 2024-03-25 | 2024-03-25 | 994d | start no earlier than 2024-03-25 | 0.0% | 0.0% | 0.0% | No BL | No BL | -1014 | On Target |
| 621 | 5.3.3 | **MES CCB Meeting** | 721d | 2021-04-19 | 2024-03-18 | 999d |  | 0.0% | 0.0% |  |  |  |  |  |
| 622 | 5.3.3.1 | MES CCB Meeting 1 | 1d | 2021-04-19 | 2021-04-19 | 1719d | start no earlier than 2021-04-17 | 0.0% | 0.0% | 0.0% | No BL | No BL | -1014 | On Target |
| 623 | 5.3.3.2 | MES CCB Meeting 2 | 1d | 2021-05-17 | 2021-05-17 | 1700d | start no earlier than 2021-05-17 | 0.0% | 0.0% | 0.0% | No BL | No BL | -1014 | On Target |
| 624 | 5.3.3.3 | MES CCB Meeting 3 | 1d | 2021-06-17 | 2021-06-17 | 1679d | start no earlier than 2021-06-17 | 0.0% | 0.0% | 0.0% | No BL | No BL | -1014 | On Target |
| 625 | 5.3.3.4 | MES CCB Meeting 4 | 1d | 2021-07-19 | 2021-07-19 | 1658d | start no earlier than 2021-07-17 | 0.0% | 0.0% | 0.0% | No BL | No BL | -1014 | On Target |
| 626 | 5.3.3.5 | MES CCB Meeting 5 | 1d | 2021-08-17 | 2021-08-17 | 1637d | start no earlier than 2021-08-17 | 0.0% | 0.0% | 0.0% | No BL | No BL | -1014 | On Target |
| 627 | 5.3.3.6 | MES CCB Meeting 6 | 1d | 2021-09-17 | 2021-09-17 | 1615d | start no earlier than 2021-09-17 | 0.0% | 0.0% | 0.0% | No BL | No BL | -1014 | On Target |
| 628 | 5.3.3.7 | MES CCB Meeting 7 | 1d | 2021-10-18 | 2021-10-18 | 1595d | start no earlier than 2021-10-17 | 0.0% | 0.0% | 0.0% | No BL | No BL | -1014 | On Target |
| 629 | 5.3.3.8 | MES CCB Meeting 8 | 1d | 2021-11-17 | 2021-11-17 | 1574d | start no earlier than 2021-11-17 | 0.0% | 0.0% | 0.0% | No BL | No BL | -1014 | On Target |
| 630 | 5.3.3.9 | MES CCB Meeting 9 | 1d | 2021-12-17 | 2021-12-17 | 1554d | start no earlier than 2021-12-17 | 0.0% | 0.0% | 0.0% | No BL | No BL | -1014 | On Target |
| 631 | 5.3.3.10 | MES CCB Meeting 10 | 1d | 2022-01-18 | 2022-01-18 | 1536d | start no earlier than 2022-01-17 | 0.0% | 0.0% | 0.0% | No BL | No BL | -1014 | On Target |
| 632 | 5.3.3.11 | MES CCB Meeting 11 | 1d | 2022-02-17 | 2022-02-17 | 1514d | start no earlier than 2022-02-17 | 0.0% | 0.0% | 0.0% | No BL | No BL | -1014 | On Target |
| 633 | 5.3.3.12 | MES CCB Meeting 12 | 1d | 2022-03-17 | 2022-03-17 | 1495d | start no earlier than 2022-03-17 | 0.0% | 0.0% | 0.0% | No BL | No BL | -1014 | On Target |
| 634 | 5.3.3.13 | MES CCB Meeting 13 | 1d | 2022-04-18 | 2022-04-18 | 1473d | start no earlier than 2022-04-17 | 0.0% | 0.0% | 0.0% | No BL | No BL | -1014 | On Target |
| 635 | 5.3.3.14 | MES CCB Meeting 14 | 1d | 2022-05-17 | 2022-05-17 | 1453d | start no earlier than 2022-05-17 | 0.0% | 0.0% | 0.0% | No BL | No BL | -1014 | On Target |
| 636 | 5.3.3.15 | MES CCB Meeting 15 | 1d | 2022-06-17 | 2022-06-17 | 1432d | start no earlier than 2022-06-17 | 0.0% | 0.0% | 0.0% | No BL | No BL | -1014 | On Target |
| 637 | 5.3.3.16 | MES CCB Meeting 16 | 1d | 2022-07-18 | 2022-07-18 | 1412d | start no earlier than 2022-07-17 | 0.0% | 0.0% | 0.0% | No BL | No BL | -1014 | On Target |
| 638 | 5.3.3.17 | MES CCB Meeting 17 | 1d | 2022-08-17 | 2022-08-17 | 1390d | start no earlier than 2022-08-17 | 0.0% | 0.0% | 0.0% | No BL | No BL | -1014 | On Target |
| 639 | 5.3.3.18 | MES CCB Meeting 18 | 1d | 2022-09-19 | 2022-09-19 | 1368d | start no earlier than 2022-09-17 | 0.0% | 0.0% | 0.0% | No BL | No BL | -1014 | On Target |
| 640 | 5.3.3.19 | MES CCB Meeting 19 | 1d | 2022-10-17 | 2022-10-17 | 1349d | start no earlier than 2022-10-17 | 0.0% | 0.0% | 0.0% | No BL | No BL | -1014 | On Target |
| 641 | 5.3.3.20 | MES CCB Meeting 20 | 1d | 2022-11-17 | 2022-11-17 | 1327d | start no earlier than 2022-11-17 | 0.0% | 0.0% | 0.0% | No BL | No BL | -1014 | On Target |
| 642 | 5.3.3.21 | MES CCB Meeting 21 | 1d | 2022-12-19 | 2022-12-19 | 1307d | start no earlier than 2022-12-17 | 0.0% | 0.0% | 0.0% | No BL | No BL | -1014 | On Target |
| 643 | 5.3.3.22 | MES CCB Meeting 22 | 1d | 2023-01-17 | 2023-01-17 | 1289d | start no earlier than 2023-01-17 | 0.0% | 0.0% | 0.0% | No BL | No BL | -1014 | On Target |
| 644 | 5.3.3.23 | MES CCB Meeting 23 | 1d | 2023-02-17 | 2023-02-17 | 1266d | start no earlier than 2023-02-17 | 0.0% | 0.0% | 0.0% | No BL | No BL | -1014 | On Target |
| 645 | 5.3.3.24 | MES CCB Meeting 24 | 1d | 2023-03-17 | 2023-03-17 | 1247d | start no earlier than 2023-03-17 | 0.0% | 0.0% | 0.0% | No BL | No BL | -1014 | On Target |
| 646 | 5.3.3.25 | MES CCB Meeting 25 | 1d | 2023-04-17 | 2023-04-17 | 1226d | start no earlier than 2023-04-17 | 0.0% | 0.0% | 0.0% | No BL | No BL | -1014 | On Target |
| 647 | 5.3.3.26 | MES CCB Meeting 26 | 1d | 2023-05-17 | 2023-05-17 | 1205d | start no earlier than 2023-05-17 | 0.0% | 0.0% | 0.0% | No BL | No BL | -1014 | On Target |
| 648 | 5.3.3.27 | MES CCB Meeting 27 | 1d | 2023-06-19 | 2023-06-19 | 1184d | start no earlier than 2023-06-17 | 0.0% | 0.0% | 0.0% | No BL | No BL | -1014 | On Target |
| 649 | 5.3.3.28 | MES CCB Meeting 28 | 1d | 2023-07-17 | 2023-07-17 | 1165d | start no earlier than 2023-07-17 | 0.0% | 0.0% | 0.0% | No BL | No BL | -1014 | On Target |
| 650 | 5.3.3.29 | MES CCB Meeting 29 | 1d | 2023-08-17 | 2023-08-17 | 1142d | start no earlier than 2023-08-17 | 0.0% | 0.0% | 0.0% | No BL | No BL | -1014 | On Target |
| 651 | 5.3.3.30 | MES CCB Meeting 30 | 1d | 2023-09-18 | 2023-09-18 | 1121d | start no earlier than 2023-09-17 | 0.0% | 0.0% | 0.0% | No BL | No BL | -1014 | On Target |
| 652 | 5.3.3.31 | MES CCB Meeting 31 | 1d | 2023-10-17 | 2023-10-17 | 1101d | start no earlier than 2023-10-17 | 0.0% | 0.0% | 0.0% | No BL | No BL | -1014 | On Target |
| 653 | 5.3.3.32 | MES CCB Meeting 32 | 1d | 2023-11-17 | 2023-11-17 | 1079d | start no earlier than 2023-11-17 | 0.0% | 0.0% | 0.0% | No BL | No BL | -1014 | On Target |
| 654 | 5.3.3.33 | MES CCB Meeting 33 | 1d | 2023-12-18 | 2023-12-18 | 1060d | start no earlier than 2023-12-17 | 0.0% | 0.0% | 0.0% | No BL | No BL | -1014 | On Target |
| 655 | 5.3.3.34 | MES CCB Meeting 34 | 1d | 2024-01-17 | 2024-01-17 | 1041d | start no earlier than 2024-01-17 | 0.0% | 0.0% | 0.0% | No BL | No BL | -1014 | On Target |
| 656 | 5.3.3.35 | MES CCB Meeting 35 | 1d | 2024-02-20 | 2024-02-20 | 1018d | start no earlier than 2024-02-17 | 0.0% | 0.0% | 0.0% | No BL | No BL | -1014 | On Target |
| 657 | 5.3.3.36 | MES CCB Meeting 36 | 1d | 2024-03-18 | 2024-03-18 | 999d | start no earlier than 2024-03-17 | 0.0% | 0.0% | 0.0% | No BL | No BL | -1014 | On Target |

| ID | WBS | Task | Duration | Start | Finish | Total slack | Constraint | _Current Target | _Baseline Target | _Progress % | _Projected Status | _Baseline % Status | _Days Since Update | _Current % Status |
| --- | --- | --- | --- | --- | --- | --- | --- | --- | --- | --- | --- | --- | --- | --- |
| 658 | 5.3.4 | **MES Risk and Issue Meeting** | 675d | 2021-04-01 | 2023-12-21 | 1057d |  | 0.0% | 0.0% |  |  |  |  |  |
| 659 | 5.3.4.1 | MES Risk and Issue Meeting 1 | 1d | 2021-04-01 | 2021-04-01 | 1731d | start no earlier than 2021-04-01 | 0.0% | 0.0% | 0.0% | No BL | No BL | -1014 | On Target |
| 660 | 5.3.4.2 | MES Risk and Issue Meeting 2 | 1d | 2021-04-15 | 2021-04-15 | 1721d | start no earlier than 2021-04-15 | 0.0% | 0.0% | 0.0% | No BL | No BL | -1014 | On Target |
| 661 | 5.3.4.3 | MES Risk and Issue Meeting 3 | 1d | 2021-04-29 | 2021-04-29 | 1712d | start no earlier than 2021-04-29 | 0.0% | 0.0% | 0.0% | No BL | No BL | -1014 | On Target |
| 662 | 5.3.4.4 | MES Risk and Issue Meeting 4 | 1d | 2021-05-13 | 2021-05-13 | 1702d | start no earlier than 2021-05-13 | 0.0% | 0.0% | 0.0% | No BL | No BL | -1014 | On Target |
| 663 | 5.3.4.5 | MES Risk and Issue Meeting 5 | 1d | 2021-05-27 | 2021-05-27 | 1692d | start no earlier than 2021-05-27 | 0.0% | 0.0% | 0.0% | No BL | No BL | -1014 | On Target |
| 664 | 5.3.4.6 | MES Risk and Issue Meeting 6 | 1d | 2021-06-10 | 2021-06-10 | 1684d | start no earlier than 2021-06-10 | 0.0% | 0.0% | 0.0% | No BL | No BL | -1014 | On Target |
| 665 | 5.3.4.7 | MES Risk and Issue Meeting 7 | 1d | 2021-06-24 | 2021-06-24 | 1674d | start no earlier than 2021-06-24 | 0.0% | 0.0% | 0.0% | No BL | No BL | -1014 | On Target |
| 666 | 5.3.4.8 | MES Risk and Issue Meeting 8 | 1d | 2021-07-08 | 2021-07-08 | 1665d | start no earlier than 2021-07-08 | 0.0% | 0.0% | 0.0% | No BL | No BL | -1014 | On Target |
| 667 | 5.3.4.9 | MES Risk and Issue Meeting 9 | 1d | 2021-07-22 | 2021-07-22 | 1655d | start no earlier than 2021-07-22 | 0.0% | 0.0% | 0.0% | No BL | No BL | -1014 | On Target |
| 668 | 5.3.4.10 | MES Risk and Issue Meeting 10 | 1d | 2021-08-05 | 2021-08-05 | 1645d | start no earlier than 2021-08-05 | 0.0% | 0.0% | 0.0% | No BL | No BL | -1014 | On Target |
| 669 | 5.3.4.11 | MES Risk and Issue Meeting 11 | 1d | 2021-08-19 | 2021-08-19 | 1635d | start no earlier than 2021-08-19 | 0.0% | 0.0% | 0.0% | No BL | No BL | -1014 | On Target |
| 670 | 5.3.4.12 | MES Risk and Issue Meeting 12 | 1d | 2021-09-02 | 2021-09-02 | 1625d | start no earlier than 2021-09-02 | 0.0% | 0.0% | 0.0% | No BL | No BL | -1014 | On Target |
| 671 | 5.3.4.13 | MES Risk and Issue Meeting 13 | 1d | 2021-09-16 | 2021-09-16 | 1616d | start no earlier than 2021-09-16 | 0.0% | 0.0% | 0.0% | No BL | No BL | -1014 | On Target |
| 672 | 5.3.4.14 | MES Risk and Issue Meeting 14 | 1d | 2021-09-30 | 2021-09-30 | 1606d | start no earlier than 2021-09-30 | 0.0% | 0.0% | 0.0% | No BL | No BL | -1014 | On Target |
| 673 | 5.3.4.15 | MES Risk and Issue Meeting 15 | 1d | 2021-10-14 | 2021-10-14 | 1597d | start no earlier than 2021-10-14 | 0.0% | 0.0% | 0.0% | No BL | No BL | -1014 | On Target |
| 674 | 5.3.4.16 | MES Risk and Issue Meeting 16 | 1d | 2021-10-28 | 2021-10-28 | 1587d | start no earlier than 2021-10-28 | 0.0% | 0.0% | 0.0% | No BL | No BL | -1014 | On Target |
| 675 | 5.3.4.17 | MES Risk and Issue Meeting 17 | 1d | 2021-11-12 | 2021-11-12 | 1577d | start no earlier than 2021-11-11 | 0.0% | 0.0% | 0.0% | No BL | No BL | -1014 | On Target |
| 676 | 5.3.4.18 | MES Risk and Issue Meeting 18 | 1d | 2021-11-29 | 2021-11-29 | 1568d | start no earlier than 2021-11-25 | 0.0% | 0.0% | 0.0% | No BL | No BL | -1014 | On Target |
| 677 | 5.3.4.19 | MES Risk and Issue Meeting 19 | 1d | 2021-12-09 | 2021-12-09 | 1560d | start no earlier than 2021-12-09 | 0.0% | 0.0% | 0.0% | No BL | No BL | -1014 | On Target |
| 678 | 5.3.4.20 | MES Risk and Issue Meeting 20 | 1d | 2021-12-23 | 2021-12-23 | 1550d | start no earlier than 2021-12-23 | 0.0% | 0.0% | 0.0% | No BL | No BL | -1014 | On Target |
| 679 | 5.3.4.21 | MES Risk and Issue Meeting 21 | 1d | 2022-01-06 | 2022-01-06 | 1543d | start no earlier than 2022-01-06 | 0.0% | 0.0% | 0.0% | No BL | No BL | -1014 | On Target |
| 680 | 5.3.4.22 | MES Risk and Issue Meeting 22 | 1d | 2022-01-20 | 2022-01-20 | 1534d | start no earlier than 2022-01-20 | 0.0% | 0.0% | 0.0% | No BL | No BL | -1014 | On Target |
| 681 | 5.3.4.23 | MES Risk and Issue Meeting 23 | 1d | 2022-02-03 | 2022-02-03 | 1524d | start no earlier than 2022-02-03 | 0.0% | 0.0% | 0.0% | No BL | No BL | -1014 | On Target |
| 682 | 5.3.4.24 | MES Risk and Issue Meeting 24 | 1d | 2022-02-17 | 2022-02-17 | 1514d | start no earlier than 2022-02-17 | 0.0% | 0.0% | 0.0% | No BL | No BL | -1014 | On Target |
| 683 | 5.3.4.25 | MES Risk and Issue Meeting 25 | 1d | 2022-03-03 | 2022-03-03 | 1505d | start no earlier than 2022-03-03 | 0.0% | 0.0% | 0.0% | No BL | No BL | -1014 | On Target |
| 684 | 5.3.4.26 | MES Risk and Issue Meeting 26 | 1d | 2022-03-17 | 2022-03-17 | 1495d | start no earlier than 2022-03-17 | 0.0% | 0.0% | 0.0% | No BL | No BL | -1014 | On Target |
| 685 | 5.3.4.27 | MES Risk and Issue Meeting 27 | 1d | 2022-03-31 | 2022-03-31 | 1485d | start no earlier than 2022-03-31 | 0.0% | 0.0% | 0.0% | No BL | No BL | -1014 | On Target |
| 686 | 5.3.4.28 | MES Risk and Issue Meeting 28 | 1d | 2022-04-14 | 2022-04-14 | 1475d | start no earlier than 2022-04-14 | 0.0% | 0.0% | 0.0% | No BL | No BL | -1014 | On Target |
| 687 | 5.3.4.29 | MES Risk and Issue Meeting 29 | 1d | 2022-04-28 | 2022-04-28 | 1466d | start no earlier than 2022-04-28 | 0.0% | 0.0% | 0.0% | No BL | No BL | -1014 | On Target |
| 688 | 5.3.4.30 | MES Risk and Issue Meeting 30 | 1d | 2022-05-12 | 2022-05-12 | 1456d | start no earlier than 2022-05-12 | 0.0% | 0.0% | 0.0% | No BL | No BL | -1014 | On Target |
| 689 | 5.3.4.31 | MES Risk and Issue Meeting 31 | 1d | 2022-05-26 | 2022-05-26 | 1446d | start no earlier than 2022-05-26 | 0.0% | 0.0% | 0.0% | No BL | No BL | -1014 | On Target |
| 690 | 5.3.4.32 | MES Risk and Issue Meeting 32 | 1d | 2022-06-09 | 2022-06-09 | 1438d | start no earlier than 2022-06-09 | 0.0% | 0.0% | 0.0% | No BL | No BL | -1014 | On Target |
| 691 | 5.3.4.33 | MES Risk and Issue Meeting 33 | 1d | 2022-06-23 | 2022-06-23 | 1428d | start no earlier than 2022-06-23 | 0.0% | 0.0% | 0.0% | No BL | No BL | -1014 | On Target |
| 692 | 5.3.4.34 | MES Risk and Issue Meeting 34 | 1d | 2022-07-07 | 2022-07-07 | 1419d | start no earlier than 2022-07-07 | 0.0% | 0.0% | 0.0% | No BL | No BL | -1014 | On Target |
| 693 | 5.3.4.35 | MES Risk and Issue Meeting 35 | 1d | 2022-07-21 | 2022-07-21 | 1409d | start no earlier than 2022-07-21 | 0.0% | 0.0% | 0.0% | No BL | No BL | -1014 | On Target |
| 694 | 5.3.4.36 | MES Risk and Issue Meeting 36 | 1d | 2022-08-04 | 2022-08-04 | 1399d | start no earlier than 2022-08-04 | 0.0% | 0.0% | 0.0% | No BL | No BL | -1014 | On Target |
| 695 | 5.3.4.37 | MES Risk and Issue Meeting 37 | 1d | 2022-08-18 | 2022-08-18 | 1389d | start no earlier than 2022-08-18 | 0.0% | 0.0% | 0.0% | No BL | No BL | -1014 | On Target |
| 696 | 5.3.4.38 | MES Risk and Issue Meeting 38 | 1d | 2022-09-01 | 2022-09-01 | 1379d | start no earlier than 2022-09-01 | 0.0% | 0.0% | 0.0% | No BL | No BL | -1014 | On Target |
| 697 | 5.3.4.39 | MES Risk and Issue Meeting 39 | 1d | 2022-09-15 | 2022-09-15 | 1370d | start no earlier than 2022-09-15 | 0.0% | 0.0% | 0.0% | No BL | No BL | -1014 | On Target |
| 698 | 5.3.4.40 | MES Risk and Issue Meeting 40 | 1d | 2022-09-29 | 2022-09-29 | 1360d | start no earlier than 2022-09-29 | 0.0% | 0.0% | 0.0% | No BL | No BL | -1014 | On Target |
| 699 | 5.3.4.41 | MES Risk and Issue Meeting 41 | 1d | 2022-10-13 | 2022-10-13 | 1351d | start no earlier than 2022-10-13 | 0.0% | 0.0% | 0.0% | No BL | No BL | -1014 | On Target |
| 700 | 5.3.4.42 | MES Risk and Issue Meeting 42 | 1d | 2022-10-27 | 2022-10-27 | 1341d | start no earlier than 2022-10-27 | 0.0% | 0.0% | 0.0% | No BL | No BL | -1014 | On Target |
| 701 | 5.3.4.43 | MES Risk and Issue Meeting 43 | 1d | 2022-11-10 | 2022-11-10 | 1331d | start no earlier than 2022-11-10 | 0.0% | 0.0% | 0.0% | No BL | No BL | -1014 | On Target |
| 702 | 5.3.4.44 | MES Risk and Issue Meeting 44 | 1d | 2022-11-28 | 2022-11-28 | 1322d | start no earlier than 2022-11-24 | 0.0% | 0.0% | 0.0% | No BL | No BL | -1014 | On Target |
| 703 | 5.3.4.45 | MES Risk and Issue Meeting 45 | 1d | 2022-12-08 | 2022-12-08 | 1314d | start no earlier than 2022-12-08 | 0.0% | 0.0% | 0.0% | No BL | No BL | -1014 | On Target |
| 704 | 5.3.4.46 | MES Risk and Issue Meeting 46 | 1d | 2022-12-22 | 2022-12-22 | 1304d | start no earlier than 2022-12-22 | 0.0% | 0.0% | 0.0% | No BL | No BL | -1014 | On Target |
| 705 | 5.3.4.47 | MES Risk and Issue Meeting 47 | 1d | 2023-01-05 | 2023-01-05 | 1296d | start no earlier than 2023-01-05 | 0.0% | 0.0% | 0.0% | No BL | No BL | -1014 | On Target |
| 706 | 5.3.4.48 | MES Risk and Issue Meeting 48 | 1d | 2023-01-19 | 2023-01-19 | 1287d | start no earlier than 2023-01-19 | 0.0% | 0.0% | 0.0% | No BL | No BL | -1014 | On Target |
| 707 | 5.3.4.49 | MES Risk and Issue Meeting 49 | 1d | 2023-02-02 | 2023-02-02 | 1277d | start no earlier than 2023-02-02 | 0.0% | 0.0% | 0.0% | No BL | No BL | -1014 | On Target |
| 708 | 5.3.4.50 | MES Risk and Issue Meeting 50 | 1d | 2023-02-16 | 2023-02-16 | 1267d | start no earlier than 2023-02-16 | 0.0% | 0.0% | 0.0% | No BL | No BL | -1014 | On Target |
| 709 | 5.3.4.51 | MES Risk and Issue Meeting 51 | 1d | 2023-03-02 | 2023-03-02 | 1258d | start no earlier than 2023-03-02 | 0.0% | 0.0% | 0.0% | No BL | No BL | -1014 | On Target |
| 710 | 5.3.4.52 | MES Risk and Issue Meeting 52 | 1d | 2023-03-16 | 2023-03-16 | 1248d | start no earlier than 2023-03-16 | 0.0% | 0.0% | 0.0% | No BL | No BL | -1014 | On Target |
| 711 | 5.3.4.53 | MES Risk and Issue Meeting 53 | 1d | 2023-03-30 | 2023-03-30 | 1238d | start no earlier than 2023-03-30 | 0.0% | 0.0% | 0.0% | No BL | No BL | -1014 | On Target |
| 712 | 5.3.4.54 | MES Risk and Issue Meeting 54 | 1d | 2023-04-13 | 2023-04-13 | 1228d | start no earlier than 2023-04-13 | 0.0% | 0.0% | 0.0% | No BL | No BL | -1014 | On Target |
| 713 | 5.3.4.55 | MES Risk and Issue Meeting 55 | 1d | 2023-04-27 | 2023-04-27 | 1219d | start no earlier than 2023-04-27 | 0.0% | 0.0% | 0.0% | No BL | No BL | -1014 | On Target |
| 714 | 5.3.4.56 | MES Risk and Issue Meeting 56 | 1d | 2023-05-11 | 2023-05-11 | 1209d | start no earlier than 2023-05-11 | 0.0% | 0.0% | 0.0% | No BL | No BL | -1014 | On Target |
| 715 | 5.3.4.57 | MES Risk and Issue Meeting 57 | 1d | 2023-05-25 | 2023-05-25 | 1199d | start no earlier than 2023-05-25 | 0.0% | 0.0% | 0.0% | No BL | No BL | -1014 | On Target |
| 716 | 5.3.4.58 | MES Risk and Issue Meeting 58 | 1d | 2023-06-08 | 2023-06-08 | 1191d | start no earlier than 2023-06-08 | 0.0% | 0.0% | 0.0% | No BL | No BL | -1014 | On Target |
| 717 | 5.3.4.59 | MES Risk and Issue Meeting 59 | 1d | 2023-06-22 | 2023-06-22 | 1181d | start no earlier than 2023-06-22 | 0.0% | 0.0% | 0.0% | No BL | No BL | -1014 | On Target |
| 718 | 5.3.4.60 | MES Risk and Issue Meeting 60 | 1d | 2023-07-06 | 2023-07-06 | 1172d | start no earlier than 2023-07-06 | 0.0% | 0.0% | 0.0% | No BL | No BL | -1014 | On Target |
| 719 | 5.3.4.61 | MES Risk and Issue Meeting 61 | 1d | 2023-07-20 | 2023-07-20 | 1162d | start no earlier than 2023-07-20 | 0.0% | 0.0% | 0.0% | No BL | No BL | -1014 | On Target |
| 720 | 5.3.4.62 | MES Risk and Issue Meeting 62 | 1d | 2023-08-03 | 2023-08-03 | 1152d | start no earlier than 2023-08-03 | 0.0% | 0.0% | 0.0% | No BL | No BL | -1014 | On Target |
| 721 | 5.3.4.63 | MES Risk and Issue Meeting 63 | 1d | 2023-08-17 | 2023-08-17 | 1142d | start no earlier than 2023-08-17 | 0.0% | 0.0% | 0.0% | No BL | No BL | -1014 | On Target |
| 722 | 5.3.4.64 | MES Risk and Issue Meeting 64 | 1d | 2023-08-31 | 2023-08-31 | 1132d | start no earlier than 2023-08-31 | 0.0% | 0.0% | 0.0% | No BL | No BL | -1014 | On Target |
| 723 | 5.3.4.65 | MES Risk and Issue Meeting 65 | 1d | 2023-09-14 | 2023-09-14 | 1123d | start no earlier than 2023-09-14 | 0.0% | 0.0% | 0.0% | No BL | No BL | -1014 | On Target |
| 724 | 5.3.4.66 | MES Risk and Issue Meeting 66 | 1d | 2023-09-28 | 2023-09-28 | 1113d | start no earlier than 2023-09-28 | 0.0% | 0.0% | 0.0% | No BL | No BL | -1014 | On Target |
| 725 | 5.3.4.67 | MES Risk and Issue Meeting 67 | 1d | 2023-10-12 | 2023-10-12 | 1104d | start no earlier than 2023-10-12 | 0.0% | 0.0% | 0.0% | No BL | No BL | -1014 | On Target |
| 726 | 5.3.4.68 | MES Risk and Issue Meeting 68 | 1d | 2023-10-26 | 2023-10-26 | 1094d | start no earlier than 2023-10-26 | 0.0% | 0.0% | 0.0% | No BL | No BL | -1014 | On Target |
| 727 | 5.3.4.69 | MES Risk and Issue Meeting 69 | 1d | 2023-11-09 | 2023-11-09 | 1084d | start no earlier than 2023-11-09 | 0.0% | 0.0% | 0.0% | No BL | No BL | -1014 | On Target |

| ID | WBS | Task | Type | Duration | Start | Finish | Predecessors | Total slack | Free slack | Constraint | _Current Target | _Baseline Target | _Progress % | _Projected Status | _Baseline % Status | _Days Since Update | _Current % Status | Text18 |
| --- | --- | --- | --- | --- | --- | --- | --- | --- | --- | --- | --- | --- | --- | --- | --- | --- | --- | --- |
| 728 | 5.3.4.70 | MES Risk and Issue Meeting 70 |  | 1d | 2023-11-27 | 2023-11-27 |  | 1075d |  | start no earlier than 2023-11-23 | 0.0% | 0.0% | 0.0% | No BL | No BL | -1014 | On Target |  |
| 729 | 5.3.4.71 | MES Risk and Issue Meeting 71 |  | 1d | 2023-12-07 | 2023-12-07 |  | 1067d |  | start no earlier than 2023-12-07 | 0.0% | 0.0% | 0.0% | No BL | No BL | -1014 | On Target |  |
| 730 | 5.3.4.72 | MES Risk and Issue Meeting 72 |  | 1d | 2023-12-21 | 2023-12-21 |  | 1057d |  | start no earlier than 2023-12-21 | 0.0% | 0.0% | 0.0% | No BL | No BL | -1014 | On Target |  |
| 731 | 6 | **Design, Develop, implement (DDI)** |  | 180d | 2021-04-02 | 2021-12-22 |  | 1411d |  |  | 0.0% | 0.0% | 0.0% | No BL | No BL | -10 | Off Target | Module |
| 732 | 6.1 | **Phase 1 - Project Approach and Scheduling Phase** |  | 30d | 2021-04-02 | 2021-05-14 |  | 1411d |  |  | 0.0% | 0.0% | 0.0% | No BL | No BL | -10 | Off Target |  |
| 733 | 6.1.1 | Key Milestones (See Notes) |  | 6w | 2021-04-02 | 2021-05-14 | 3, 7 | 1411d | 0d |  | 0.0% | 0.0% | 0.0% | No BL | No BL | -1014 | On Target |  |
| 734 | 6.1.2 | M: Phase 1 - Project Approach and Scheduling Phase - Complete | milestone | 0d | 2021-05-14 | 2021-05-14 | 733 | 1561d | 150d |  | 0.0% | 0.0% | 0.0% | No BL | No BL | -1014 | On Target |  |
| 735 | 6.2 | **Phase 2 - Design Phase** |  | 50d | 2021-05-03 | 2021-07-14 |  | 1411d |  |  | 0.0% | 0.0% | 0.0% | No BL | No BL | -10 | Off Target |  |
| 736 | 6.2.1 | Key Milestones (See Notes) |  | 10w | 2021-05-03 | 2021-07-14 | 733FS-2w | 1411d | 0d |  | 0.0% | 0.0% | 0.0% | No BL | No BL | -1014 | On Target |  |
| 737 | 6.2.2 | M: Phase 2 - Design Phase - Complete | milestone | 0d | 2021-07-14 | 2021-07-14 | 736 | 1521d | 110d |  | 0.0% | 0.0% | 0.0% | No BL | No BL | -1014 | On Target |  |
| 738 | 6.3 | **Phase 3 - Development Phase** |  | 40d | 2021-08-12 | 2021-10-07 |  | 1411d |  |  | 0.0% | 0.0% | 0.0% | No BL | No BL | -10 | Off Target |  |
| 739 | 6.3.1 | Key Milestones (See Notes) |  | 8w | 2021-08-12 | 2021-10-07 | 736FS+4w | 1411d | 0d |  | 0.0% | 0.0% | 0.0% | No BL | No BL | -1014 | On Target |  |
| 740 | 6.3.2 | M: Phase 3 - Development Phae - Complete | milestone | 0d | 2021-10-07 | 2021-10-07 | 739 | 1461d | 50d |  | 0.0% | 0.0% | 0.0% | No BL | No BL | -1014 | On Target |  |
| 741 | 6.4 | **Phase 4 - Conversion Phase** |  | 40d | 2021-08-12 | 2021-10-07 |  | 1411d |  |  | 0.0% | 0.0% | 0.0% | No BL | No BL | -10 | Off Target |  |
| 742 | 6.4.1 | Key Milestones (See Notes) |  | 8w | 2021-08-12 | 2021-10-07 | 736FS+4w | 1411d | 0d |  | 0.0% | 0.0% | 0.0% | No BL | No BL | -1014 | On Target |  |
| 743 | 6.4.2 | M: Phase 4 - Conversion Phase - Complete | milestone | 0d | 2021-10-07 | 2021-10-07 | 742 | 1461d | 50d |  | 0.0% | 0.0% | 0.0% | No BL | No BL | -1014 | On Target |  |
| 744 | 6.5 | **Phase 5 - Testing Phase** |  | 75d | 2021-09-02 | 2021-12-22 |  | 1411d |  |  | 0.0% | 0.0% | 0.0% | No BL | No BL | -10 | Off Target |  |
| 745 | 6.5.1 | Key Milestones (See Notes) |  | 9w | 2021-09-02 | 2021-11-05 | 742FF+4w, 739FF+4w | 1411d | 0d |  | 0.0% | 0.0% | 0.0% | No BL | No BL | -1014 | On Target |  |
| 746 | 6.5.2 | **Training (Will likely span multiple phases)** |  | 30d | 2021-11-08 | 2021-12-22 |  | 1411d |  |  | 0.0% | 0.0% | 0.0% | No BL | No BL | -284 | On Target |  |
| 747 | 6.5.2.1 | Key Milestones (See Notes) |  | 6w | 2021-11-08 | 2021-12-22 | 745 | 1411d | 0d |  | 0.0% | 0.0% | 0.0% | No BL | No BL | -1014 | On Target |  |
| 748 | 6.5.3 | M: Phase 5 - Testing Phase - Complete | milestone | 0d | 2021-11-05 | 2021-11-05 | 745 | 1441d | 30d |  | 0.0% | 0.0% | 0.0% | No BL | No BL | -1014 | On Target |  |
| 749 | 6.6 | **Phase 6 - Implementation Phase** |  | 30d | 2021-11-08 | 2021-12-22 |  | 1411d |  |  | 0.0% | 0.0% | 0.0% | No BL | No BL | -10 | Off Target |  |
| 750 | 6.6.1 | Key Milestones (See Notes) |  | 6w | 2021-11-08 | 2021-12-22 | 745 | 1411d | 0d |  | 0.0% | 0.0% | 0.0% | No BL | No BL | -1014 | On Target |  |
| 751 | 6.6.2 | M: Phase 6 - Implementation Phase - Complete | milestone | 0d | 2021-12-22 | 2021-12-22 | 747, 750 | 1411d | 0d |  | 0.0% | 0.0% | 0.0% | No BL | No BL | -1014 | On Target |  |
| 752 | 6.7 | M: Design Development and Implementation (DDI) - Complete | milestone | 0d | 2021-12-22 | 2021-12-22 | 751, 748, 743, 740, 737, 734 | 1411d | 0d |  | 0.0% | 0.0% | 0.0% | No BL | No BL | -1014 | On Target |  |

Notes:
- 731: This subsection of the SOW defines the tasks associated with the Design, Development and Implementation (DDI) of the Modular Project. The phases are defined for the DDI scope of work include are typically: / 1. Project Approach and Scheduling Phase / 2. Design Phase / 3. Development Phase / 4. Conversion Phase / 5. Testing Phase / 6. Implementation Phase / The objectives for each task have been identified and responsibilities to be fulfilled are outlined under each task below. Initial milestones for each task are listed to ensure that adequate progress can be measured. These milestones must be cross-referenced to the contractor proposed products and approved by Medicaid. / If the contractors system development methodology supports different but equivalent tasks, the contractor must cross-reference the task list as provided to their methodology. The contractor must clearly define the objective, the entrance, and the exit criteria for each phase in their methodology. / All milestones and deliverables defined in the sections below must be approved by Medicaid before payment will be rendered.
- 732: The Project Approach and Scheduling Phase will allow the contractor six (6) weeks to produce the deliverables and finalize scheduling. The activities will include briefings, presentations, and training in the proposed system development life cycle methodology, processes and any software tools the contractor proposes. / The Project approach and scheduling phase will result in all parties the new contractor, the current contractor and all stakeholders understanding the project approach and timeline. This will provide the basis needed for the project to move forward smoothly and successfully. / The contractor shall develop a Project Phase Kick-Off Plan. The Plan will outline coordination of kick-off meetings, material, responsibilities, stakeholders etc. See Section 6.8 Appendix - H Contract Deliverables Table. The contractor shall be responsible for scheduling, developing and coordinating Kick-off meetings for the Modular project. These kick-off meetings will define the purpose of the contractor as well as contain the project timeline, the upcoming task and the actions required of the business / areas.
- 733: The Milestones defined below are due based on the Initial Delivery Due Date and Frequency Schedule defined in Appendix H - Contract Deliverables: / Project Management Status Reporting with risks and issues / Project Plans / Detailed Implementation Schedule / Project Kick-off / Contractor Tool Training (if applicable)
- 735: The objectives of the Design Phase are to identify, plan and document all changes required to transition to the Modular EVV contractor. This phase will provide the detail information for the plans defined in the Project Approach and Scheduling Phase.
- 736: DESIGN PHASE MILESTONES / Project Management Status Reporting with risks, issues and design statistics / Requirements Definition and Gap Assessment / Software Configuration / Edits, Audits and Error Messages / Detail Design (if needed) / Companion Guide / User Training Plan / User Manual (Including Help Desk, Operations) / Role-based Dashboard / System Back-up and Storage / Requirements Traceability Matrix / Master Test Plan / Re-baseline Project Schedule
- 738: The objectives of the Development Phase are to execute the steps defined in the previous phases.
- 739: DEVELOPMENT PHASE MILESTONES / Project Management Status Reporting with risks, issues development statistics / Configuration of Software / Define Edits, Audits and Error Messages / Code Modification from Detail Design (if needed) / Application of claim status (BRF & 835 transaction) / Implementation Schedule / System Definition / Finalized Training Materials / Role-based Dashboard / Mock Data Conversions / Updated Requirements Traceability Matrix / Detail Test Plan / User Manual
- 741: During this phase, the contractor will define their approach or high-level plan to convert the data from the current system to the Modular system. This Data Conversion Plan will provide a high-level overview of the process as well as the template for detail conversion documents. The Modular contractor shall identify any data clean up required, and the process for cleansing the data. The cleansing, mapping or omission of any data will require written justification and Medicaid approval. The contractor shall be required to perform a minimum of two (2) mock data conversions. The results of the mock conversion shall be presented to Medicaid for review. The contractor shall make corrections or perform clean up on the data as requested by Medicaid. This phase may be performed concurrently with the Design Phase.
- 742: CONVERSION PHASE MILESTONES / Project Management Status Reporting with risks, issues and conversion statistics / Data Conversion / System Interface Conversion / Help Desk Start-up and Conversion / Operations Start-up and Conversion
- 744: The objectives of the Testing Phase are to fully test the Modular system. All phases of testing shall use data converted from the current system. All milestones must include updated documentation with changes tracked or a statement that no documentation update was necessary before receiving Medicaid approval. The contractor shall develop a Master Test Plan that describes the test strategy, scope, objectives, resources and processes required for the completion of testing for each phase of the project. Testing results will identify needed changes or defects that the contractor must address in the Modular system.
- 745: TESTING PHASE MILESTONES / Project Management Status Reporting with risks, issues and test statistics / Configuration Test Results / Edits, Audits and Error Messages test results / Application of claim status test results (BRF & 835 transaction) / Code Modification test results (if needed) / Parallel Test/Operational Readiness Results / User Acceptance Testing Support / Regression Testing / Stress Testing / External Interface Testing / Change & Defect Management Plan / Finalize Implementation Plan / Perform Mock Conversions / Updated Manuals and Documentation / Role-based Dashboard / Conduct Training / Updated Requirements Traceability Matrix / Notification to all Stakeholders on Implementation / Written Certification of full functionality / Operational Readiness Review
- 746: The contractor shall develop a User Training Plan which will describe the objectives, requirements, strategies and methodologies for delivering training which shall support the development of knowledge and skills to ensure users of the EVV system can perform their roles efficiently and effectively. Execution of training shall be included in these section as well.
- 747: Training Milestones/ Identify Role-based training needs / Design/develop Role-based training needs / Obtain approval of Role-based training needs / Execute Training / Outreach/Followup Training
- 749: During the Implementation Phase, the contractor shall prepare for the start of operations for the Modular project. The contractor will receive and be responsible for system functions as stated in the RFB/RFP.The contractor shall develop an Implementation Plan that provides the approach, activities and detail necessary to complete implementation efforts.
- 750: IMPLEMENTATION PHASE MILESTONES / Role-based Dashboard / Project Management Status Reporting with risks and issues / Move Configuration or Code to Production environment / Transition Help Desk / Transition Interfaces / Perform Final Conversions / Updated Requirements Traceability Matrix / Written Certification of full functionality

| ID | WBS | Task | Type | Duration | Start | Finish | Predecessors | Total slack | Free slack | Constraint | _Current Target | _Baseline Target | _Progress % | _Projected Status | _Baseline % Status | _Days Since Update | _Current % Status | Text18 |
| --- | --- | --- | --- | --- | --- | --- | --- | --- | --- | --- | --- | --- | --- | --- | --- | --- | --- | --- |
| 753 | 7 | **Post-Implementation Phase - (3 months Support)** |  | 125d | 2021-12-23 | 2022-06-27 |  | 1426d |  |  | 0.0% | 0.0% | 0.0% | No BL | No BL | -10 | Off Target | Module |
| 754 | 7.1 | Post Go-Live (Daily Meetings 2-weeks) |  | 10d | 2021-12-23 | 2022-01-10 | 752 | 1541d |  |  | 0.0% | 0.0% | 0.0% | No BL | No BL | -1014 | On Target |  |
| 755 | 7.2 | **Turnover** |  | 45d | 2022-01-26 | 2022-03-30 | 752 | 1426d |  |  | 0.0% | 0.0% | 0.0% | No BL | No BL | -80 | On Target |  |
| 756 | 7.2.1 | **Contract Monitoring** |  | 45d | 2022-01-26 | 2022-03-30 |  | 1426d |  |  | 0.0% | 0.0% | 0.0% | No BL | No BL | -80 | Off Target |  |
| 757 | 7.2.1.1 | Define exisitng Activities |  | 5d | 2022-01-26 | 2022-02-01 | 752FS+20d | 1426d | 0d |  | 0.0% | 0.0% | 0.0% | No BL | No BL | -1014 | On Target |  |
| 758 | 7.2.1.2 | Review and update Activities |  | 20d | 2022-02-02 | 2022-03-02 | 757 | 1426d | 0d |  | 0.0% | 0.0% | 0.0% | No BL | No BL | -1014 | On Target |  |
| 759 | 7.2.1.3 | Turnover Activities (Mirror Support) |  | 20d | 2022-03-03 | 2022-03-30 | 758 | 1426d | 0d |  | 0.0% | 0.0% | 0.0% | No BL | No BL | -1014 | On Target |  |
| 760 | 7.2.1.4 | M: Contract Monitoring - Complete | milestone | 0d | 2022-03-30 | 2022-03-30 | 759 | 1426d | 0d |  | 0.0% | 0.0% | 0.0% | No BL | No BL | -1014 | On Target |  |
| 761 | 7.3 | Key Milestones (See Notes) |  | 3mo | 2022-03-31 | 2022-06-27 | 747, 760, 752, 750 | 1426d | 0d |  | 0.0% | 0.0% | 0.0% | No BL | No BL | -1014 | On Target |  |
| 762 | 7.4 | M: Post-Implementation Phase - (3 months Support) - Complete | milestone | 0d | 2022-06-27 | 2022-06-27 | 761 | 1426d |  |  | 0.0% | 0.0% | 0.0% | No BL | No BL | -1014 | On Target |  |
| 763 | 8 | **CMS Certification (Ex. Outcome Based Certification - OBC)** |  | 210d | 2021-09-10 | 2022-07-19 |  | 1411d |  |  | 0.0% | 0.0% | 0.0% | No BL | No BL | -10 | Off Target | Module |
| 764 | 8.1 | **CMS - Operations Readiness Review (Finish prior to go-Live)** |  | 60d | 2021-09-10 | 2021-12-08 |  | 1561d |  | start no earlier than 2021-04-30 | 0.0% | 0.0% | 0.0% | No BL | No BL | -11 | Off Target |  |
| 765 | 8.1.1 | R2 - Operations Milestone Review (Finish prior to go-Live) |  | 3mo | 2021-09-10 | 2021-12-08 | 752FF-10d | 1561d | 0d | finish no earlier than 2021-01-04 | 0.0% | 0.0% | 0.0% | No BL | No BL | -1014 | On Target |  |
| 766 | 8.1.2 | M: Operations Readiness Review (Finish prior to go-Live) - Complete | milestone | 0mo | 2021-12-08 | 2021-12-08 | 765 | 1561d | 0d |  | 0.0% | 0.0% | 0.0% | No BL | No BL | -1014 | On Target |  |
| 767 | 8.2 | **CMS - Certification Review - (6 months after Go-Live)** |  | 140d | 2021-12-23 | 2022-07-19 |  | 1411d | 0d |  | 0.0% | 0.0% | 0.0% | No BL | No BL | -11 | On Target |  |
| 768 | 8.2.1 | Report on KPIs |  | 6mo | 2021-12-23 | 2022-06-20 | 752 | 1411d | 0d |  | 0.0% | 0.0% | 0.0% | No BL | No BL | -1014 | On Target |  |
| 769 | 8.2.2 | Certification Review |  | 1mo | 2022-06-21 | 2022-07-19 | 768 | 1411d | 0d |  | 0.0% | 0.0% | 0.0% | No BL | No BL | -1014 | On Target |  |
| 770 | 8.2.3 | M: CMS Certification (OBC) - Complete | milestone | 0d | 2022-07-19 | 2022-07-19 | 769 | 1411d | 0d |  | 0.0% | 0.0% | 0.0% | No BL | No BL | -1014 | On Target |  |
| 771 | 8.3 | M: CMS Certification (Ex. Outcome Based Certification - OBC) - Complete | milestone | 0d | 2022-07-19 | 2022-07-19 | 770, 766 | 1411d | 0d |  | 0.0% | 0.0% | 0.0% | No BL | No BL | -1014 | On Target |  |
| 772 | 8.4 | M: Modular transition to Base MMIS Operations | milestone | 0d | 2022-07-19 | 2022-07-19 | 770 | 1411d | 0d |  | 0.0% | 0.0% | 0.0% | No BL | No BL | -1014 | On Target |  |
| 773 | 9 | **Module Contract Period (ex. 3 years + (4) 1 year optional extensions)** |  | 1731d | 2021-04-01 | 2028-03-31 |  | 0d |  |  | 0.0% | 0.0% | 0.0% | No BL | No BL | -10 | Off Target | Module |
| 774 | 9.1 | 3-year Base (As Needed) |  | 1095ed | 2021-04-01 | 2024-03-31 | 3 | 0d |  |  | 0.0% | 0.0% | 0.0% | No BL | No BL | -1014 | On Target |  |
| 775 | 9.2 | 1-year Optional Extension (As Needed) |  | 365ed | 2024-03-31 | 2025-03-31 | 774 | 0d |  |  | 0.0% | 0.0% | 0.0% | No BL | No BL | -1014 | On Target |  |
| 776 | 9.3 | 1-year Optional Extension (As Needed) |  | 365ed | 2025-03-31 | 2026-03-31 | 775 | 0d |  |  | 0.0% | 0.0% | 0.0% | No BL | No BL | -1014 | On Target |  |
| 777 | 9.4 | 1-year Optional Extension (As Needed) |  | 365ed | 2026-03-31 | 2027-03-31 | 776 | 0d |  |  | 0.0% | 0.0% | 0.0% | No BL | No BL | -1014 | On Target |  |
| 778 | 9.5 | 1-year Optional Extension (As Needed) |  | 366ed | 2027-03-31 | 2028-03-31 | 777 | 0d |  |  | 0.0% | 0.0% | 0.0% | No BL | No BL | -1014 | On Target |  |
| 779 | 9.6 | M: Module Contract Period (ex. 3 years + (4) 1 year optional extensions) - Complete | milestone | 0ed | 2028-03-31 | 2028-03-31 | 778 | 0d |  |  | 0.0% | 0.0% | 0.0% | No BL | No BL | -1014 | On Target |  |
| 780 | 10 | M: MES_Contractor_Module - Complete | milestone | 0ed | 2028-03-31 | 2028-03-31 | 778, 779, 771, 762, 752 | 0d |  |  | 0.0% | 0.0% | 0.0% | No BL | No BL | -1014 | On Target |  |

Notes:
- 753: The Post Implementation Phase will consist of three (3) months of enhanced support and issue resolution. The contractor shall have increased focus on the resolution of all issues and defects. The Key Performance Indicators and CMS OBC reporting shall be p
- 761: POST IMPLEMENTATION PHASE MILESTONES / Project Management Status Reporting with issues and production statistics / Issue and Defect resolution / Help Desk statistics / Interface statistics / Aggregator statistics / Claim statistics / As a part of the response to this Proposal, the contractor must describe how they plan to perform Section 3.5 Design Development and Implementation.
- 764: Operations Readiness Review (Finish prior to go-Live)
- 767: Certification Review - (6 months after Go-Live)
- 773: Contract Period of RFB (Example) / In accordance with the Code of Alabama Section 22-6-7, establish~a three (3) year fixed contract with an option to extend for four (4) additional 1-year periods not to exceed a total of 7 years~at the same pricing, terms and conditions. / Each 12-month renewal period, if agreed by both parties, would begin the day after the previous contract period expires. Any successive extension must have written approval of both the state and vendor as outlined in the specifications.
- 774: 3 year base
- 775: 1-year Optional Extension
- 776: 1-year Optional Extension
- 777: 1-year Optional Extension
- 778: 1-year Optional Extension
- 779: 1-year Optional Extension
- 780: 1-year Optional Extension
